# BINAK OILFIELD DEVELOPMENT

Schedule from MS Project, 2023-12-16 to 2025-04-21.

## Calendars

- Standard: Mon-Thu 08:00-12:00, 13:00-17:00; Fri off; Sat-Sun 08:00-12:00, 13:00-17:00. Exceptions (off unless hours are given): 2024-03-16 to 2024-04-01 (نوروز 1403), 2025-03-16 to 2025-04-01 (نوروز 1404).

## Schedule

| ID | WBS | Task | Type | Duration | Start | Finish | Predecessors | Total slack | Free slack | Constraint | شروع | پایان | Text3 |
| --- | --- | --- | --- | --- | --- | --- | --- | --- | --- | --- | --- | --- | --- |
| 1 | 1 | **Key milestones** |  | 393d | 2023-12-16 | 2025-04-21 |  | 0d |  |  | 1402/9/25 | 1404/2/1 |  |
| 2 | 1.1 | DP - (Effective Date) پس از تکمیل پیش پرداخت | milestone | 0d | 2024-02-20 | 2024-02-20 |  | 336d |  | start no earlier than 2024-02-20 | 1402/12/1 | 1402/12/1 |  |
| 3 | 1.2 | Engineering Start | milestone | 0d | 2023-12-16 | 2023-12-16 |  | 0d |  |  | 1402/9/25 | 1402/9/25 |  |
| 4 | 1.3 | procument start | milestone | 0d | 2024-06-12 | 2024-06-12 | 217SS | 254d |  |  | 1403/3/23 | 1403/3/23 |  |
| 5 | 1.4 | Procument Finish | milestone | 0d | 2025-03-13 | 2025-03-13 | 253 | 18d |  |  | 1403/12/23 | 1403/12/23 |  |
| 6 | 1.5 | Engineering Finish | milestone | 0d | 2024-05-14 | 2024-05-14 | 15 | 278d |  |  | 1403/2/25 | 1403/2/25 |  |
| 7 | 1.6 | Fabrication start | milestone | 0d | 2025-01-28 | 2025-01-28 | 355 | 56d |  |  | 1403/11/9 | 1403/11/9 |  |
| 8 | 1.7 | Project Finish | milestone | 0d | 2025-04-21 | 2025-04-21 | 1107, 1109, 1111, 1113, 1115, 1117, 1119, 1121, 1123, 1125, 1127, 1129, 1131, 1133, 1135 | 0d |  |  | 1404/2/1 | 1404/2/1 |  |
| 9 | 2 | **Engineering** |  | 263d | 2023-12-16 | 2024-11-03 |  | 0d |  |  | 1402/9/25 | 1403/8/13 |  |
| 10 | 2.1 | **General Document** |  | 263d | 2023-12-16 | 2024-11-03 |  | 0d |  |  | 1402/9/25 | 1403/8/13 |  |
| 11 | 2.1.1 | **PROJECT MANAGEMENT DOCUMENTS** |  | 263d | 2023-12-16 | 2024-11-03 |  | 0d |  |  | 1402/9/25 | 1403/8/13 |  |
| 12 | 2.1.1.1 | WORK BREAKDOWN STRUCTURE FOR GAS DEHYDRATION PACKAGE |  | 40d | 2023-12-19 | 2024-02-03 | 13SS+3d | 167d | 0d |  | 1402/9/28 | 1402/11/14 |  |
| 13 | 2.1.1.2 | VENDOR PRINT INDEX & SCHEDULE (VPIS) FOR GAS DEHYDRATION PACKAGE |  | 40d | 2023-12-16 | 2024-01-30 | 3 | 0d |  |  | 1402/9/25 | 1402/11/10 |  |
| 14 | 2.1.1.3 | TIME SCHEDULE FOR GAS DEHYDRATION PACKAGE |  | 40d | 2023-12-19 | 2024-02-03 | 12SS | 167d | 0d |  | 1402/9/28 | 1402/11/14 |  |
| 15 | 2.1.1.4 | FINAL VENDOR DATA BOOK INDEX FOR GAS DEHYDRATION PACKAGE |  | 30d | 2024-04-10 | 2024-05-14 | 38SS+45d | 278d | 0d |  | 1403/1/22 | 1403/2/25 |  |
| 16 | 2.1.1.5 | SHIPPING & INSTALLATION MANUAL (INCLUDING HANDLING, TRANSPORTATION, STORAGE AND ERECTION) FOR GAS DEHYDRATION PACKAGE |  | 50d | 2024-09-07 | 2024-11-03 | 18SS+2d | 130d |  |  | 1403/6/17 | 1403/8/13 |  |
| 17 | 2.1.1.6 | SUB-VENDOR LIST FOR GAS DEHYDRATION PACKAGE |  | 50d | 2024-04-16 | 2024-06-12 | 65SS | 86d | 0d |  | 1403/1/28 | 1403/3/23 |  |
| 18 | 2.1.1.7 | MARKING & PACKING PROCEDURE FOR GAS DEHYDRATION PACKAGE (TOWER, REBOILER, DRUMS, FILTERS, COLUMNS, EXCHANGERS) |  | 50d | 2024-09-04 | 2024-10-31 | 19SS+5d | 130d | 0d |  | 1403/6/14 | 1403/8/10 |  |
| 19 | 2.1.1.8 | MARKING & PACKING PROCEDURE FOR GLYCOL CIRCULATION PUMPS |  | 50d | 2024-08-29 | 2024-10-26 | 244SS+10d | 130d | 0d |  | 1403/6/8 | 1403/8/5 |  |
| 20 | 2.1.2 | **QUALITY CONTROL DOCUMENTS** |  | 106d | 2024-03-10 | 2024-07-28 |  | 167d |  |  | 1402/12/20 | 1403/5/7 |  |
| 21 | 2.1.2.1 | INSPECTION AND TEST PLAN FOR GAS DEHYDRATION PACKAGE |  | 50d | 2024-03-10 | 2024-05-23 | 14FS+30d | 167d | 0d |  | 1402/12/20 | 1403/3/3 |  |
| 22 | 2.1.2.2 | NDE PERSONNEL QUALIFICATION LIST FOR GAS DEHYDRATION PACKAGE |  | 50d | 2024-05-27 | 2024-07-23 | 29SS | 167d | 0d |  | 1403/3/7 | 1403/5/2 |  |
| 23 | 2.1.2.3 | HARDNESS TESTING PROCEDURE FOR GAS DEHYDRATION PACKAGE (TOWER, COLUMNS, REBOILER, DRUMS, FILTERS & EXCHANGERS) |  | 50d | 2024-05-07 | 2024-07-03 | 27SS+3d | 202d | 159d |  | 1403/2/18 | 1403/4/13 |  |
| 24 | 2.1.2.4 | SURFACE PREPARATION AND INTERNAL/EXTERNAL PAINTING PROCEDURE FOR TOWER, COLUMNS, REBOILER, DRUMS, FILTERS & EXCHANGERS |  | 50d | 2024-05-28 | 2024-07-24 | 22SS+1d | 167d | 148d |  | 1403/3/8 | 1403/5/3 |  |
| 25 | 2.1.2.5 | PICKLING AND PASSIVATION PROCEDURE FOR GAS DEHYDRATION PACKAGE |  | 50d | 2024-05-28 | 2024-07-24 | 22SS+1d | 181d | 0d |  | 1403/3/8 | 1403/5/3 |  |
| 26 | 2.1.2.6 | POSTWELD HEAT TREATMENT PROCEDURE FOR GAS DEHYDRATION PACKAGE (TOWER, COLUMNS, REBOILER, DRUMS, FILTERS & EXCHANGERS) |  | 50d | 2024-06-01 | 2024-07-28 | 25SS+3d | 181d | 138d |  | 1403/3/12 | 1403/5/7 |  |
| 27 | 2.1.2.7 | WPS & PQR FOR GAS DEHYDRATION PACKAGE (TOWER, COLUMNS, REBOILER, DRUMS, FILTERS & EXCHANGERS) |  | 50d | 2024-05-04 | 2024-06-30 | 31SS+10d | 167d | 0d |  | 1403/2/15 | 1403/4/10 | 20 |
| 28 | 2.1.2.8 | PMI PROCEDURE FOR GAS DEHYDRATION PACKAGE (TOWER, COLUMNS, REBOILER, DRUMS, FILTERS & EXCHANGERS) |  | 50d | 2024-05-15 | 2024-07-11 | 27SS+10d | 167d | 0d |  | 1403/2/26 | 1403/4/21 |  |
| 29 | 2.1.2.9 | WELDER LIST FOR GAS DEHYDRATION PACKAGE (TOWER, COLUMNS, REBOILER, DRUMS, FILTERS & EXCHANGERS) |  | 50d | 2024-05-27 | 2024-07-23 | 28SS+10d | 167d | 0d |  | 1403/3/7 | 1403/5/2 |  |
| 30 | 2.1.2.10 | NDT PROCEDURE FOR GAS DEHYDRATION PACKAGE (TOWER, COLUMNS, REBOILER, DRUMS, FILTERS & EXCHANGERS) |  | 50d | 2024-04-20 | 2024-06-16 | 21SS+20d | 167d | 0d |  | 1403/2/1 | 1403/3/27 |  |
| 31 | 2.1.2.11 | HYDROSTATIC TESTING PROCEDURE FOR GAS DEHYDRATION PACKAGE (TOWER, COLUMNS, REBOILER, DRUMS & FILTERS) |  | 50d | 2024-04-22 | 2024-06-18 | 30SS+2d | 167d | 0d |  | 1403/2/3 | 1403/3/29 |  |
| 32 | 2.1.2.12 | HYDROSTATIC TEST PROCEDURE FOR HEAT EXCHANGERS |  | 50d | 2024-04-24 | 2024-06-20 | 31SS+2d | 231d | 0d |  | 1403/2/5 | 1403/3/31 |  |
| 33 | 2.1.2.13 | WELD REPAIR PROCEDURE FOR GAS DEHYDRATION PACKAGE |  | 50d | 2024-04-27 | 2024-06-23 | 32SS+2d | 244d |  |  | 1403/2/8 | 1403/4/3 |  |

| ID | WBS | Task | Duration | Start | Finish | Predecessors | Total slack | Free slack | شروع | پایان |
| --- | --- | --- | --- | --- | --- | --- | --- | --- | --- | --- |
| 34 | 2.2 | **Technical Document** | 181d | 2024-01-14 | 2024-08-28 |  | 0d |  | 1402/10/24 | 1403/6/7 |
| 35 | 2.2.1 | **PROCESS DOCUMENTS** | 129d | 2024-01-14 | 2024-06-29 |  | 0d |  | 1402/10/24 | 1403/4/9 |
| 36 | 2.2.1.1 | PROCESS FLOW DIAGRAM FOR GAS DEHYDRATION PACKAGE | 50d | 2024-01-14 | 2024-03-11 | 13SS+25d | 0d |  | 1402/10/24 | 1402/12/21 |
| 37 | 2.2.1.2 | HEAT AND MASS BALANCE FOR GAS DEHYDRATION PACKAGE | 50d | 2024-01-14 | 2024-03-11 | 36SS | 0d |  | 1402/10/24 | 1402/12/21 |
| 38 | 2.2.1.3 | PIPING & INSTRUMENTATION DIAGRAM FOR GAS DEHYDRATION PACKAGE | 50d | 2024-01-31 | 2024-04-15 | 37SS+15d | 0d |  | 1402/11/11 | 1403/1/27 |
| 39 | 2.2.1.4 | UCP LOGIC DESCRIPTION FOR GAS DEHYDRATION PACKAGE | 50d | 2024-03-11 | 2024-05-25 | 47SS+10d | 116d | 0d | 1402/12/21 | 1403/3/5 |
| 40 | 2.2.1.5 | BMS LOGIC DESCRIPTION FOR DEHYDRATION PACKAGE | 50d | 2024-04-03 | 2024-05-30 | 39SS+5d | 247d | 0d | 1403/1/15 | 1403/3/10 |
| 41 | 2.2.1.6 | CAUSE AND EFFECT DIAGRAM FOR GAS DEHYDRATION PACKAGE | 50d | 2024-04-27 | 2024-06-23 | 55SS+10d | 35d | 6d | 1403/2/8 | 1403/4/3 |
| 42 | 2.2.1.7 | PROCESS DATA SHEET FOR DEHYDRATION COLUMN | 50d | 2024-01-30 | 2024-04-14 | 37SS+14d | 19d | 0d | 1402/11/10 | 1403/1/26 |
| 43 | 2.2.1.8 | PROCESS DATA SHEET FOR GLYCOL FLASH DRUM | 50d | 2024-02-05 | 2024-04-20 | 42SS+5d | 19d | 0d | 1402/11/16 | 1403/2/1 |
| 44 | 2.2.1.9 | PROCESS DATA SHEET FOR GLYCOL CARBON FILTER | 50d | 2024-02-11 | 2024-04-25 | 43SS+5d | 19d | 0d | 1402/11/22 | 1403/2/6 |
| 45 | 2.2.1.10 | PROCESS DATA SHEET FOR GLYCOL STRIPPING COLUMN | 50d | 2024-02-17 | 2024-05-01 | 44SS+5d | 19d | 0d | 1402/11/28 | 1403/2/12 |
| 46 | 2.2.1.11 | PROCESS DATA SHEET FOR GLYCOL STILL COLUMN | 50d | 2024-02-22 | 2024-05-07 | 45SS+5d | 19d | 0d | 1402/12/3 | 1403/2/18 |
| 47 | 2.2.1.12 | PROCESS DATA SHEET FOR GLYCOL CIRCULATION PUMPS | 50d | 2024-02-28 | 2024-05-13 | 46SS+5d | 19d | 0d | 1402/12/9 | 1403/2/24 |
| 48 | 2.2.1.13 | PROCESS DATA SHEET FOR GLYCOL STILL COLUMN CONDENSER | 50d | 2024-03-05 | 2024-05-19 | 47SS+5d | 19d | 0d | 1402/12/15 | 1403/2/30 |
| 49 | 2.2.1.14 | PROCESS DATA SHEET FOR GLYCOL REBOILER | 50d | 2024-03-11 | 2024-05-25 | 48SS+5d | 24d | 5d | 1402/12/21 | 1403/3/5 |
| 50 | 2.2.1.15 | PROCESS DATA SHEET FOR GLYCOL SURGE VESSEL | 50d | 2024-02-11 | 2024-04-25 | 43SS+5d | 44d | 25d | 1402/11/22 | 1403/2/6 |
| 51 | 2.2.1.16 | PROCESS DATA SHEET FOR GLYCOL PARTICLE FILTER | 50d | 2024-04-03 | 2024-05-30 | 52SS+5d | 19d | 0d | 1403/1/15 | 1403/3/10 |
| 52 | 2.2.1.17 | PROCESS DATA SHEET FOR LEAN GLYCOL DRY GAS HEAT EXCHSNGER | 50d | 2024-03-11 | 2024-05-25 | 48SS+5d | 19d | 0d | 1402/12/21 | 1403/3/5 |
| 53 | 2.2.1.18 | PROCESS DATA SHEET FOR RICH / LEAN GLYCOL HEAT EXCHANGER | 50d | 2024-04-03 | 2024-05-30 | 52SS+5d | 19d | 0d | 1403/1/15 | 1403/3/10 |
| 54 | 2.2.1.19 | EQUIPMENT LIST FOR GAS DEHYDRATION PACKAGE | 50d | 2024-04-09 | 2024-06-05 | 49SS+5d, 50SS+10d, 51SS+5d, 53SS+5d | 19d | 0d | 1403/1/21 | 1403/3/16 |
| 55 | 2.2.1.20 | ALARM & TRIP SET POINT LIST FOR GAS DEHYDRATION PACKAGE | 50d | 2024-04-15 | 2024-06-11 | 54SS+5d | 19d | 0d | 1403/1/27 | 1403/3/22 |
| 56 | 2.2.1.21 | UTILITY CONSUMPTION LIST FOR GAS DEHYDRATION PACKAGE | 50d | 2024-04-21 | 2024-06-17 | 55SS+5d | 19d | 0d | 1403/2/2 | 1403/3/28 |
| 57 | 2.2.1.22 | CHEMICAL CONSUMPTION LIST FOR GAS DEHYDRATION PACKAGE | 50d | 2024-04-27 | 2024-06-23 | 56SS+5d | 19d | 0d | 1403/2/8 | 1403/4/3 |
| 58 | 2.2.1.23 | OPERATION, COMMISSIONING & MAINTENANCE MANUAL FOR GAS DEHYDRATION PACKAGE | 50d | 2024-04-15 | 2024-06-11 | 39SS+10d, 40SS+10d | 247d | 0d | 1403/1/27 | 1403/3/22 |
| 59 | 2.2.1.24 | PERFORMANCE TEST PROCEDURE FOR GAS DEHYDRATION PACKAGE (SAT Procedure)) | 50d | 2024-04-23 | 2024-06-19 | 58SS+7d | 247d |  | 1403/2/4 | 1403/3/30 |
| 60 | 2.2.1.25 | PROCESS DATA SHEET FOR ANTI-FOAM PACKAGE | 50d | 2024-05-02 | 2024-06-29 | 57SS+5d | 41d | 0d | 1403/2/13 | 1403/4/9 |
| 61 | 2.2.1.26 | PROCESS DATA SHEET FOR PH-CONTROLLER PACKAGE | 50d | 2024-05-02 | 2024-06-29 | 57SS+5d | 19d | 0d | 1403/2/13 | 1403/4/9 |

| ID | WBS | Task | Duration | Start | Finish | Predecessors | Total slack | Free slack | شروع | پایان |
| --- | --- | --- | --- | --- | --- | --- | --- | --- | --- | --- |
| 62 | 2.2.2 | **MECHANICAL DOCUMENT** | 116d | 2024-04-16 | 2024-08-28 |  | 0d |  | 1403/1/28 | 1403/6/7 |
| 63 | 2.2.2.1 | **FIXED EQUIPMENT** | 116d | 2024-04-16 | 2024-08-28 |  | 9d |  | 1403/1/28 | 1403/6/7 |
| 64 | 2.2.2.1.1 | **Glycol Contactor (C-100)** | 107d | 2024-04-16 | 2024-08-18 |  | 13d |  | 1403/1/28 | 1403/5/28 |
| 65 | 2.2.2.1.1.1 | Mechanical Calculation Book for C-100 | 50d | 2024-04-16 | 2024-06-12 | 38 | 13d | 0d | 1403/1/28 | 1403/3/23 |
| 66 | 2.2.2.1.1.2 | Lifting Calculation Book for C-100 | 50d | 2024-04-16 | 2024-06-12 | 65SS | 13d | 0d | 1403/1/28 | 1403/3/23 |
| 67 | 2.2.2.1.1.3 | General Arrangement Drawing for C-100 | 50d | 2024-05-04 | 2024-06-30 | 66SS+15d | 13d | 0d | 1403/2/15 | 1403/4/10 |
| 68 | 2.2.2.1.1.4 | Detail of Body for C-100 | 50d | 2024-05-21 | 2024-07-17 | 67SS+15d | 13d | 0d | 1403/3/1 | 1403/4/27 |
| 69 | 2.2.2.1.1.5 | NOZZLE & Manhole Detail Drawing for C-100 | 50d | 2024-06-04 | 2024-07-31 | 68SS+12d | 23d | 0d | 1403/3/15 | 1403/5/10 |
| 70 | 2.2.2.1.1.6 | External Attachment Drawing for C-100 | 50d | 2024-06-08 | 2024-08-04 | 69SS+3d | 102d | 0d | 1403/3/19 | 1403/5/14 |
| 71 | 2.2.2.1.1.7 | Internal Welded Attachments for C-100 | 50d | 2024-06-11 | 2024-08-07 | 70SS+3d | 102d | 0d | 1403/3/22 | 1403/5/17 |
| 72 | 2.2.2.1.1.8 | Name Plate Detail Drawing for C-100 | 50d | 2024-06-15 | 2024-08-11 | 71SS+3d | 102d | 0d | 1403/3/26 | 1403/5/21 |
| 73 | 2.2.2.1.1.9 | NDT Map for C-100 | 50d | 2024-06-18 | 2024-08-14 | 72SS+3d | 102d | 0d | 1403/3/29 | 1403/5/24 |
| 74 | 2.2.2.1.1.10 | Welding Map for C-100 | 50d | 2024-06-22 | 2024-08-18 | 73SS+3d | 102d | 77d | 1403/4/2 | 1403/5/28 |
| 75 | 2.2.2.1.2 | **Still Column (C-200)** | 75d | 2024-04-16 | 2024-07-11 |  | 30d |  | 1403/1/28 | 1403/4/21 |
| 76 | 2.2.2.1.2.1 | Mechanical Calculation Book for C-200 | 50d | 2024-04-16 | 2024-06-12 | 38 | 30d | 0d | 1403/1/28 | 1403/3/23 |
| 77 | 2.2.2.1.2.2 | General Arrangement Drawing for C-200 | 50d | 2024-04-28 | 2024-06-24 | 76SS+10d | 30d | 0d | 1403/2/9 | 1403/4/4 |
| 78 | 2.2.2.1.2.3 | Detail of Body & Nozzle drawing for C-200 | 50d | 2024-05-01 | 2024-06-27 | 77SS+3d | 30d | 0d | 1403/2/12 | 1403/4/7 |
| 79 | 2.2.2.1.2.4 | Name Plate Detail Drawing for C-200 | 50d | 2024-05-05 | 2024-07-01 | 78SS+3d | 172d | 0d | 1403/2/16 | 1403/4/11 |
| 80 | 2.2.2.1.2.5 | Internal Welded & External Attachments for C-200 | 50d | 2024-05-08 | 2024-07-04 | 79SS+3d | 172d | 0d | 1403/2/19 | 1403/4/14 |
| 81 | 2.2.2.1.2.6 | NDT Map for C-200 | 50d | 2024-05-12 | 2024-07-08 | 80SS+3d | 172d | 0d | 1403/2/23 | 1403/4/18 |
| 82 | 2.2.2.1.2.7 | Welding Map for C-200 | 50d | 2024-05-15 | 2024-07-11 | 81SS+3d | 172d | 108d | 1403/2/26 | 1403/4/21 |
| 83 | 2.2.2.1.3 | **Stripping Column (C-300)** | 84d | 2024-04-24 | 2024-07-30 |  | 2d |  | 1403/2/5 | 1403/5/9 |
| 84 | 2.2.2.1.3.1 | Mechanical Calculation Book for C-300 | 50d | 2024-04-24 | 2024-06-20 | 38FS+7d | 2d | 0d | 1403/2/5 | 1403/3/31 |
| 85 | 2.2.2.1.3.2 | General Arrangement Drawing for C-300 | 50d | 2024-05-06 | 2024-07-02 | 84SS+10d | 11d | 0d | 1403/2/17 | 1403/4/12 |
| 86 | 2.2.2.1.3.3 | Detail drawing for C-300 | 50d | 2024-05-23 | 2024-07-20 | 85SS+15d | 11d | 0d | 1403/3/3 | 1403/4/30 |
| 87 | 2.2.2.1.3.4 | Name Plate Detail Drawing for C-300 | 50d | 2024-05-27 | 2024-07-23 | 86SS+3d | 158d | 0d | 1403/3/7 | 1403/5/2 |
| 88 | 2.2.2.1.3.5 | NDT Map for C-300 | 50d | 2024-05-30 | 2024-07-27 | 87SS+3d | 158d | 0d | 1403/3/10 | 1403/5/6 |
| 89 | 2.2.2.1.3.6 | Welding Map for C-300 | 50d | 2024-06-03 | 2024-07-30 | 88SS+3d | 158d | 91d | 1403/3/14 | 1403/5/9 |

| ID | WBS | Task | Duration | Start | Finish | Predecessors | Total slack | Free slack | شروع | پایان |
| --- | --- | --- | --- | --- | --- | --- | --- | --- | --- | --- |
| 90 | 2.2.2.1.4 | **Glycol Flash Drum (V-120)** | 89d | 2024-04-24 | 2024-08-05 |  | 2d |  | 1403/2/5 | 1403/5/15 |
| 91 | 2.2.2.1.4.1 | Mechanical & Lifting Calculation Book for V-120 | 50d | 2024-04-24 | 2024-06-20 | 84SS | 2d | 0d | 1403/2/5 | 1403/3/31 |
| 92 | 2.2.2.1.4.2 | General Arrangement Drawing for V-120 | 50d | 2024-05-06 | 2024-07-02 | 91SS+10d | 31d | 0d | 1403/2/17 | 1403/4/12 |
| 93 | 2.2.2.1.4.3 | Detail of Body for V-120 | 50d | 2024-05-22 | 2024-07-18 | 92SS+14d | 31d | 0d | 1403/3/2 | 1403/4/28 |
| 94 | 2.2.2.1.4.4 | Nozzle & Manhole Detail Drawing for V-120 | 50d | 2024-05-26 | 2024-07-22 | 93SS+3d | 31d | 0d | 1403/3/6 | 1403/5/1 |
| 95 | 2.2.2.1.4.5 | External Attachments & Saddle drawing for V-120 | 50d | 2024-05-29 | 2024-07-25 | 94SS+3d | 139d | 0d | 1403/3/9 | 1403/5/4 |
| 96 | 2.2.2.1.4.6 | Name Plate Detail Drawing for V-120 | 50d | 2024-06-02 | 2024-07-29 | 95SS+3d | 139d | 0d | 1403/3/13 | 1403/5/8 |
| 97 | 2.2.2.1.4.7 | NDT Map for V-120 | 50d | 2024-06-05 | 2024-08-01 | 96SS+3d | 139d | 0d | 1403/3/16 | 1403/5/11 |
| 98 | 2.2.2.1.4.8 | Welding Map for V-120 | 50d | 2024-06-09 | 2024-08-05 | 97SS+3d | 139d | 87d | 1403/3/20 | 1403/5/15 |
| 99 | 2.2.2.1.5 | **Particle Glycol Filter (F-100 A/B)** | 66d | 2024-04-24 | 2024-07-09 |  | 2d |  | 1403/2/5 | 1403/4/19 |
| 100 | 2.2.2.1.5.1 | Mechanical Calculation Book for F-100 | 50d | 2024-04-24 | 2024-06-20 | 91SS | 2d | 0d | 1403/2/5 | 1403/3/31 |
| 101 | 2.2.2.1.5.2 | General Arrangement Drawing for F-100 | 50d | 2024-05-06 | 2024-07-02 | 100SS+10d | 80d | 0d | 1403/2/17 | 1403/4/12 |
| 102 | 2.2.2.1.5.3 | Detail Drawing for F-100 | 50d | 2024-05-09 | 2024-07-06 | 101SS+3d | 174d | 0d | 1403/2/20 | 1403/4/16 |
| 103 | 2.2.2.1.5.4 | Name Plate Detail Drawing for F-100 | 50d | 2024-05-13 | 2024-07-09 | 102SS+3d | 230d |  | 1403/2/24 | 1403/4/19 |
| 104 | 2.2.2.1.6 | **Glycol Filter (F-200)** | 67d | 2024-04-24 | 2024-07-10 |  | 2d |  | 1403/2/5 | 1403/4/20 |
| 105 | 2.2.2.1.6.1 | Mechanical Calculation Book for F-200 | 50d | 2024-04-24 | 2024-06-20 | 100SS | 2d | 0d | 1403/2/5 | 1403/3/31 |
| 106 | 2.2.2.1.6.2 | General Arrangement Drawing for F-200 | 50d | 2024-05-06 | 2024-07-02 | 105SS+10d | 22d | 0d | 1403/2/17 | 1403/4/12 |
| 107 | 2.2.2.1.6.3 | Detail Drawing for F-200 | 50d | 2024-05-11 | 2024-07-07 | 106SS+4d | 22d | 0d | 1403/2/22 | 1403/4/17 |
| 108 | 2.2.2.1.6.4 | Name Plate Detail Drawing for F-200 | 50d | 2024-05-14 | 2024-07-10 | 107SS+3d | 229d |  | 1403/2/25 | 1403/4/20 |
| 109 | 2.2.2.1.7 | **Glycol Reflux Condenser (E-100)** | 63d | 2024-04-30 | 2024-07-11 |  | 2d |  | 1403/2/11 | 1403/4/21 |
| 110 | 2.2.2.1.7.1 | Mechanical Calculation Book for E-100 | 50d | 2024-04-30 | 2024-06-26 | 105SS+5d | 2d | 0d | 1403/2/11 | 1403/4/6 |
| 111 | 2.2.2.1.7.2 | General Arrangement Drawing for E-100 | 50d | 2024-05-14 | 2024-07-10 | 110SS+12d | 73d | 3d | 1403/2/25 | 1403/4/20 |
| 112 | 2.2.2.1.7.3 | Detail Drawing for E-100 | 50d | 2024-05-12 | 2024-07-08 | 110SS+10d | 21d | 0d | 1403/2/23 | 1403/4/18 |
| 113 | 2.2.2.1.7.4 | Name Plate Detail Drawing for E-100 | 50d | 2024-05-15 | 2024-07-11 | 112SS+3d | 228d |  | 1403/2/26 | 1403/4/21 |

| ID | WBS | Task | Duration | Start | Finish | Predecessors | Total slack | Free slack | شروع | پایان |
| --- | --- | --- | --- | --- | --- | --- | --- | --- | --- | --- |
| 114 | 2.2.2.1.8 | **Rich-Lean Glycol Heat Exchanger (E-200)** | 78d | 2024-04-30 | 2024-07-29 |  | 2d |  | 1403/2/11 | 1403/5/8 |
| 115 | 2.2.2.1.8.1 | Mechanical Calculation Book for E-200 | 50d | 2024-04-30 | 2024-06-26 | 110SS | 2d | 0d | 1403/2/11 | 1403/4/6 |
| 116 | 2.2.2.1.8.2 | General Arrangement Drawing for E-200 | 50d | 2024-05-12 | 2024-07-08 | 115SS+10d | 7d | 0d | 1403/2/23 | 1403/4/18 |
| 117 | 2.2.2.1.8.3 | Detail Drawing for E-200 | 50d | 2024-05-28 | 2024-07-24 | 116SS+14d | 7d | 0d | 1403/3/8 | 1403/5/3 |
| 118 | 2.2.2.1.8.4 | Name Plate Detail Drawing for E-200 | 50d | 2024-06-02 | 2024-07-29 | 117SS+4d | 213d |  | 1403/3/13 | 1403/5/8 |
| 119 | 2.2.2.1.9 | **Lean Glycol-Dry Gas Heat Exchanger (E-300)** | 75d | 2024-04-30 | 2024-07-25 |  | 2d |  | 1403/2/11 | 1403/5/4 |
| 120 | 2.2.2.1.9.1 | Mechanical Calculation Book for E-300 | 50d | 2024-04-30 | 2024-06-26 | 115SS | 2d | 0d | 1403/2/11 | 1403/4/6 |
| 121 | 2.2.2.1.9.2 | General Arrangement Drawing for E-300 | 50d | 2024-05-12 | 2024-07-08 | 120SS+10d | 75d | 0d | 1403/2/23 | 1403/4/18 |
| 122 | 2.2.2.1.9.3 | Detail Drawing for E-300 | 50d | 2024-05-26 | 2024-07-22 | 121SS+12d | 132d | 0d | 1403/3/6 | 1403/5/1 |
| 123 | 2.2.2.1.9.4 | Name Plate Detail Drawing for E-300 | 50d | 2024-05-29 | 2024-07-25 | 122SS+3d | 216d |  | 1403/3/9 | 1403/5/4 |
| 124 | 2.2.2.1.10 | **Reboiler (R-100)** | 99d | 2024-05-06 | 2024-08-28 |  | 2d |  | 1403/2/17 | 1403/6/7 |
| 125 | 2.2.2.1.10.1 | Mechanical & Lifting Calculation Book for R-100 | 50d | 2024-05-06 | 2024-07-02 | 120SS+5d | 2d | 0d | 1403/2/17 | 1403/4/12 |
| 126 | 2.2.2.1.10.2 | General Arrangement Drawing for R-100 | 50d | 2024-05-18 | 2024-07-14 | 125SS+10d | 2d | 0d | 1403/2/29 | 1403/4/24 |
| 127 | 2.2.2.1.10.3 | Detail of Body for R-100 | 50d | 2024-06-03 | 2024-07-30 | 126SS+14d | 2d | 0d | 1403/3/14 | 1403/5/9 |
| 128 | 2.2.2.1.10.4 | Nozzle & Manhole Detail Drawing for R-100 | 50d | 2024-06-15 | 2024-08-11 | 127SS+10d | 14d | 0d | 1403/3/26 | 1403/5/21 |
| 129 | 2.2.2.1.10.5 | Detail of Saddle drawing for R-100 | 50d | 2024-06-18 | 2024-08-14 | 128SS+3d | 128d | 0d | 1403/3/29 | 1403/5/24 |
| 130 | 2.2.2.1.10.6 | Internal & External Welded Attachments for R-100 | 50d | 2024-06-22 | 2024-08-18 | 129SS+3d | 128d | 0d | 1403/4/2 | 1403/5/28 |
| 131 | 2.2.2.1.10.7 | Name Plate Detail Drawing for R-100 | 50d | 2024-06-25 | 2024-08-21 | 130SS+3d | 128d | 0d | 1403/4/5 | 1403/5/31 |
| 132 | 2.2.2.1.10.8 | NDT Map for R-100 | 50d | 2024-06-29 | 2024-08-25 | 131SS+3d | 128d | 0d | 1403/4/9 | 1403/6/4 |
| 133 | 2.2.2.1.10.9 | Welding Map for R-100 | 50d | 2024-07-02 | 2024-08-28 | 132SS+3d | 128d | 66d | 1403/4/12 | 1403/6/7 |
| 134 | 2.2.2.1.11 | **Surge Drum (V-130)** | 86d | 2024-05-06 | 2024-08-13 |  | 2d |  | 1403/2/17 | 1403/5/23 |
| 135 | 2.2.2.1.11.1 | Mechanical & Lifting Calculation Book for V-130 | 50d | 2024-05-06 | 2024-07-02 | 125SS | 2d | 0d | 1403/2/17 | 1403/4/12 |
| 136 | 2.2.2.1.11.2 | General Arrangement Drawing for V-130 | 50d | 2024-05-18 | 2024-07-14 | 135SS+10d | 2d | 0d | 1403/2/29 | 1403/4/24 |
| 137 | 2.2.2.1.11.3 | Detail of Body for V-130 | 50d | 2024-06-03 | 2024-07-30 | 136SS+14d | 2d | 0d | 1403/3/14 | 1403/5/9 |
| 138 | 2.2.2.1.11.4 | Nozzle & Manhole Detail Drawing for V-130 | 50d | 2024-06-06 | 2024-08-03 | 137SS+3d | 21d | 0d | 1403/3/17 | 1403/5/13 |
| 139 | 2.2.2.1.11.5 | External Attachments & Saddle drawing for V-130 | 50d | 2024-06-10 | 2024-08-06 | 138SS+3d | 129d | 0d | 1403/3/21 | 1403/5/16 |
| 140 | 2.2.2.1.11.6 | Name Plate Detail Drawing for V-130 | 50d | 2024-06-13 | 2024-08-10 | 139SS+3d | 129d | 0d | 1403/3/24 | 1403/5/20 |
| 141 | 2.2.2.1.11.7 | NDT Map for V-130 | 50d | 2024-06-17 | 2024-08-13 | 140SS+3d | 200d |  | 1403/3/28 | 1403/5/23 |
| 142 | 2.2.2.1.11.8 | Welding Map for V-130 | 50d | 2024-06-17 | 2024-08-13 | 140SS+3d | 129d | 80d | 1403/3/28 | 1403/5/23 |

| ID | WBS | Task | Duration | Start | Finish | Predecessors | Total slack | Free slack | شروع | پایان |
| --- | --- | --- | --- | --- | --- | --- | --- | --- | --- | --- |
| 143 | 2.2.2.2 | **MACHINERY** | 81d | 2024-04-16 | 2024-07-18 |  | 0d |  | 1403/1/28 | 1403/4/28 |
| 144 | 2.2.2.2.1 | BURNER DATA SHEET FOR GLYCOL REBOILER | 50d | 2024-04-16 | 2024-06-12 | 38 | 0d |  | 1403/1/28 | 1403/3/23 |
| 145 | 2.2.2.2.2 | BURNER DRAWING FOR GLYCOL REBOILER | 50d | 2024-04-24 | 2024-06-20 | 144SS+7d | 77d | 0d | 1403/2/5 | 1403/3/31 |
| 146 | 2.2.2.2.3 | LUBRICATION LIST FOR GAS DEHYDRATION PACKAGE | 50d | 2024-05-06 | 2024-07-02 | 145SS+10d | 77d | 0d | 1403/2/17 | 1403/4/12 |
| 147 | 2.2.2.2.4 | GENERAL ASSEMBLY DRAWING FOR GLYCOL CIRCULATION PUMPS | 50d | 2024-05-09 | 2024-07-06 | 146SS+3d | 77d | 0d | 1403/2/20 | 1403/4/16 |
| 148 | 2.2.2.2.5 | PUMPS CROSS SECTIONAL DRAWING FOR GLYCOL CIRCULATION PUMPS | 50d | 2024-05-14 | 2024-07-10 | 147SS+4d | 229d |  | 1403/2/25 | 1403/4/20 |
| 149 | 2.2.2.2.6 | PUMPS INSTALLATION, OPERATION AND MAINTENANCE MANUAL FOR GLYCOL CIRCULATION PUMPS | 50d | 2024-05-14 | 2024-07-10 | 147SS+4d | 229d |  | 1403/2/25 | 1403/4/20 |
| 150 | 2.2.2.2.7 | NAME PLATE FOR GLYCOL CIRCULATION PUMPS | 50d | 2024-05-16 | 2024-07-13 | 147SS+6d | 222d | 0d | 1403/2/27 | 1403/4/23 |
| 151 | 2.2.2.2.8 | TWO YEARS & COMMISSIONING SPARE PART LIST FOR GLYCOL CIRCULATION PUMPS | 50d | 2024-05-22 | 2024-07-18 | 150SS+5d | 222d |  | 1403/3/2 | 1403/4/28 |
| 152 | 2.2.3 | **STRUCTURE DOCUMENTS** | 56d | 2024-05-07 | 2024-07-10 |  | 141d |  | 1403/2/18 | 1403/4/20 |
| 153 | 2.2.3.1 | STRUCTURAL DESIGN CALCULATION FOR GAS DEHYDRATION PACKAGE | 50d | 2024-05-07 | 2024-07-03 | 67SS+3d | 141d | 0d | 1403/2/18 | 1403/4/13 |
| 154 | 2.2.3.2 | FOUNDATION LOADING DATA FOR GAS DEHYDRATION PACKAGE | 50d | 2024-05-11 | 2024-07-07 | 153SS+3d | 141d | 0d | 1403/2/22 | 1403/4/17 |
| 155 | 2.2.3.3 | STEEL STRUCTURAL DETAIL DRAWING FOR GAS DEHYDRATION PACKAGE | 50d | 2024-05-14 | 2024-07-10 | 154SS+3d | 141d | 107d | 1403/2/25 | 1403/4/20 |
| 156 | 2.2.4 | **PIPING DOCUMENTS** | 74d | 2024-05-09 | 2024-08-03 |  | 29d |  | 1403/2/20 | 1403/5/13 |
| 157 | 2.2.4.1 | 3D MODEL NAVIS FILE AND PDMS DATA BASE (30%) FOR GAS DEHYDRATION PACKAGE | 50d | 2024-05-09 | 2024-07-06 | 38FS+20d | 29d | 0d | 1403/2/20 | 1403/4/16 |
| 158 | 2.2.4.2 | 3D MODEL NAVIS FILE AND PDMS DATA BASE (60%) FOR GAS DEHYDRATION PACKAGE | 40d | 2024-05-21 | 2024-07-06 | 157SS+10d, 41SS+15d | 29d | 0d | 1403/3/1 | 1403/4/16 |
| 159 | 2.2.4.3 | 3D MODEL NAVIS FILE AND PDMS DATA BASE (90%) FOR GAS DEHYDRATION PACKAGE | 40d | 2024-06-02 | 2024-07-17 | 158SS+10d | 29d | 0d | 1403/3/13 | 1403/4/27 |
| 160 | 2.2.4.4 | PACKAGE PLOT PLAN FOR GAS DEHYDRATION PACKAGE | 40d | 2024-06-04 | 2024-07-20 | 159SS+2d | 29d | 0d | 1403/3/15 | 1403/4/30 |
| 161 | 2.2.4.5 | PIPING GENERAL ARRANGEMENT DRAWING FOR GAS DEHYDRATION PACKAGE | 40d | 2024-06-06 | 2024-07-22 | 160SS+2d | 29d | 0d | 1403/3/17 | 1403/5/1 |
| 162 | 2.2.4.6 | PIPING ISOMETRIC DRAWING FOR GAS DEHYDRATION PACKAGE | 40d | 2024-06-09 | 2024-07-24 | 161SS+2d | 29d | 0d | 1403/3/20 | 1403/5/3 |
| 163 | 2.2.4.7 | LINE LIST FOR GAS DEHYDRATION PACKAGE | 40d | 2024-06-11 | 2024-07-27 | 162SS+2d | 209d | 0d | 1403/3/22 | 1403/5/6 |
| 164 | 2.2.4.8 | TIE-IN-LIST FOR GAS DEHYDRATION PACKAGE | 40d | 2024-06-13 | 2024-07-29 | 163SS+2d | 209d | 0d | 1403/3/24 | 1403/5/8 |
| 165 | 2.2.4.9 | SUPPORT LIST FOR GAS DEHYDRATION PACKAGE | 40d | 2024-06-16 | 2024-07-31 | 164SS+2d | 209d | 0d | 1403/3/27 | 1403/5/10 |
| 166 | 2.2.4.10 | STRESS ANALYSIS REPORT FOR GAS DEHYDRATION PACKAGE | 40d | 2024-06-18 | 2024-08-03 | 165SS+2d | 209d |  | 1403/3/29 | 1403/5/13 |

| ID | WBS | Task | Duration | Start | Finish | Predecessors | Total slack | Free slack | شروع | پایان |
| --- | --- | --- | --- | --- | --- | --- | --- | --- | --- | --- |
| 167 | 2.2.5 | **ELECTRICAL DOCUMENTS** | 76d | 2024-04-24 | 2024-07-21 |  | 86d |  | 1403/2/5 | 1403/4/31 |
| 168 | 2.2.5.1 | Electrical single line diagram | 50d | 2024-05-21 | 2024-07-17 | 38SS+25d, 67SS+3d, 77SS+3d, 85SS+3d, 92SS+3d, 101SS+3d, 106SS+3d, 111SS+3d, 116SS+3d, 121SS+3d, 126SS+3d, 136SS+3d, 147SS+3d | 147d | 0d | 1403/3/1 | 1403/4/27 |
| 169 | 2.2.5.2 | Power and control cable list | 50d | 2024-05-25 | 2024-07-21 | 168SS+3d | 147d | 0d | 1403/3/5 | 1403/4/31 |
| 170 | 2.2.5.3 | Earthing detail layout | 50d | 2024-05-22 | 2024-07-18 | 168SS+1d, 172SS+2d, 173SS+2d | 222d |  | 1403/3/2 | 1403/4/28 |
| 171 | 2.2.5.4 | Electrical load list | 50d | 2024-04-24 | 2024-06-20 | 17SS+7d, 47SS+7d | 86d | 0d | 1403/2/5 | 1403/3/31 |
| 172 | 2.2.5.5 | Electrical/Instrument Cable Route Layout | 50d | 2024-05-02 | 2024-06-29 | 171SS+7d | 86d | 15d | 1403/2/13 | 1403/4/9 |
| 173 | 2.2.5.6 | Electrical motor data sheets | 50d | 2024-04-25 | 2024-06-22 | 171SS+1d | 101d | 0d | 1403/2/6 | 1403/4/2 |
| 174 | 2.2.5.7 | Local control station (LCS) panel layout and wiring diagram with connections and dimensions | 50d | 2024-04-27 | 2024-06-23 | 173SS+1d | 101d | 20d | 1403/2/8 | 1403/4/3 |
| 175 | 2.2.6 | **INSTRUMENT DOCUMENTS** | 119d | 2024-02-24 | 2024-07-28 |  | 25d |  | 1402/12/5 | 1403/5/7 |
| 176 | 2.2.6.1 | Instrument list | 50d | 2024-02-24 | 2024-05-08 | 38SS+20d | 25d | 0d | 1402/12/5 | 1403/2/19 |
| 177 | 2.2.6.2 | Input/Output signal list | 50d | 2024-03-06 | 2024-05-20 | 176SS+10d | 25d | 0d | 1402/12/16 | 1403/2/31 |
| 178 | 2.2.6.3 | Instrument and electrical block schematic diagram | 50d | 2024-03-12 | 2024-05-26 | 177SS+5d | 63d | 0d | 1402/12/22 | 1403/3/6 |
| 179 | 2.2.6.4 | UCP system configuration diagram | 50d | 2024-04-07 | 2024-06-03 | 178SS+7d | 63d | 0d | 1403/1/19 | 1403/3/14 |
| 180 | 2.2.6.5 | BMS system configuration diagram | 50d | 2024-04-15 | 2024-06-11 | 179SS+7d | 63d | 0d | 1403/1/27 | 1403/3/22 |
| 181 | 2.2.6.6 | Instrument junction box layout and wiring termination diagram | 50d | 2024-04-25 | 2024-06-22 | 177SS+28d | 102d | 21d | 1403/2/6 | 1403/4/2 |
| 182 | 2.2.6.7 | Burner operation panel layout & wiring diagram with connections & dimensions | 50d | 2024-05-20 | 2024-07-16 | 38SS+25d, 67SS+2d, 77SS+2d, 85SS+2d, 92SS+2d, 101SS+2d, 106SS+2d, 111SS+2d, 116SS+2d, 121SS+2d, 126SS+2d, 136SS+2d, 147SS+2d, 177SS+2d | 81d | 0d | 1403/2/31 | 1403/4/26 |
| 183 | 2.2.6.8 | Control valve calculation sheets | 50d | 2024-02-24 | 2024-05-08 | 38SS+20d | 78d | 0d | 1402/12/5 | 1403/2/19 |
| 184 | 2.2.6.9 | Instrument D.S. for control valves | 50d | 2024-02-27 | 2024-05-12 | 183SS+3d | 78d | 49d | 1402/12/8 | 1403/2/23 |
| 185 | 2.2.6.10 | Instrument cable list | 50d | 2024-05-25 | 2024-07-21 | 177SS+4d, 38SS+25d, 182SS+4d | 147d | 0d | 1403/3/5 | 1403/4/31 |
| 186 | 2.2.6.11 | Instrument D.S. for On/Off valves | 50d | 2024-04-15 | 2024-06-11 | 42 | 21d | 0d | 1403/1/27 | 1403/3/22 |
| 187 | 2.2.6.12 | Instrument D.S. for H2O analyzer | 50d | 2024-04-21 | 2024-06-17 | 186SS+5d | 21d | 0d | 1403/2/2 | 1403/3/28 |
| 188 | 2.2.6.13 | Instrument D.S. for temperature gauge | 50d | 2024-04-24 | 2024-06-20 | 187SS+3d | 29d | 0d | 1403/2/5 | 1403/3/31 |
| 189 | 2.2.6.14 | Instrument D.S. for temperature transmitters | 50d | 2024-04-28 | 2024-06-24 | 188SS+3d | 29d | 0d | 1403/2/9 | 1403/4/4 |
| 190 | 2.2.6.15 | Instrument D.S. for pressure gauges and differential gauges | 50d | 2024-05-01 | 2024-06-27 | 189SS+3d | 29d | 0d | 1403/2/12 | 1403/4/7 |
| 191 | 2.2.6.16 | Instrument D.S. for pressure transmitters and differentia pressure transmitters | 50d | 2024-05-05 | 2024-07-01 | 190SS+3d | 29d | 0d | 1403/2/16 | 1403/4/11 |
| 192 | 2.2.6.17 | Pressure safety valves calculation | 50d | 2024-05-09 | 2024-07-06 | 191SS+4d | 29d | 0d | 1403/2/20 | 1403/4/16 |
| 193 | 2.2.6.18 | Pressure safety valves data sheet | 50d | 2024-05-12 | 2024-07-08 | 38SS+34d, 192SS+2d | 29d | 0d | 1403/2/23 | 1403/4/18 |
| 194 | 2.2.6.19 | Instrument D.S. for pressure regulator valves | 50d | 2024-05-15 | 2024-07-11 | 193SS+3d | 61d | 0d | 1403/2/26 | 1403/4/21 |
| 195 | 2.2.6.20 | Flow element calculation sheets | 50d | 2024-04-16 | 2024-06-12 | 38 | 250d | 0d | 1403/1/28 | 1403/3/23 |
| 196 | 2.2.6.21 | Instrument D.S. for flow elements | 50d | 2024-04-20 | 2024-06-16 | 195SS+3d | 250d |  | 1403/2/1 | 1403/3/27 |
| 197 | 2.2.6.22 | Instrument D.S. for level gauges | 50d | 2024-05-21 | 2024-07-17 | 194SS+5d | 61d | 0d | 1403/3/1 | 1403/4/27 |
| 198 | 2.2.6.23 | Instrument D.S. for level transmitters | 50d | 2024-05-27 | 2024-07-23 | 197SS+5d | 61d | 0d | 1403/3/7 | 1403/5/2 |
| 199 | 2.2.6.24 | Hook up drawing | 50d | 2024-06-01 | 2024-07-28 | 38SS+31d, 198SS+4d, 67SS, 77SS, 85SS+3d, 92SS+3d, 101SS+3d, 106SS+3d, 111SS+3d, 116SS+3d, 121SS+3d, 126SS+3d, 136SS+3d, 147SS+3d | 61d | 0d | 1403/3/12 | 1403/5/7 |
| 200 | 2.2.6.25 | Instrument location layout | 50d | 2024-06-01 | 2024-07-28 | 199SS | 61d | 0d | 1403/3/12 | 1403/5/7 |
| 201 | 2.2.6.26 | Flame scanner data sheet | 50d | 2024-06-01 | 2024-07-28 | 199SS | 214d |  | 1403/3/12 | 1403/5/7 |
| 202 | 2.2.6.27 | UCP panel layout and arrangement | 50d | 2024-04-25 | 2024-06-22 | 38FS+8d | 231d | 0d | 1403/2/6 | 1403/4/2 |
| 203 | 2.2.6.28 | BMS panel layout and arrangement | 50d | 2024-04-29 | 2024-06-25 | 202SS+3d | 242d |  | 1403/2/10 | 1403/4/5 |
| 204 | 2.2.6.29 | UCP system wiring diagram and connections | 50d | 2024-05-01 | 2024-06-27 | 202SS+5d | 240d |  | 1403/2/12 | 1403/4/7 |
| 205 | 2.2.6.30 | BMS system wiring diagram and connections | 50d | 2024-05-04 | 2024-06-30 | 202SS+7d | 238d |  | 1403/2/15 | 1403/4/10 |
| 206 | 2.2.6.31 | UCP and BMS system power consumption list | 50d | 2024-05-05 | 2024-07-01 | 202SS+8d | 237d |  | 1403/2/16 | 1403/4/11 |
| 207 | 2.2.6.32 | Instrument loop diagram | 50d | 2024-05-06 | 2024-07-02 | 202SS+9d | 236d |  | 1403/2/17 | 1403/4/12 |
| 208 | 2.2.6.33 | Modbus IO list (Modbus mapping list) | 50d | 2024-05-07 | 2024-07-03 | 202SS+10d | 235d |  | 1403/2/18 | 1403/4/13 |
| 209 | 2.2.6.34 | FAT procedure for UCP system | 50d | 2024-05-08 | 2024-07-04 | 202SS+11d | 234d |  | 1403/2/19 | 1403/4/14 |
| 210 | 2.2.6.35 | FAT procedure for BMS system | 50d | 2024-05-08 | 2024-07-04 | 202SS+11d | 234d |  | 1403/2/19 | 1403/4/14 |
| 211 | 2.2.6.36 | UCP system Logic diagram | 50d | 2024-05-08 | 2024-07-04 | 202SS+11d | 234d |  | 1403/2/19 | 1403/4/14 |
| 212 | 2.2.6.37 | BMS system Logic diagram | 50d | 2024-05-11 | 2024-07-07 | 202SS+13d | 232d |  | 1403/2/22 | 1403/4/17 |
| 213 | 2.2.6.38 | PRINT OUT OF HMI FOR BMS and UCP | 50d | 2024-05-12 | 2024-07-08 | 202SS+14d | 231d |  | 1403/2/23 | 1403/4/18 |

| ID | WBS | Task | Duration | Start | Finish | Predecessors | Total slack | Free slack | شروع | پایان |
| --- | --- | --- | --- | --- | --- | --- | --- | --- | --- | --- |
| 214 | 3 | **RAW MATERIAL** | 256d | 2024-05-20 | 2025-03-13 |  | 1d |  | 1403/2/31 | 1403/12/23 |
| 215 | 3.1 | **BMS & UCP** | 205d | 2024-05-20 | 2025-01-13 |  | 63d |  | 1403/2/31 | 1403/10/24 |
| 216 | 3.1.1 | PO | 20d | 2024-05-20 | 2024-06-11 | 177SS+30d, 179SS+30d, 180SS+30d, 38 | 63d | 0d | 1403/2/31 | 1403/3/22 |
| 217 | 3.1.2 | Supply/Receive | 185d | 2024-06-12 | 2025-01-13 | 216 | 63d | 0d | 1403/3/23 | 1403/10/24 |
| 218 | 3.2 | **Field Instrument** | 135d | 2024-05-26 | 2024-10-29 |  | 116d |  | 1403/3/6 | 1403/8/8 |
| 219 | 3.2.1 | PO | 15d | 2024-05-26 | 2024-06-11 | 39 | 116d | 0d | 1403/3/6 | 1403/3/22 |
| 220 | 3.2.2 | Supply/Receive | 120d | 2024-06-12 | 2024-10-29 | 219 | 116d | 0d | 1403/3/23 | 1403/8/8 |
| 221 | 3.3 | **Pipe** | 30d | 2024-08-12 | 2024-09-15 |  | 34d |  | 1403/5/22 | 1403/6/25 |
| 222 | 3.3.1 | PO | 5d | 2024-08-12 | 2024-08-17 | 69, 94, 128, 138 | 34d | 0d | 1403/5/22 | 1403/5/27 |
| 223 | 3.3.2 | Supply/Receive | 25d | 2024-08-18 | 2024-09-15 | 222 | 34d | 0d | 1403/5/28 | 1403/6/25 |
| 224 | 3.4 | **plate** | 120d | 2024-06-26 | 2024-11-12 |  | 2d |  | 1403/4/6 | 1403/8/22 |
| 225 | 3.4.1 | PO | 10d | 2024-06-26 | 2024-07-07 | 68SS+20d, 78SS+20d, 86SS+20d, 107SS+20d, 112SS+20d, 117SS+20d, 127SS+20d, 137SS+20d | 2d | 0d | 1403/4/6 | 1403/4/17 |
| 226 | 3.4.2 | Supply/Receive | 110d | 2024-07-08 | 2024-11-12 | 225 | 2d | 0d | 1403/4/18 | 1403/8/22 |
| 227 | 3.5 | **Flange** | 110d | 2024-08-12 | 2024-12-17 |  | 14d |  | 1403/5/22 | 1403/9/27 |
| 228 | 3.5.1 | PO | 5d | 2024-08-12 | 2024-08-17 | 69, 94, 128, 138 | 14d | 0d | 1403/5/22 | 1403/5/27 |
| 229 | 3.5.2 | Supply/Receive | 105d | 2024-08-18 | 2024-12-17 | 228 | 14d | 0d | 1403/5/28 | 1403/9/27 |
| 230 | 3.6 | **Gasket** | 45d | 2025-01-08 | 2025-03-01 |  | 23d |  | 1403/10/19 | 1403/12/11 |
| 231 | 3.6.1 | PO | 5d | 2025-01-08 | 2025-01-13 | 247FS+40d | 23d | 0d | 1403/10/19 | 1403/10/24 |
| 232 | 3.6.2 | Supply/Receive | 40d | 2025-01-14 | 2025-03-01 | 231 | 23d | 0d | 1403/10/25 | 1403/12/11 |
| 233 | 3.7 | **Fitting** | 30d | 2024-07-31 | 2024-09-03 |  | 104d |  | 1403/5/10 | 1403/6/13 |
| 234 | 3.7.1 | PO | 5d | 2024-07-31 | 2024-08-05 | 68, 78, 86, 107, 112, 117, 127, 137 | 104d | 0d | 1403/5/10 | 1403/5/15 |
| 235 | 3.7.2 | Supply/Receive | 25d | 2024-08-06 | 2024-09-03 | 234 | 104d | 90d | 1403/5/16 | 1403/6/13 |
| 236 | 3.8 | **Bolt & Nut** | 45d | 2025-01-08 | 2025-03-01 |  | 23d |  | 1403/10/19 | 1403/12/11 |
| 237 | 3.8.1 | PO | 5d | 2025-01-08 | 2025-01-13 | 247FS+40d | 23d | 0d | 1403/10/19 | 1403/10/24 |
| 238 | 3.8.2 | Supply/Receive | 40d | 2025-01-14 | 2025-03-01 | 237 | 23d | 0d | 1403/10/25 | 1403/12/11 |

| ID | WBS | Task | Duration | Start | Finish | Predecessors | Total slack | Free slack | شروع | پایان |
| --- | --- | --- | --- | --- | --- | --- | --- | --- | --- | --- |
| 239 | 3.9 | **Valves** | 184d | 2024-07-09 | 2025-02-08 |  | 29d |  | 1403/4/19 | 1403/11/20 |
| 240 | 3.9.1 | PO | 15d | 2024-07-09 | 2024-07-25 | 184, 186, 193 | 29d | 0d | 1403/4/19 | 1403/5/4 |
| 241 | 3.9.2 | Supply/Receive | 169d | 2024-07-27 | 2025-02-08 | 240 | 29d | 0d | 1403/5/6 | 1403/11/20 |
| 242 | 3.10 | **TEG Pumps - 2 Sets** | 170d | 2024-07-25 | 2025-02-08 |  | 29d |  | 1403/5/4 | 1403/11/20 |
| 243 | 3.10.1 | PO | 20d | 2024-07-25 | 2024-08-17 | 162 | 29d | 0d | 1403/5/4 | 1403/5/27 |
| 244 | 3.10.2 | Supply/Receive | 150d | 2024-08-18 | 2025-02-08 | 243 | 29d | 0d | 1403/5/28 | 1403/11/20 |
| 245 | 3.11 | **Internals** | 125d | 2024-06-30 | 2024-11-21 |  | 19d |  | 1403/4/10 | 1403/9/1 |
| 246 | 3.11.1 | PO | 15d | 2024-06-30 | 2024-07-16 | 61 | 19d | 0d | 1403/4/10 | 1403/4/26 |
| 247 | 3.11.2 | Supply/Receive | 110d | 2024-07-17 | 2024-11-21 | 246 | 19d | 0d | 1403/4/27 | 1403/9/1 |
| 248 | 3.12 | **Analyzer** | 230d | 2024-05-26 | 2025-02-17 |  | 21d |  | 1403/3/6 | 1403/11/29 |
| 249 | 3.12.1 | PO | 20d | 2024-05-26 | 2024-06-17 | 177, 187SS+30d | 21d | 0d | 1403/3/6 | 1403/3/28 |
| 250 | 3.12.2 | Supply/Receive | 210d | 2024-06-18 | 2025-02-17 | 249 | 21d |  | 1403/3/29 | 1403/11/29 |
| 251 | 3.13 | **Burner** | 255d | 2024-05-21 | 2025-03-13 |  | 0d |  | 1403/3/1 | 1403/12/23 |
| 252 | 3.13.1 | PO | 20d | 2024-05-21 | 2024-06-12 | 144SS+30d | 0d |  | 1403/3/1 | 1403/3/23 |
| 253 | 3.13.2 | Supply/Receive | 235d | 2024-06-13 | 2025-03-13 | 252 | 0d |  | 1403/3/24 | 1403/12/23 |
| 254 | 3.14 | **Panel & Junction Box** | 125d | 2024-07-17 | 2024-12-09 |  | 81d |  | 1403/4/27 | 1403/9/19 |
| 255 | 3.14.1 | PO | 15d | 2024-07-17 | 2024-08-03 | 181, 174, 182 | 81d | 0d | 1403/4/27 | 1403/5/13 |
| 256 | 3.14.2 | Supply/Receive | 110d | 2024-08-04 | 2024-12-09 | 255 | 81d | 0d | 1403/5/14 | 1403/9/19 |
| 257 | 3.15 | **Profile** | 30d | 2024-07-31 | 2024-09-03 |  | 94d |  | 1403/5/10 | 1403/6/13 |
| 258 | 3.15.1 | PO | 5d | 2024-07-31 | 2024-08-05 | 68, 78, 86, 107, 112, 117, 127, 137 | 94d | 0d | 1403/5/10 | 1403/5/15 |
| 259 | 3.15.2 | Supply/Receive | 25d | 2024-08-06 | 2024-09-03 | 258 | 94d | 60d | 1403/5/16 | 1403/6/13 |
| 260 | 3.16 | **Injection Package** | 180d | 2024-06-30 | 2025-01-25 |  | 41d |  | 1403/4/10 | 1403/11/6 |
| 261 | 3.16.1 | PO | 15d | 2024-06-30 | 2024-07-16 | 61, 60 | 41d | 0d | 1403/4/10 | 1403/4/26 |
| 262 | 3.16.2 | Supply/Receive | 165d | 2024-07-17 | 2025-01-25 | 261 | 41d | 0d | 1403/4/27 | 1403/11/6 |

| ID | WBS | Task | Duration | Start | Finish | Predecessors | Total slack | Free slack | شروع | پایان |
| --- | --- | --- | --- | --- | --- | --- | --- | --- | --- | --- |
| 263 | 3.17 | **INSTRUMEN and Electrical Tray,support,ladder,Connection,…(Installation Cable Accessory)** | 135d | 2024-07-29 | 2025-01-01 |  | 61d |  | 1403/5/8 | 1403/10/12 |
| 264 | 3.17.1 | PO | 15d | 2024-07-29 | 2024-08-14 | 172, 200 | 61d | 0d | 1403/5/8 | 1403/5/24 |
| 265 | 3.17.2 | Supply/Receive | 120d | 2024-08-15 | 2025-01-01 | 264 | 61d | 0d | 1403/5/25 | 1403/10/12 |
| 266 | 3.18 | **Cable** | 55d | 2024-07-22 | 2024-09-23 |  | 147d |  | 1403/5/1 | 1403/7/2 |
| 267 | 3.18.1 | PO | 10d | 2024-07-22 | 2024-08-01 | 185, 169 | 147d | 0d | 1403/5/1 | 1403/5/11 |
| 268 | 3.18.2 | Supply/Receive | 45d | 2024-08-03 | 2024-09-23 | 267 | 147d | 0d | 1403/5/13 | 1403/7/2 |
| 269 | 3.19 | **Filter** | 120d | 2024-06-01 | 2024-10-17 |  | 143d |  | 1403/3/12 | 1403/7/26 |
| 270 | 3.19.1 | PO | 15d | 2024-06-01 | 2024-06-17 | 44, 51 | 143d | 0d | 1403/3/12 | 1403/3/28 |
| 271 | 3.19.2 | Supply/Receive | 105d | 2024-06-18 | 2024-10-17 | 270 | 143d | 0d | 1403/3/29 | 1403/7/26 |
| 272 | 3.20 | **Paint** | 35d | 2025-01-14 | 2025-02-23 |  | 19d | 0d | 1403/10/25 | 1403/12/5 |
| 273 | 3.20.1 | PO | 5d | 2025-01-14 | 2025-01-19 | 24, 247FS+45d | 19d | 0d | 1403/10/25 | 1403/10/30 |
| 274 | 3.20.2 | Supply/Receive | 30d | 2025-01-20 | 2025-02-23 | 273 | 19d | 0d | 1403/11/1 | 1403/12/5 |
| 275 | 4 | **Construction** | 166d | 2024-09-16 | 2025-04-14 |  | 6d |  | 1403/6/26 | 1404/1/25 |
| 276 | 4.1 | **Pressure Vessel** | 164d | 2024-09-16 | 2025-04-12 |  | 2d |  | 1403/6/26 | 1404/1/23 |
| 277 | 4.1.1 | **C-100 Glycol Contactor** | 114d | 2024-11-13 | 2025-04-12 |  | 2d |  | 1403/8/23 | 1404/1/23 |
| 278 | 4.1.1.1 | **Shell** | 11d | 2024-11-13 | 2024-11-25 |  | 25d |  | 1403/8/23 | 1403/9/5 |
| 279 | 4.1.1.1.1 | Marking & Cutting & Beveling | 3d | 2024-11-13 | 2024-11-16 | 67, 68, 226 | 25d | 0d | 1403/8/23 | 1403/8/26 |
| 280 | 4.1.1.1.2 | Pre- Assembling & Per-Welding of Plates | 3d | 2024-11-17 | 2024-11-19 | 279, 74, 886 | 25d | 0d | 1403/8/27 | 1403/8/29 |
| 281 | 4.1.1.1.3 | Rolling | 2d | 2024-11-20 | 2024-11-21 | 280 | 25d | 0d | 1403/8/30 | 1403/9/1 |
| 282 | 4.1.1.1.4 | Assemble & Welding of Plates | 2d | 2024-11-23 | 2024-11-24 | 281 | 25d | 0d | 1403/9/3 | 1403/9/4 |
| 283 | 4.1.1.1.5 | Rerolling | 1d | 2024-11-25 | 2024-11-25 | 282 | 25d | 23d | 1403/9/5 | 1403/9/5 |
| 284 | 4.1.1.2 | **Head** | 34d | 2024-11-13 | 2024-12-22 |  | 2d |  | 1403/8/23 | 1403/10/2 |
| 285 | 4.1.1.2.1 | Marking & Cutting & Beveling head plate | 4d | 2024-11-13 | 2024-11-17 | 67, 68, 226 | 2d | 0d | 1403/8/23 | 1403/8/27 |
| 286 | 4.1.1.2.2 | Forming Head plate (sub contractor) | 30d | 2024-11-18 | 2024-12-22 | 285 | 2d | 0d | 1403/8/28 | 1403/10/2 |

| ID | WBS | Task | Duration | Start | Finish | Predecessors | Total slack | Free slack | شروع | پایان |
| --- | --- | --- | --- | --- | --- | --- | --- | --- | --- | --- |
| 287 | 4.1.1.3 | **External Part** | 36d | 2024-11-13 | 2024-12-24 |  | 24d |  | 1403/8/23 | 1403/10/4 |
| 288 | 4.1.1.3.1 | **Nozzles & Manholes** | 26d | 2024-11-25 | 2024-12-24 |  | 17d |  | 1403/9/5 | 1403/10/4 |
| 289 | 4.1.1.3.1.1 | Cutting & Beveling Pipe | 3d | 2024-11-25 | 2024-11-27 | 69, 223FS+60d | 34d | 17d | 1403/9/5 | 1403/9/7 |
| 290 | 4.1.1.3.1.2 | Assembling of Pipe To Flange | 2d | 2024-12-18 | 2024-12-19 | 289, 229, 235 | 17d | 0d | 1403/9/28 | 1403/9/29 |
| 291 | 4.1.1.3.1.3 | Welding of Pipe To Flange | 4d | 2024-12-21 | 2024-12-24 | 290 | 17d | 15d | 1403/10/1 | 1403/10/4 |
| 292 | 4.1.1.3.2 | **Lifting & Other External Part** | 20d | 2024-11-13 | 2024-12-05 |  | 40d |  | 1403/8/23 | 1403/9/15 |
| 293 | 4.1.1.3.2.1 | Marking & Cutting & Beveling Lifting & Other External Part | 5d | 2024-11-13 | 2024-11-18 | 70, 226 | 40d | 0d | 1403/8/23 | 1403/8/28 |
| 294 | 4.1.1.3.2.2 | Drilling Lifting & Other External Part | 6d | 2024-11-19 | 2024-11-25 | 293 | 40d | 0d | 1403/8/29 | 1403/9/5 |
| 295 | 4.1.1.3.2.3 | Assembling of external parts together | 4d | 2024-11-26 | 2024-11-30 | 294 | 40d | 0d | 1403/9/6 | 1403/9/10 |
| 296 | 4.1.1.3.2.4 | Welding of external parts together | 5d | 2024-12-01 | 2024-12-05 | 295 | 40d | 38d | 1403/9/11 | 1403/9/15 |
| 297 | 4.1.1.4 | **Internal Part** | 9d | 2024-11-13 | 2024-11-23 |  | 69d |  | 1403/8/23 | 1403/9/3 |
| 298 | 4.1.1.4.1 | Marking & Cutting & Beveling Internal Part | 1d | 2024-11-13 | 2024-11-13 | 71, 226 | 69d | 0d | 1403/8/23 | 1403/8/23 |
| 299 | 4.1.1.4.2 | Drilling Internal Part | 3d | 2024-11-14 | 2024-11-17 | 298 | 69d | 0d | 1403/8/24 | 1403/8/27 |
| 300 | 4.1.1.4.3 | Assembling of Internal parts together | 3d | 2024-11-18 | 2024-11-20 | 299 | 69d | 0d | 1403/8/28 | 1403/8/30 |
| 301 | 4.1.1.4.4 | Welding of Internal parts together | 2d | 2024-11-21 | 2024-11-23 | 300 | 69d | 67d | 1403/9/1 | 1403/9/3 |
| 302 | 4.1.1.5 | **Final Assembly** | 56d | 2024-12-23 | 2025-02-25 |  | 2d |  | 1403/10/3 | 1403/12/7 |
| 303 | 4.1.1.5.1 | Assembling Shell course & head | 6d | 2024-12-23 | 2024-12-29 | 283, 286, 73, 74, 887, 890 | 2d | 0d | 1403/10/3 | 1403/10/9 |
| 304 | 4.1.1.5.2 | Welding Shell course & head | 8d | 2024-12-30 | 2025-01-07 | 303 | 2d | 0d | 1403/10/10 | 1403/10/18 |
| 305 | 4.1.1.5.3 | Marking & Opening Nozzle | 3d | 2025-01-08 | 2025-01-11 | 304, 889 | 2d | 0d | 1403/10/19 | 1403/10/22 |
| 306 | 4.1.1.5.4 | Assembling nozzel & manhole | 2d | 2025-01-12 | 2025-01-13 | 291, 305 | 2d | 0d | 1403/10/23 | 1403/10/24 |
| 307 | 4.1.1.5.5 | Welding of nozzel & manhole | 5d | 2025-01-14 | 2025-01-19 | 306, 888 | 2d | 0d | 1403/10/25 | 1403/10/30 |
| 308 | 4.1.1.5.6 | Assembling of Lifting & Other External Part | 10d | 2025-01-20 | 2025-01-30 | 296, 307 | 2d | 0d | 1403/11/1 | 1403/11/11 |
| 309 | 4.1.1.5.7 | Welding of Lifting & Other External Part | 8d | 2025-02-01 | 2025-02-09 | 308 | 2d | 0d | 1403/11/13 | 1403/11/21 |
| 310 | 4.1.1.5.8 | Assembling of internal parts | 5d | 2025-02-10 | 2025-02-15 | 301, 309 | 2d | 0d | 1403/11/22 | 1403/11/27 |
| 311 | 4.1.1.5.9 | Welding of Internal parts | 5d | 2025-02-16 | 2025-02-20 | 310 | 2d | 0d | 1403/11/28 | 1403/12/2 |
| 312 | 4.1.1.5.10 | Final dimensional Inspection | 4d | 2025-02-22 | 2025-02-25 | 311 | 2d | 0d | 1403/12/4 | 1403/12/7 |

| ID | WBS | Task | Duration | Start | Finish | Predecessors | Total slack | Free slack | شروع | پایان |
| --- | --- | --- | --- | --- | --- | --- | --- | --- | --- | --- |
| 313 | 4.1.1.6 | **Final Activity** | 24d | 2025-02-26 | 2025-04-12 |  | 2d |  | 1403/12/8 | 1404/1/23 |
| 314 | 4.1.1.6.1 | prepare for PWHT | 2d | 2025-02-26 | 2025-02-27 | 312 | 2d | 0d | 1403/12/8 | 1403/12/9 |
| 315 | 4.1.1.6.2 | PWHT | 4d | 2025-03-01 | 2025-03-04 | 314, 26, 23 | 2d | 0d | 1403/12/11 | 1403/12/14 |
| 316 | 4.1.1.6.3 | NDT after PWHT | 4d | 2025-03-05 | 2025-03-09 | 315 | 2d | 0d | 1403/12/15 | 1403/12/19 |
| 317 | 4.1.1.6.4 | Prepare for Hydrotest | 3d | 2025-03-10 | 2025-03-12 | 316 | 2d | 0d | 1403/12/20 | 1403/12/22 |
| 318 | 4.1.1.6.5 | Hydrotest | 5d | 2025-03-13 | 2025-04-05 | 317, 31, 891, 892, 894, 895, 896 | 2d | 0d | 1403/12/23 | 1404/1/16 |
| 319 | 4.1.1.6.6 | Sanblasting & Painting | 5d | 2025-04-07 | 2025-04-12 | 318, 272, 898, 899, 274 | 2d | 0d | 1404/1/18 | 1404/1/23 |
| 320 | 4.1.2 | **C-200 Still Column** | 92d | 2024-11-13 | 2025-02-27 |  | 24d |  | 1403/8/23 | 1403/12/9 |
| 321 | 4.1.2.1 | **Shell** | 7d | 2024-11-13 | 2024-11-20 |  | 64d |  | 1403/8/23 | 1403/8/30 |
| 322 | 4.1.2.1.1 | Marking & Cutting & Beveling | 2d | 2024-11-13 | 2024-11-14 | 77, 78, 226 | 64d | 0d | 1403/8/23 | 1403/8/24 |
| 323 | 4.1.2.1.2 | Pre- Assembling & Per-Welding of Plates | 1d | 2024-11-16 | 2024-11-16 | 322, 82, 902 | 64d | 0d | 1403/8/26 | 1403/8/26 |
| 324 | 4.1.2.1.3 | Rolling | 1d | 2024-11-17 | 2024-11-17 | 323 | 64d | 0d | 1403/8/27 | 1403/8/27 |
| 325 | 4.1.2.1.4 | Assemble & Welding of Plates | 2d | 2024-11-18 | 2024-11-19 | 324 | 64d | 0d | 1403/8/28 | 1403/8/29 |
| 326 | 4.1.2.1.5 | Rerolling | 1d | 2024-11-20 | 2024-11-20 | 325 | 64d | 27d | 1403/8/30 | 1403/8/30 |
| 327 | 4.1.2.2 | **Head** | 34d | 2024-11-13 | 2024-12-22 |  | 37d |  | 1403/8/23 | 1403/10/2 |
| 328 | 4.1.2.2.1 | Marking & Cutting & Beveling head plate | 4d | 2024-11-13 | 2024-11-17 | 77, 78, 226 | 37d | 0d | 1403/8/23 | 1403/8/27 |
| 329 | 4.1.2.2.2 | Forming Head plate (sub contractor) | 30d | 2024-11-18 | 2024-12-22 | 328 | 37d | 0d | 1403/8/28 | 1403/10/2 |
| 330 | 4.1.2.3 | **External Part** | 36d | 2024-11-13 | 2024-12-24 |  | 49d |  | 1403/8/23 | 1403/10/4 |
| 331 | 4.1.2.3.1 | **Nozzles & Manholes** | 36d | 2024-11-13 | 2024-12-24 |  | 42d |  | 1403/8/23 | 1403/10/4 |
| 332 | 4.1.2.3.1.1 | Cutting & Beveling Pipe | 2d | 2024-11-13 | 2024-11-14 | 80, 226 | 70d | 28d | 1403/8/23 | 1403/8/24 |
| 333 | 4.1.2.3.1.2 | Assembling of Pipe To Flange | 2d | 2024-12-18 | 2024-12-19 | 332, 229, 235 | 42d | 0d | 1403/9/28 | 1403/9/29 |
| 334 | 4.1.2.3.1.3 | Welding of Pipe To Flange | 4d | 2024-12-21 | 2024-12-24 | 333 | 42d | 5d | 1403/10/1 | 1403/10/4 |
| 335 | 4.1.2.3.2 | **Lifting & Other External Part** | 7d | 2024-11-13 | 2024-11-20 |  | 78d |  | 1403/8/23 | 1403/8/30 |
| 336 | 4.1.2.3.2.1 | Marking & Cutting & Beveling Lifting & Other External Part | 2d | 2024-11-13 | 2024-11-14 | 80, 226 | 78d | 0d | 1403/8/23 | 1403/8/24 |
| 337 | 4.1.2.3.2.2 | Drilling Lifting & Other External Part | 1d | 2024-11-16 | 2024-11-16 | 336 | 78d | 0d | 1403/8/26 | 1403/8/26 |
| 338 | 4.1.2.3.2.3 | Assembling of external parts together | 2d | 2024-11-17 | 2024-11-18 | 337 | 78d | 0d | 1403/8/27 | 1403/8/28 |
| 339 | 4.1.2.3.2.4 | Welding of external parts together | 2d | 2024-11-19 | 2024-11-20 | 338 | 78d | 41d | 1403/8/29 | 1403/8/30 |

| ID | WBS | Task | Duration | Start | Finish | Predecessors | Total slack | Free slack | شروع | پایان |
| --- | --- | --- | --- | --- | --- | --- | --- | --- | --- | --- |
| 340 | 4.1.2.4 | **Internal Part** | 9d | 2024-11-13 | 2024-11-23 |  | 86d |  | 1403/8/23 | 1403/9/3 |
| 341 | 4.1.2.4.1 | Marking & Cutting & Beveling Internal Part | 2d | 2024-11-13 | 2024-11-14 | 80, 226 | 86d | 0d | 1403/8/23 | 1403/8/24 |
| 342 | 4.1.2.4.2 | Drilling Internal Part | 3d | 2024-11-16 | 2024-11-18 | 341 | 86d | 0d | 1403/8/26 | 1403/8/28 |
| 343 | 4.1.2.4.3 | Assembling of Internal parts together | 2d | 2024-11-19 | 2024-11-20 | 342 | 86d | 0d | 1403/8/29 | 1403/8/30 |
| 344 | 4.1.2.4.4 | Welding of Internal parts together | 2d | 2024-11-21 | 2024-11-23 | 343 | 86d | 49d | 1403/9/1 | 1403/9/3 |
| 345 | 4.1.2.5 | **Final Assembly** | 32d | 2024-12-23 | 2025-01-28 |  | 37d |  | 1403/10/3 | 1403/11/9 |
| 346 | 4.1.2.5.1 | Assembling Shell course & head | 3d | 2024-12-23 | 2024-12-25 | 326, 329, 81, 82, 903 | 37d | 0d | 1403/10/3 | 1403/10/5 |
| 347 | 4.1.2.5.2 | Welding Shell course & head | 2d | 2024-12-26 | 2024-12-28 | 346 | 37d | 0d | 1403/10/6 | 1403/10/8 |
| 348 | 4.1.2.5.3 | Marking & Opening Nozzle | 2d | 2024-12-29 | 2024-12-30 | 347 | 37d | 0d | 1403/10/9 | 1403/10/10 |
| 349 | 4.1.2.5.4 | Assembling nozzel & manhole | 2d | 2024-12-31 | 2025-01-01 | 334, 348 | 37d | 0d | 1403/10/11 | 1403/10/12 |
| 350 | 4.1.2.5.5 | Welding of nozzel & manhole | 5d | 2025-01-02 | 2025-01-07 | 349, 904 | 37d | 0d | 1403/10/13 | 1403/10/18 |
| 351 | 4.1.2.5.6 | Assembling of Lifting & Other External Part | 5d | 2025-01-08 | 2025-01-13 | 339, 350 | 37d | 0d | 1403/10/19 | 1403/10/24 |
| 352 | 4.1.2.5.7 | Welding of Lifting & Other External Part | 5d | 2025-01-14 | 2025-01-19 | 351 | 37d | 0d | 1403/10/25 | 1403/10/30 |
| 353 | 4.1.2.5.8 | Assembling of internal parts | 2d | 2025-01-20 | 2025-01-21 | 344, 352 | 37d | 0d | 1403/11/1 | 1403/11/2 |
| 354 | 4.1.2.5.9 | Welding of Internal parts | 4d | 2025-01-22 | 2025-01-26 | 353 | 37d | 0d | 1403/11/3 | 1403/11/7 |
| 355 | 4.1.2.5.10 | Final dimensional Inspection | 2d | 2025-01-27 | 2025-01-28 | 354, 905 | 37d | 0d | 1403/11/8 | 1403/11/9 |
| 356 | 4.1.2.6 | **Final Activity** | 26d | 2025-01-29 | 2025-02-27 |  | 24d |  | 1403/11/10 | 1403/12/9 |
| 357 | 4.1.2.6.1 | prepare for PWHT | 1d | 2025-01-29 | 2025-01-29 | 355 | 37d | 0d | 1403/11/10 | 1403/11/10 |
| 358 | 4.1.2.6.2 | PWHT | 1d | 2025-01-30 | 2025-01-30 | 357, 26, 23 | 37d | 0d | 1403/11/11 | 1403/11/11 |
| 359 | 4.1.2.6.3 | NDT after PWHT | 2d | 2025-02-01 | 2025-02-02 | 358 | 37d | 0d | 1403/11/13 | 1403/11/14 |
| 360 | 4.1.2.6.4 | Prepare for Hydrotest | 2d | 2025-02-03 | 2025-02-04 | 359 | 37d | 0d | 1403/11/15 | 1403/11/16 |
| 361 | 4.1.2.6.5 | Hydrotest | 2d | 2025-02-05 | 2025-02-06 | 360, 31, 906, 907, 909, 910, 911, 1075 | 37d | 0d | 1403/11/17 | 1403/11/18 |
| 362 | 4.1.2.6.6 | Sanblasting & Painting | 4d | 2025-02-24 | 2025-02-27 | 361, 272, 913, 914, 274 | 24d | 0d | 1403/12/6 | 1403/12/9 |
| 363 | 4.1.3 | **C-300 Stripping Column** | 142d | 2024-09-16 | 2025-02-27 |  | 24d |  | 1403/6/26 | 1403/12/9 |
| 364 | 4.1.3.1 | **Shell** | 14d | 2024-11-13 | 2024-11-28 |  | 67d |  | 1403/8/23 | 1403/9/8 |
| 365 | 4.1.3.1.1 | Marking & Cutting & Beveling | 1d | 2024-11-13 | 2024-11-13 | 85, 86, 226 | 67d | 0d | 1403/8/23 | 1403/8/23 |
| 366 | 4.1.3.1.2 | Pre- Assembling & Per-Welding of Plates | 2d | 2024-11-14 | 2024-11-16 | 365, 89, 917 | 67d | 0d | 1403/8/24 | 1403/8/26 |
| 367 | 4.1.3.1.3 | Rolling | 3d | 2024-11-17 | 2024-11-19 | 366 | 67d | 0d | 1403/8/27 | 1403/8/29 |
| 368 | 4.1.3.1.4 | Assemble & Welding of Plates | 4d | 2024-11-20 | 2024-11-24 | 367 | 67d | 0d | 1403/8/30 | 1403/9/4 |
| 369 | 4.1.3.1.5 | Rerolling | 4d | 2024-11-25 | 2024-11-28 | 368 | 67d | 17d | 1403/9/5 | 1403/9/8 |

| ID | WBS | Task | Duration | Start | Finish | Predecessors | Total slack | Free slack | شروع | پایان |
| --- | --- | --- | --- | --- | --- | --- | --- | --- | --- | --- |
| 370 | 4.1.3.2 | **Head** | 31d | 2024-11-13 | 2024-12-18 |  | 50d |  | 1403/8/23 | 1403/9/28 |
| 371 | 4.1.3.2.1 | Marking & Cutting & Beveling head plate | 1d | 2024-11-13 | 2024-11-13 | 85, 86, 226 | 50d | 0d | 1403/8/23 | 1403/8/23 |
| 372 | 4.1.3.2.2 | Forming Head plate (sub contractor) | 30d | 2024-11-14 | 2024-12-18 | 371 | 50d | 0d | 1403/8/24 | 1403/9/28 |
| 373 | 4.1.3.3 | **External Part** | 83d | 2024-09-16 | 2024-12-21 |  | 59d |  | 1403/6/26 | 1403/10/1 |
| 374 | 4.1.3.3.1 | **Nozzles & Manholes** | 83d | 2024-09-16 | 2024-12-21 |  | 53d |  | 1403/6/26 | 1403/10/1 |
| 375 | 4.1.3.3.1.1 | Cutting & Beveling Pipe | 1d | 2024-09-16 | 2024-09-16 | 86, 223 | 132d | 79d | 1403/6/26 | 1403/6/26 |
| 376 | 4.1.3.3.1.2 | Assembling of Pipe To Flange | 1d | 2024-12-18 | 2024-12-18 | 375, 229, 235 | 53d | 0d | 1403/9/28 | 1403/9/28 |
| 377 | 4.1.3.3.1.3 | Welding of Pipe To Flange | 2d | 2024-12-19 | 2024-12-21 | 376 | 53d | 3d | 1403/9/29 | 1403/10/1 |
| 378 | 4.1.3.3.2 | **Lifting & Other External Part** | 11d | 2024-11-13 | 2024-11-25 |  | 81d |  | 1403/8/23 | 1403/9/5 |
| 379 | 4.1.3.3.2.1 | Marking & Cutting & Beveling Lifting & Other External Part | 2d | 2024-11-13 | 2024-11-14 | 86, 226 | 81d | 0d | 1403/8/23 | 1403/8/24 |
| 380 | 4.1.3.3.2.2 | Drilling Lifting & Other External Part | 3d | 2024-11-16 | 2024-11-18 | 379 | 81d | 0d | 1403/8/26 | 1403/8/28 |
| 381 | 4.1.3.3.2.3 | Assembling of external parts together | 2d | 2024-11-19 | 2024-11-20 | 380 | 81d | 0d | 1403/8/29 | 1403/8/30 |
| 382 | 4.1.3.3.2.4 | Welding of external parts together | 4d | 2024-11-21 | 2024-11-25 | 381 | 81d | 31d | 1403/9/1 | 1403/9/5 |
| 383 | 4.1.3.4 | **Internal Part** | 6d | 2024-11-13 | 2024-11-19 |  | 91d |  | 1403/8/23 | 1403/8/29 |
| 384 | 4.1.3.4.1 | Marking & Cutting & Beveling Internal Part | 1d | 2024-11-13 | 2024-11-13 | 86, 226 | 91d | 0d | 1403/8/23 | 1403/8/23 |
| 385 | 4.1.3.4.2 | Drilling Internal Part | 2d | 2024-11-14 | 2024-11-16 | 384 | 91d | 0d | 1403/8/24 | 1403/8/26 |
| 386 | 4.1.3.4.3 | Assembling of Internal parts together | 1d | 2024-11-17 | 2024-11-17 | 385 | 91d | 0d | 1403/8/27 | 1403/8/27 |
| 387 | 4.1.3.4.4 | Welding of Internal parts together | 2d | 2024-11-18 | 2024-11-19 | 386 | 91d | 41d | 1403/8/28 | 1403/8/29 |
| 388 | 4.1.3.5 | **Final Assembly** | 23d | 2024-12-19 | 2025-01-14 |  | 50d |  | 1403/9/29 | 1403/10/25 |
| 389 | 4.1.3.5.1 | Assembling Shell course & head | 2d | 2024-12-19 | 2024-12-21 | 369, 372, 918 | 50d | 0d | 1403/9/29 | 1403/10/1 |
| 390 | 4.1.3.5.2 | Welding Shell course & head | 2d | 2024-12-22 | 2024-12-23 | 389 | 50d | 0d | 1403/10/2 | 1403/10/3 |
| 391 | 4.1.3.5.3 | Marking & Opening Nozzle | 1d | 2024-12-24 | 2024-12-24 | 390 | 50d | 0d | 1403/10/4 | 1403/10/4 |
| 392 | 4.1.3.5.4 | Assembling nozzel & manhole | 2d | 2024-12-25 | 2024-12-26 | 377, 391 | 50d | 0d | 1403/10/5 | 1403/10/6 |
| 393 | 4.1.3.5.5 | Welding of nozzel & manhole | 4d | 2024-12-28 | 2024-12-31 | 392 | 50d | 0d | 1403/10/8 | 1403/10/11 |
| 394 | 4.1.3.5.6 | Assembling of Lifting & Other External Part | 3d | 2025-01-01 | 2025-01-04 | 382, 393 | 50d | 0d | 1403/10/12 | 1403/10/15 |
| 395 | 4.1.3.5.7 | Welding of Lifting & Other External Part | 2d | 2025-01-05 | 2025-01-06 | 394 | 50d | 0d | 1403/10/16 | 1403/10/17 |
| 396 | 4.1.3.5.8 | Assembling of internal parts | 2d | 2025-01-07 | 2025-01-08 | 387, 395 | 50d | 0d | 1403/10/18 | 1403/10/19 |
| 397 | 4.1.3.5.9 | Welding of Internal parts | 3d | 2025-01-09 | 2025-01-12 | 396 | 50d | 0d | 1403/10/20 | 1403/10/23 |
| 398 | 4.1.3.5.10 | Final dimensional Inspection | 2d | 2025-01-13 | 2025-01-14 | 397, 919, 920 | 50d | 0d | 1403/10/24 | 1403/10/25 |

| ID | WBS | Task | Duration | Start | Finish | Predecessors | Total slack | Free slack | شروع | پایان |
| --- | --- | --- | --- | --- | --- | --- | --- | --- | --- | --- |
| 399 | 4.1.3.6 | **Final Activity** | 38d | 2025-01-15 | 2025-02-27 |  | 24d |  | 1403/10/26 | 1403/12/9 |
| 400 | 4.1.3.6.1 | prepare for PWHT | 1d | 2025-01-15 | 2025-01-15 | 398 | 50d | 0d | 1403/10/26 | 1403/10/26 |
| 401 | 4.1.3.6.2 | PWHT | 1d | 2025-01-16 | 2025-01-16 | 400, 26, 23 | 50d | 0d | 1403/10/27 | 1403/10/27 |
| 402 | 4.1.3.6.3 | NDT after PWHT | 2d | 2025-01-18 | 2025-01-19 | 401 | 50d | 0d | 1403/10/29 | 1403/10/30 |
| 403 | 4.1.3.6.4 | Prepare for Hydrotest | 1d | 2025-01-20 | 2025-01-20 | 402 | 50d | 0d | 1403/11/1 | 1403/11/1 |
| 404 | 4.1.3.6.5 | Hydrotest | 2d | 2025-01-21 | 2025-01-22 | 403, 31, 921, 922, 924, 925, 926 | 50d | 0d | 1403/11/2 | 1403/11/3 |
| 405 | 4.1.3.6.6 | Sanblasting & Painting | 4d | 2025-02-24 | 2025-02-27 | 404, 272, 928, 929, 274 | 24d | 0d | 1403/12/6 | 1403/12/9 |
| 406 | 4.1.4 | **V-120 Glycol Flash Drum** | 142d | 2024-09-16 | 2025-02-27 |  | 24d |  | 1403/6/26 | 1403/12/9 |
| 407 | 4.1.4.1 | **Shell** | 13d | 2024-11-13 | 2024-11-27 |  | 52d |  | 1403/8/23 | 1403/9/7 |
| 408 | 4.1.4.1.1 | Marking & Cutting & Beveling | 2d | 2024-11-13 | 2024-11-14 | 92, 93, 226 | 52d | 0d | 1403/8/23 | 1403/8/24 |
| 409 | 4.1.4.1.2 | Pre- Assembling & Per-Welding of Plates | 2d | 2024-11-16 | 2024-11-17 | 408, 98, 932 | 52d | 0d | 1403/8/26 | 1403/8/27 |
| 410 | 4.1.4.1.3 | Rolling | 2d | 2024-11-18 | 2024-11-19 | 409 | 52d | 0d | 1403/8/28 | 1403/8/29 |
| 411 | 4.1.4.1.4 | Assemble & Welding of Plates | 5d | 2024-11-20 | 2024-11-25 | 410 | 52d | 0d | 1403/8/30 | 1403/9/5 |
| 412 | 4.1.4.1.5 | Rerolling | 2d | 2024-11-26 | 2024-11-27 | 411 | 52d | 20d | 1403/9/6 | 1403/9/7 |
| 413 | 4.1.4.2 | **Head** | 33d | 2024-11-13 | 2024-12-21 |  | 32d |  | 1403/8/23 | 1403/10/1 |
| 414 | 4.1.4.2.1 | Marking & Cutting & Beveling head plate | 3d | 2024-11-13 | 2024-11-16 | 92, 93, 226 | 32d | 0d | 1403/8/23 | 1403/8/26 |
| 415 | 4.1.4.2.2 | Forming Head plate (sub contractor) | 30d | 2024-11-17 | 2024-12-21 | 414 | 32d | 0d | 1403/8/27 | 1403/10/1 |
| 416 | 4.1.4.3 | **External Part** | 89d | 2024-09-16 | 2024-12-28 |  | 43d |  | 1403/6/26 | 1403/10/8 |
| 417 | 4.1.4.3.1 | **Nozzles & Manholes** | 89d | 2024-09-16 | 2024-12-28 |  | 37d |  | 1403/6/26 | 1403/10/8 |
| 418 | 4.1.4.3.1.1 | Cutting & Beveling Pipe | 2d | 2024-09-16 | 2024-09-17 | 94, 223 | 115d | 78d | 1403/6/26 | 1403/6/27 |
| 419 | 4.1.4.3.1.2 | Assembling of Pipe To Flange | 4d | 2024-12-18 | 2024-12-22 | 418, 229, 235 | 37d | 0d | 1403/9/28 | 1403/10/2 |
| 420 | 4.1.4.3.1.3 | Welding of Pipe To Flange | 5d | 2024-12-23 | 2024-12-28 | 419 | 37d | 5d | 1403/10/3 | 1403/10/8 |
| 421 | 4.1.4.3.2 | **Lifting & Other External Part** | 9d | 2024-11-13 | 2024-11-23 |  | 73d |  | 1403/8/23 | 1403/9/3 |
| 422 | 4.1.4.3.2.1 | Marking & Cutting & Beveling Lifting & Other External Part | 1d | 2024-11-13 | 2024-11-13 | 95, 226 | 73d | 0d | 1403/8/23 | 1403/8/23 |
| 423 | 4.1.4.3.2.2 | Drilling Lifting & Other External Part | 2d | 2024-11-14 | 2024-11-16 | 422 | 73d | 0d | 1403/8/24 | 1403/8/26 |
| 424 | 4.1.4.3.2.3 | Assembling of external parts together | 2d | 2024-11-17 | 2024-11-18 | 423 | 73d | 0d | 1403/8/27 | 1403/8/28 |
| 425 | 4.1.4.3.2.4 | Welding of external parts together | 4d | 2024-11-19 | 2024-11-23 | 424 | 73d | 41d | 1403/8/29 | 1403/9/3 |

| ID | WBS | Task | Duration | Start | Finish | Predecessors | Total slack | Free slack | شروع | پایان |
| --- | --- | --- | --- | --- | --- | --- | --- | --- | --- | --- |
| 426 | 4.1.4.4 | **Internal Part** | 6d | 2024-11-13 | 2024-11-19 |  | 87d |  | 1403/8/23 | 1403/8/29 |
| 427 | 4.1.4.4.1 | Marking & Cutting & Beveling Internal Part | 1d | 2024-11-13 | 2024-11-13 | 95, 226 | 87d | 0d | 1403/8/23 | 1403/8/23 |
| 428 | 4.1.4.4.2 | Drilling Internal Part | 2d | 2024-11-14 | 2024-11-16 | 427 | 87d | 0d | 1403/8/24 | 1403/8/26 |
| 429 | 4.1.4.4.3 | Assembling of Internal parts together | 2d | 2024-11-17 | 2024-11-18 | 428 | 87d | 0d | 1403/8/27 | 1403/8/28 |
| 430 | 4.1.4.4.4 | Welding of Internal parts together | 1d | 2024-11-19 | 2024-11-19 | 429 | 87d | 55d | 1403/8/29 | 1403/8/29 |
| 431 | 4.1.4.5 | **Final Assembly** | 38d | 2024-12-22 | 2025-02-03 |  | 32d |  | 1403/10/2 | 1403/11/15 |
| 432 | 4.1.4.5.1 | Assembling Shell course & head | 4d | 2024-12-22 | 2024-12-25 | 412, 415, 933 | 32d | 0d | 1403/10/2 | 1403/10/5 |
| 433 | 4.1.4.5.2 | Welding Shell course & head | 5d | 2024-12-26 | 2024-12-31 | 432 | 32d | 0d | 1403/10/6 | 1403/10/11 |
| 434 | 4.1.4.5.3 | Marking & Opening Nozzle | 2d | 2025-01-01 | 2025-01-02 | 433 | 32d | 0d | 1403/10/12 | 1403/10/13 |
| 435 | 4.1.4.5.4 | Assembling nozzel & manhole | 2d | 2025-01-04 | 2025-01-05 | 420, 434 | 32d | 0d | 1403/10/15 | 1403/10/16 |
| 436 | 4.1.4.5.5 | Welding of nozzel & manhole | 4d | 2025-01-06 | 2025-01-09 | 435 | 32d | 0d | 1403/10/17 | 1403/10/20 |
| 437 | 4.1.4.5.6 | Assembling of Lifting & Other External Part | 5d | 2025-01-11 | 2025-01-15 | 425, 436 | 32d | 0d | 1403/10/22 | 1403/10/26 |
| 438 | 4.1.4.5.7 | Welding of Lifting & Other External Part | 6d | 2025-01-16 | 2025-01-22 | 437 | 32d | 0d | 1403/10/27 | 1403/11/3 |
| 439 | 4.1.4.5.8 | Assembling of internal parts | 3d | 2025-01-23 | 2025-01-26 | 430, 438 | 32d | 0d | 1403/11/4 | 1403/11/7 |
| 440 | 4.1.4.5.9 | Welding of Internal parts | 5d | 2025-01-27 | 2025-02-01 | 439 | 32d | 0d | 1403/11/8 | 1403/11/13 |
| 441 | 4.1.4.5.10 | Final dimensional Inspection | 2d | 2025-02-02 | 2025-02-03 | 440, 934, 935 | 32d | 0d | 1403/11/14 | 1403/11/15 |
| 442 | 4.1.4.6 | **Final Activity** | 21d | 2025-02-04 | 2025-02-27 |  | 24d |  | 1403/11/16 | 1403/12/9 |
| 443 | 4.1.4.6.1 | prepare for PWHT | 2d | 2025-02-04 | 2025-02-05 | 441 | 32d | 0d | 1403/11/16 | 1403/11/17 |
| 444 | 4.1.4.6.2 | PWHT | 1d | 2025-02-06 | 2025-02-06 | 443, 26, 23 | 32d | 0d | 1403/11/18 | 1403/11/18 |
| 445 | 4.1.4.6.3 | NDT after PWHT | 2d | 2025-02-08 | 2025-02-09 | 444 | 32d | 0d | 1403/11/20 | 1403/11/21 |
| 446 | 4.1.4.6.4 | Prepare for Hydrotest | 1d | 2025-02-10 | 2025-02-10 | 445 | 32d | 0d | 1403/11/22 | 1403/11/22 |
| 447 | 4.1.4.6.5 | Hydrotest | 2d | 2025-02-11 | 2025-02-12 | 446, 31, 936, 937, 939, 940, 941 | 32d | 0d | 1403/11/23 | 1403/11/24 |
| 448 | 4.1.4.6.6 | Sanblasting & Painting | 4d | 2025-02-24 | 2025-02-27 | 447, 272, 943, 944, 274 | 24d | 0d | 1403/12/6 | 1403/12/9 |
| 449 | 4.1.5 | **F-100A Particle Glycol Filter** | 143d | 2024-09-16 | 2025-03-01 |  | 23d |  | 1403/6/26 | 1403/12/11 |
| 450 | 4.1.5.1 | **Shell** | 6d | 2024-11-17 | 2024-11-23 |  | 61d |  | 1403/8/27 | 1403/9/3 |
| 451 | 4.1.5.1.1 | Marking & Cutting & Beveling | 1d | 2024-11-17 | 2024-11-17 | 101, 102, 226FS+3d | 61d | 0d | 1403/8/27 | 1403/8/27 |
| 452 | 4.1.5.1.2 | Pre- Assembling & Per-Welding of Plates | 1d | 2024-11-18 | 2024-11-18 | 451, 947 | 61d | 0d | 1403/8/28 | 1403/8/28 |
| 453 | 4.1.5.1.3 | Rolling | 1d | 2024-11-19 | 2024-11-19 | 452 | 61d | 0d | 1403/8/29 | 1403/8/29 |
| 454 | 4.1.5.1.4 | Assemble & Welding of Plates | 2d | 2024-11-20 | 2024-11-21 | 453 | 61d | 0d | 1403/8/30 | 1403/9/1 |
| 455 | 4.1.5.1.5 | Rerolling | 1d | 2024-11-23 | 2024-11-23 | 454 | 61d | 25d | 1403/9/3 | 1403/9/3 |

| ID | WBS | Task | Duration | Start | Finish | Predecessors | Total slack | Free slack | شروع | پایان |
| --- | --- | --- | --- | --- | --- | --- | --- | --- | --- | --- |
| 456 | 4.1.5.2 | **Head** | 31d | 2024-11-17 | 2024-12-22 |  | 36d |  | 1403/8/27 | 1403/10/2 |
| 457 | 4.1.5.2.1 | Marking & Cutting & Beveling head plate | 1d | 2024-11-17 | 2024-11-17 | 101, 226FS+3d | 36d | 0d | 1403/8/27 | 1403/8/27 |
| 458 | 4.1.5.2.2 | Forming Head plate (sub contractor) | 30d | 2024-11-18 | 2024-12-22 | 457 | 36d | 0d | 1403/8/28 | 1403/10/2 |
| 459 | 4.1.5.3 | **External Part** | 85d | 2024-09-16 | 2024-12-23 |  | 49d |  | 1403/6/26 | 1403/10/3 |
| 460 | 4.1.5.3.1 | **Nozzles & Manholes** | 85d | 2024-09-16 | 2024-12-23 |  | 43d |  | 1403/6/26 | 1403/10/3 |
| 461 | 4.1.5.3.1.1 | Cutting & Beveling Pipe | 1d | 2024-09-16 | 2024-09-16 | 102, 223 | 122d | 79d | 1403/6/26 | 1403/6/26 |
| 462 | 4.1.5.3.1.2 | Assembling of Pipe To Flange | 2d | 2024-12-18 | 2024-12-19 | 461, 229, 235 | 43d | 0d | 1403/9/28 | 1403/9/29 |
| 463 | 4.1.5.3.1.3 | Welding of Pipe To Flange | 3d | 2024-12-21 | 2024-12-23 | 462 | 43d | 7d | 1403/10/1 | 1403/10/3 |
| 464 | 4.1.5.3.2 | **Lifting & Other External Part** | 10d | 2024-11-24 | 2024-12-04 |  | 65d |  | 1403/9/4 | 1403/9/14 |
| 465 | 4.1.5.3.2.1 | Marking & Cutting & Beveling Lifting & Other External Part | 2d | 2024-11-24 | 2024-11-25 | 102, 226FS+9d | 65d | 0d | 1403/9/4 | 1403/9/5 |
| 466 | 4.1.5.3.2.2 | Drilling Lifting & Other External Part | 3d | 2024-11-26 | 2024-11-28 | 465 | 65d | 0d | 1403/9/6 | 1403/9/8 |
| 467 | 4.1.5.3.2.3 | Assembling of external parts together | 2d | 2024-11-30 | 2024-12-01 | 466 | 65d | 0d | 1403/9/10 | 1403/9/11 |
| 468 | 4.1.5.3.2.4 | Welding of external parts together | 3d | 2024-12-02 | 2024-12-04 | 467 | 65d | 29d | 1403/9/12 | 1403/9/14 |
| 469 | 4.1.5.4 | **Internal Part** | 6d | 2024-12-01 | 2024-12-07 |  | 69d |  | 1403/9/11 | 1403/9/17 |
| 470 | 4.1.5.4.1 | Marking & Cutting & Beveling Internal Part | 1d | 2024-12-01 | 2024-12-01 | 102, 226FS+15d | 69d | 0d | 1403/9/11 | 1403/9/11 |
| 471 | 4.1.5.4.2 | Drilling Internal Part | 2d | 2024-12-02 | 2024-12-03 | 470 | 69d | 0d | 1403/9/12 | 1403/9/13 |
| 472 | 4.1.5.4.3 | Assembling of Internal parts together | 1d | 2024-12-04 | 2024-12-04 | 471 | 69d | 0d | 1403/9/14 | 1403/9/14 |
| 473 | 4.1.5.4.4 | Welding of Internal parts together | 2d | 2024-12-05 | 2024-12-07 | 472 | 69d | 33d | 1403/9/15 | 1403/9/17 |
| 474 | 4.1.5.5 | **Final Assembly** | 29d | 2024-12-23 | 2025-01-25 |  | 36d |  | 1403/10/3 | 1403/11/6 |
| 475 | 4.1.5.5.1 | Assembling Shell course & head | 2d | 2024-12-23 | 2024-12-24 | 455, 458, 948 | 36d | 0d | 1403/10/3 | 1403/10/4 |
| 476 | 4.1.5.5.2 | Welding Shell course & head | 4d | 2024-12-25 | 2024-12-29 | 475 | 36d | 0d | 1403/10/5 | 1403/10/9 |
| 477 | 4.1.5.5.3 | Marking & Opening Nozzle | 2d | 2024-12-30 | 2024-12-31 | 476 | 36d | 0d | 1403/10/10 | 1403/10/11 |
| 478 | 4.1.5.5.4 | Assembling nozzel & manhole | 4d | 2025-01-01 | 2025-01-05 | 463, 477 | 36d | 0d | 1403/10/12 | 1403/10/16 |
| 479 | 4.1.5.5.5 | Welding of nozzel & manhole | 2d | 2025-01-06 | 2025-01-07 | 478 | 36d | 0d | 1403/10/17 | 1403/10/18 |
| 480 | 4.1.5.5.6 | Assembling of Lifting & Other External Part | 2d | 2025-01-08 | 2025-01-09 | 468, 479 | 36d | 0d | 1403/10/19 | 1403/10/20 |
| 481 | 4.1.5.5.7 | Welding of Lifting & Other External Part | 4d | 2025-01-11 | 2025-01-14 | 480 | 36d | 0d | 1403/10/22 | 1403/10/25 |
| 482 | 4.1.5.5.8 | Assembling of internal parts | 2d | 2025-01-15 | 2025-01-16 | 473, 481 | 36d | 0d | 1403/10/26 | 1403/10/27 |
| 483 | 4.1.5.5.9 | Welding of Internal parts | 3d | 2025-01-18 | 2025-01-20 | 482 | 36d | 0d | 1403/10/29 | 1403/11/1 |
| 484 | 4.1.5.5.10 | Final dimensional Inspection | 4d | 2025-01-21 | 2025-01-25 | 483, 949, 950 | 36d | 0d | 1403/11/2 | 1403/11/6 |

| ID | WBS | Task | Duration | Start | Finish | Predecessors | Total slack | Free slack | شروع | پایان |
| --- | --- | --- | --- | --- | --- | --- | --- | --- | --- | --- |
| 485 | 4.1.5.6 | **Final Activity** | 30d | 2025-01-26 | 2025-03-01 |  | 23d |  | 1403/11/7 | 1403/12/11 |
| 486 | 4.1.5.6.1 | prepare for PWHT | 1d | 2025-01-26 | 2025-01-26 | 484 | 36d | 0d | 1403/11/7 | 1403/11/7 |
| 487 | 4.1.5.6.2 | PWHT | 3d | 2025-01-27 | 2025-01-29 | 486, 26, 23 | 36d | 0d | 1403/11/8 | 1403/11/10 |
| 488 | 4.1.5.6.3 | NDT after PWHT | 2d | 2025-01-30 | 2025-02-01 | 487 | 36d | 0d | 1403/11/11 | 1403/11/13 |
| 489 | 4.1.5.6.4 | Prepare for Hydrotest | 1d | 2025-02-02 | 2025-02-02 | 488 | 36d | 0d | 1403/11/14 | 1403/11/14 |
| 490 | 4.1.5.6.5 | Hydrotest | 4d | 2025-02-03 | 2025-02-06 | 489, 31, 951, 952, 954, 955, 956 | 36d | 0d | 1403/11/15 | 1403/11/18 |
| 491 | 4.1.5.6.6 | Sanblasting & Painting | 5d | 2025-02-24 | 2025-03-01 | 490, 272, 958, 959, 274 | 23d | 0d | 1403/12/6 | 1403/12/11 |
| 492 | 4.1.6 | **F-100B Particle Glycol Filter** | 140d | 2024-09-16 | 2025-02-25 |  | 26d |  | 1403/6/26 | 1403/12/7 |
| 493 | 4.1.6.1 | **Shell** | 6d | 2024-11-13 | 2024-11-19 |  | 88d |  | 1403/8/23 | 1403/8/29 |
| 494 | 4.1.6.1.1 | Marking & Cutting & Beveling | 1d | 2024-11-13 | 2024-11-13 | 101, 102, 226 | 88d | 0d | 1403/8/23 | 1403/8/23 |
| 495 | 4.1.6.1.2 | Pre- Assembling & Per-Welding of Plates | 1d | 2024-11-14 | 2024-11-14 | 494, 962 | 88d | 0d | 1403/8/24 | 1403/8/24 |
| 496 | 4.1.6.1.3 | Rolling | 1d | 2024-11-16 | 2024-11-16 | 495 | 88d | 0d | 1403/8/26 | 1403/8/26 |
| 497 | 4.1.6.1.4 | Assemble & Welding of Plates | 2d | 2024-11-17 | 2024-11-18 | 496 | 88d | 0d | 1403/8/27 | 1403/8/28 |
| 498 | 4.1.6.1.5 | Rerolling | 1d | 2024-11-19 | 2024-11-19 | 497 | 88d | 25d | 1403/8/29 | 1403/8/29 |
| 499 | 4.1.6.2 | **Head** | 31d | 2024-11-13 | 2024-12-18 |  | 63d |  | 1403/8/23 | 1403/9/28 |
| 500 | 4.1.6.2.1 | Marking & Cutting & Beveling head plate | 1d | 2024-11-13 | 2024-11-13 | 102, 226 | 63d | 0d | 1403/8/23 | 1403/8/23 |
| 501 | 4.1.6.2.2 | Forming Head plate (sub contractor) | 30d | 2024-11-14 | 2024-12-18 | 500 | 63d | 0d | 1403/8/24 | 1403/9/28 |
| 502 | 4.1.6.3 | **External Part** | 85d | 2024-09-16 | 2024-12-23 |  | 65d |  | 1403/6/26 | 1403/10/3 |
| 503 | 4.1.6.3.1 | **Nozzles & Manholes** | 85d | 2024-09-16 | 2024-12-23 |  | 62d |  | 1403/6/26 | 1403/10/3 |
| 504 | 4.1.6.3.1.1 | Cutting & Beveling Pipe | 1d | 2024-09-16 | 2024-09-16 | 102, 223 | 141d | 79d | 1403/6/26 | 1403/6/26 |
| 505 | 4.1.6.3.1.2 | Assembling of Pipe To Flange | 2d | 2024-12-18 | 2024-12-19 | 504, 229, 235 | 62d | 0d | 1403/9/28 | 1403/9/29 |
| 506 | 4.1.6.3.1.3 | Welding of Pipe To Flange | 3d | 2024-12-21 | 2024-12-23 | 505 | 62d | 0d | 1403/10/1 | 1403/10/3 |
| 507 | 4.1.6.3.2 | **Lifting & Other External Part** | 10d | 2024-11-13 | 2024-11-24 |  | 90d |  | 1403/8/23 | 1403/9/4 |
| 508 | 4.1.6.3.2.1 | Marking & Cutting & Beveling Lifting & Other External Part | 2d | 2024-11-13 | 2024-11-14 | 102, 226 | 90d | 0d | 1403/8/23 | 1403/8/24 |
| 509 | 4.1.6.3.2.2 | Drilling Lifting & Other External Part | 3d | 2024-11-16 | 2024-11-18 | 508 | 90d | 0d | 1403/8/26 | 1403/8/28 |
| 510 | 4.1.6.3.2.3 | Assembling of external parts together | 2d | 2024-11-19 | 2024-11-20 | 509 | 90d | 0d | 1403/8/29 | 1403/8/30 |
| 511 | 4.1.6.3.2.4 | Welding of external parts together | 3d | 2024-11-21 | 2024-11-24 | 510 | 90d | 28d | 1403/9/1 | 1403/9/4 |

| ID | WBS | Task | Duration | Start | Finish | Predecessors | Total slack | Free slack | شروع | پایان |
| --- | --- | --- | --- | --- | --- | --- | --- | --- | --- | --- |
| 512 | 4.1.6.4 | **Internal Part** | 6d | 2024-11-13 | 2024-11-19 |  | 97d |  | 1403/8/23 | 1403/8/29 |
| 513 | 4.1.6.4.1 | Marking & Cutting & Beveling Internal Part | 1d | 2024-11-13 | 2024-11-13 | 102, 226 | 97d | 0d | 1403/8/23 | 1403/8/23 |
| 514 | 4.1.6.4.2 | Drilling Internal Part | 2d | 2024-11-14 | 2024-11-16 | 513 | 97d | 0d | 1403/8/24 | 1403/8/26 |
| 515 | 4.1.6.4.3 | Assembling of Internal parts together | 1d | 2024-11-17 | 2024-11-17 | 514 | 97d | 0d | 1403/8/27 | 1403/8/27 |
| 516 | 4.1.6.4.4 | Welding of Internal parts together | 2d | 2024-11-18 | 2024-11-19 | 515 | 97d | 35d | 1403/8/28 | 1403/8/29 |
| 517 | 4.1.6.5 | **Final Assembly** | 14d | 2024-12-19 | 2025-01-04 |  | 62d |  | 1403/9/29 | 1403/10/15 |
| 518 | 4.1.6.5.1 | Assembling Shell course & head | 1d | 2024-12-19 | 2024-12-19 | 498, 501, 963 | 63d | 0d | 1403/9/29 | 1403/9/29 |
| 519 | 4.1.6.5.2 | Welding Shell course & head | 1d | 2024-12-21 | 2024-12-21 | 518 | 63d | 0d | 1403/10/1 | 1403/10/1 |
| 520 | 4.1.6.5.3 | Marking & Opening Nozzle | 1d | 2024-12-22 | 2024-12-22 | 519 | 63d | 1d | 1403/10/2 | 1403/10/2 |
| 521 | 4.1.6.5.4 | Assembling nozzel & manhole | 1d | 2024-12-24 | 2024-12-24 | 506, 520 | 62d | 0d | 1403/10/4 | 1403/10/4 |
| 522 | 4.1.6.5.5 | Welding of nozzel & manhole | 2d | 2024-12-25 | 2024-12-26 | 521 | 62d | 0d | 1403/10/5 | 1403/10/6 |
| 523 | 4.1.6.5.6 | Assembling of Lifting & Other External Part | 1d | 2024-12-28 | 2024-12-28 | 511, 522 | 62d | 0d | 1403/10/8 | 1403/10/8 |
| 524 | 4.1.6.5.7 | Welding of Lifting & Other External Part | 2d | 2024-12-29 | 2024-12-30 | 523 | 62d | 0d | 1403/10/9 | 1403/10/10 |
| 525 | 4.1.6.5.8 | Assembling of internal parts | 1d | 2024-12-31 | 2024-12-31 | 516, 524 | 62d | 0d | 1403/10/11 | 1403/10/11 |
| 526 | 4.1.6.5.9 | Welding of Internal parts | 1d | 2025-01-01 | 2025-01-01 | 525 | 62d | 0d | 1403/10/12 | 1403/10/12 |
| 527 | 4.1.6.5.10 | Final dimensional Inspection | 2d | 2025-01-02 | 2025-01-04 | 526, 964, 965 | 62d | 0d | 1403/10/13 | 1403/10/15 |
| 528 | 4.1.6.6 | **Final Activity** | 45d | 2025-01-05 | 2025-02-25 |  | 26d |  | 1403/10/16 | 1403/12/7 |
| 529 | 4.1.6.6.1 | prepare for PWHT | 1d | 2025-01-05 | 2025-01-05 | 527 | 62d | 0d | 1403/10/16 | 1403/10/16 |
| 530 | 4.1.6.6.2 | PWHT | 1d | 2025-01-06 | 2025-01-06 | 529, 26, 23 | 62d | 0d | 1403/10/17 | 1403/10/17 |
| 531 | 4.1.6.6.3 | NDT after PWHT | 1d | 2025-01-07 | 2025-01-07 | 530 | 62d | 0d | 1403/10/18 | 1403/10/18 |
| 532 | 4.1.6.6.4 | Prepare for Hydrotest | 1d | 2025-01-08 | 2025-01-08 | 531 | 62d | 0d | 1403/10/19 | 1403/10/19 |
| 533 | 4.1.6.6.5 | Hydrotest | 2d | 2025-01-09 | 2025-01-11 | 532, 31, 966, 967, 969, 970, 971 | 62d | 0d | 1403/10/20 | 1403/10/22 |
| 534 | 4.1.6.6.6 | Sanblasting & Painting | 2d | 2025-02-24 | 2025-02-25 | 533, 272, 973, 974, 274 | 26d | 0d | 1403/12/6 | 1403/12/7 |
| 535 | 4.1.7 | **F-200 Carbon Glycol Filter** | 142d | 2024-09-16 | 2025-02-27 |  | 24d |  | 1403/6/26 | 1403/12/9 |
| 536 | 4.1.7.1 | **Shell** | 6d | 2024-11-17 | 2024-11-23 |  | 80d |  | 1403/8/27 | 1403/9/3 |
| 537 | 4.1.7.1.1 | Marking & Cutting & Beveling | 1d | 2024-11-17 | 2024-11-17 | 106, 107, 226FS+3d | 80d | 0d | 1403/8/27 | 1403/8/27 |
| 538 | 4.1.7.1.2 | Pre- Assembling & Per-Welding of Plates | 1d | 2024-11-18 | 2024-11-18 | 537, 977 | 80d | 0d | 1403/8/28 | 1403/8/28 |
| 539 | 4.1.7.1.3 | Rolling | 2d | 2024-11-19 | 2024-11-20 | 538 | 80d | 0d | 1403/8/29 | 1403/8/30 |
| 540 | 4.1.7.1.4 | Assemble & Welding of Plates | 1d | 2024-11-21 | 2024-11-21 | 539 | 80d | 0d | 1403/9/1 | 1403/9/1 |
| 541 | 4.1.7.1.5 | Rerolling | 1d | 2024-11-23 | 2024-11-23 | 540 | 80d | 25d | 1403/9/3 | 1403/9/3 |

| ID | WBS | Task | Duration | Start | Finish | Predecessors | Total slack | Free slack | شروع | پایان |
| --- | --- | --- | --- | --- | --- | --- | --- | --- | --- | --- |
| 542 | 4.1.7.2 | **Head** | 31d | 2024-11-17 | 2024-12-22 |  | 55d |  | 1403/8/27 | 1403/10/2 |
| 543 | 4.1.7.2.1 | Marking & Cutting & Beveling head plate | 1d | 2024-11-17 | 2024-11-17 | 107, 106, 226FS+3d | 55d | 0d | 1403/8/27 | 1403/8/27 |
| 544 | 4.1.7.2.2 | Forming Head plate (sub contractor) | 30d | 2024-11-18 | 2024-12-22 | 543 | 55d | 0d | 1403/8/28 | 1403/10/2 |
| 545 | 4.1.7.3 | **External Part** | 88d | 2024-09-16 | 2024-12-26 |  | 57d |  | 1403/6/26 | 1403/10/6 |
| 546 | 4.1.7.3.1 | **Nozzles & Manholes** | 88d | 2024-09-16 | 2024-12-26 |  | 54d |  | 1403/6/26 | 1403/10/6 |
| 547 | 4.1.7.3.1.1 | Cutting & Beveling Pipe | 2d | 2024-09-16 | 2024-09-17 | 107, 223 | 132d | 78d | 1403/6/26 | 1403/6/27 |
| 548 | 4.1.7.3.1.2 | Assembling of Pipe To Flange | 3d | 2024-12-18 | 2024-12-21 | 547, 229, 235 | 54d | 0d | 1403/9/28 | 1403/10/1 |
| 549 | 4.1.7.3.1.3 | Welding of Pipe To Flange | 5d | 2024-12-22 | 2024-12-26 | 548 | 54d | 0d | 1403/10/2 | 1403/10/6 |
| 550 | 4.1.7.3.2 | **Lifting & Other External Part** | 5d | 2024-11-20 | 2024-11-25 |  | 84d |  | 1403/8/30 | 1403/9/5 |
| 551 | 4.1.7.3.2.1 | Marking & Cutting & Beveling Lifting & Other External Part | 1d | 2024-11-20 | 2024-11-20 | 107, 226FS+6d | 84d | 0d | 1403/8/30 | 1403/8/30 |
| 552 | 4.1.7.3.2.2 | Drilling Lifting & Other External Part | 1d | 2024-11-21 | 2024-11-21 | 551 | 84d | 0d | 1403/9/1 | 1403/9/1 |
| 553 | 4.1.7.3.2.3 | Assembling of external parts together | 1d | 2024-11-23 | 2024-11-23 | 552 | 84d | 0d | 1403/9/3 | 1403/9/3 |
| 554 | 4.1.7.3.2.4 | Welding of external parts together | 2d | 2024-11-24 | 2024-11-25 | 553 | 84d | 30d | 1403/9/4 | 1403/9/5 |
| 555 | 4.1.7.4 | **Internal Part** | 7d | 2024-11-13 | 2024-11-20 |  | 91d |  | 1403/8/23 | 1403/8/30 |
| 556 | 4.1.7.4.1 | Marking & Cutting & Beveling Internal Part | 1d | 2024-11-13 | 2024-11-13 | 107, 226 | 91d | 0d | 1403/8/23 | 1403/8/23 |
| 557 | 4.1.7.4.2 | Drilling Internal Part | 1d | 2024-11-14 | 2024-11-14 | 556 | 91d | 0d | 1403/8/24 | 1403/8/24 |
| 558 | 4.1.7.4.3 | Assembling of Internal parts together | 2d | 2024-11-16 | 2024-11-17 | 557 | 91d | 0d | 1403/8/26 | 1403/8/27 |
| 559 | 4.1.7.4.4 | Welding of Internal parts together | 3d | 2024-11-18 | 2024-11-20 | 558 | 91d | 37d | 1403/8/28 | 1403/8/30 |
| 560 | 4.1.7.5 | **Final Assembly** | 14d | 2024-12-23 | 2025-01-07 |  | 54d |  | 1403/10/3 | 1403/10/18 |
| 561 | 4.1.7.5.1 | Assembling Shell course & head | 1d | 2024-12-23 | 2024-12-23 | 541, 544, 978 | 55d | 0d | 1403/10/3 | 1403/10/3 |
| 562 | 4.1.7.5.2 | Welding Shell course & head | 1d | 2024-12-24 | 2024-12-24 | 561 | 55d | 0d | 1403/10/4 | 1403/10/4 |
| 563 | 4.1.7.5.3 | Marking & Opening Nozzle | 1d | 2024-12-25 | 2024-12-25 | 562 | 55d | 1d | 1403/10/5 | 1403/10/5 |
| 564 | 4.1.7.5.4 | Assembling nozzel & manhole | 1d | 2024-12-28 | 2024-12-28 | 549, 563 | 54d | 0d | 1403/10/8 | 1403/10/8 |
| 565 | 4.1.7.5.5 | Welding of nozzel & manhole | 2d | 2024-12-29 | 2024-12-30 | 564 | 54d | 0d | 1403/10/9 | 1403/10/10 |
| 566 | 4.1.7.5.6 | Assembling of Lifting & Other External Part | 1d | 2024-12-31 | 2024-12-31 | 554, 565 | 54d | 0d | 1403/10/11 | 1403/10/11 |
| 567 | 4.1.7.5.7 | Welding of Lifting & Other External Part | 2d | 2025-01-01 | 2025-01-02 | 566 | 54d | 0d | 1403/10/12 | 1403/10/13 |
| 568 | 4.1.7.5.8 | Assembling of internal parts | 1d | 2025-01-04 | 2025-01-04 | 559, 567 | 54d | 0d | 1403/10/15 | 1403/10/15 |
| 569 | 4.1.7.5.9 | Welding of Internal parts | 1d | 2025-01-05 | 2025-01-05 | 568 | 54d | 0d | 1403/10/16 | 1403/10/16 |
| 570 | 4.1.7.5.10 | Final dimensional Inspection | 2d | 2025-01-06 | 2025-01-07 | 569, 979, 980 | 54d | 0d | 1403/10/17 | 1403/10/18 |

| ID | WBS | Task | Duration | Start | Finish | Predecessors | Total slack | Free slack | شروع | پایان |
| --- | --- | --- | --- | --- | --- | --- | --- | --- | --- | --- |
| 571 | 4.1.7.6 | **Final Activity** | 44d | 2025-01-08 | 2025-02-27 |  | 24d |  | 1403/10/19 | 1403/12/9 |
| 572 | 4.1.7.6.1 | prepare for PWHT | 2d | 2025-01-08 | 2025-01-09 | 570 | 54d | 0d | 1403/10/19 | 1403/10/20 |
| 573 | 4.1.7.6.2 | PWHT | 1d | 2025-01-11 | 2025-01-11 | 572, 26, 23 | 54d | 0d | 1403/10/22 | 1403/10/22 |
| 574 | 4.1.7.6.3 | NDT after PWHT | 1d | 2025-01-12 | 2025-01-12 | 573 | 54d | 0d | 1403/10/23 | 1403/10/23 |
| 575 | 4.1.7.6.4 | Prepare for Hydrotest | 2d | 2025-01-13 | 2025-01-14 | 574 | 54d | 0d | 1403/10/24 | 1403/10/25 |
| 576 | 4.1.7.6.5 | Hydrotest | 3d | 2025-01-15 | 2025-01-18 | 575, 31, 981, 982, 984, 985, 986 | 54d | 0d | 1403/10/26 | 1403/10/29 |
| 577 | 4.1.7.6.6 | Sanblasting & Painting | 4d | 2025-02-24 | 2025-02-27 | 576, 272, 988, 989, 274 | 24d | 0d | 1403/12/6 | 1403/12/9 |
| 578 | 4.1.8 | **E-100 Glycol reflux condenser COIL TYPE** | 142d | 2024-09-16 | 2025-02-27 |  | 24d |  | 1403/6/26 | 1403/12/9 |
| 579 | 4.1.8.1 | **Shell** | 5d | 2024-11-25 | 2024-11-30 |  | 50d |  | 1403/9/5 | 1403/9/10 |
| 580 | 4.1.8.1.1 | Marking & Cutting & Beveling | 1d | 2024-11-25 | 2024-11-25 | 111, 112, 226FS+10d | 50d | 0d | 1403/9/5 | 1403/9/5 |
| 581 | 4.1.8.1.2 | Pre- Assembling & Per-Welding of Plates | 1d | 2024-11-26 | 2024-11-26 | 580, 992 | 50d | 0d | 1403/9/6 | 1403/9/6 |
| 582 | 4.1.8.1.3 | Rolling | 1d | 2024-11-27 | 2024-11-27 | 581 | 50d | 0d | 1403/9/7 | 1403/9/7 |
| 583 | 4.1.8.1.4 | Assemble & Welding of Plates | 1d | 2024-11-28 | 2024-11-28 | 582 | 50d | 0d | 1403/9/8 | 1403/9/8 |
| 584 | 4.1.8.1.5 | Rerolling | 1d | 2024-11-30 | 2024-11-30 | 583 | 50d | 0d | 1403/9/10 | 1403/9/10 |
| 585 | 4.1.8.2 | **External Part** | 83d | 2024-09-16 | 2024-12-21 |  | 44d |  | 1403/6/26 | 1403/10/1 |
| 586 | 4.1.8.2.1 | **Nozzles & Manholes** | 83d | 2024-09-16 | 2024-12-21 |  | 38d |  | 1403/6/26 | 1403/10/1 |
| 587 | 4.1.8.2.1.1 | Cutting & Beveling Pipe | 1d | 2024-09-16 | 2024-09-16 | 112, 223 | 117d | 79d | 1403/6/26 | 1403/6/26 |
| 588 | 4.1.8.2.1.2 | Assembling of Pipe To Flange | 1d | 2024-12-18 | 2024-12-18 | 587, 229, 235 | 38d | 0d | 1403/9/28 | 1403/9/28 |
| 589 | 4.1.8.2.1.3 | Welding of Pipe To Flange | 2d | 2024-12-19 | 2024-12-21 | 588 | 38d | 0d | 1403/9/29 | 1403/10/1 |
| 590 | 4.1.8.2.2 | **Lifting & Other External Part** | 6d | 2024-11-25 | 2024-12-01 |  | 61d |  | 1403/9/5 | 1403/9/11 |
| 591 | 4.1.8.2.2.1 | Marking & Cutting & Beveling Lifting & Other External Part | 1d | 2024-11-25 | 2024-11-25 | 112, 226FS+10d | 61d | 0d | 1403/9/5 | 1403/9/5 |
| 592 | 4.1.8.2.2.2 | Drilling Lifting & Other External Part | 2d | 2024-11-26 | 2024-11-27 | 591 | 61d | 0d | 1403/9/6 | 1403/9/7 |
| 593 | 4.1.8.2.2.3 | Assembling of external parts together | 1d | 2024-11-28 | 2024-11-28 | 592 | 61d | 0d | 1403/9/8 | 1403/9/8 |
| 594 | 4.1.8.2.2.4 | Welding of external parts together | 2d | 2024-11-30 | 2024-12-01 | 593 | 61d | 23d | 1403/9/10 | 1403/9/11 |

| ID | WBS | Task | Duration | Start | Finish | Predecessors | Total slack | Free slack | شروع | پایان |
| --- | --- | --- | --- | --- | --- | --- | --- | --- | --- | --- |
| 595 | 4.1.8.3 | **Coil** | 10d | 2024-09-16 | 2024-09-26 |  | 120d |  | 1403/6/26 | 1403/7/5 |
| 596 | 4.1.8.3.1 | Cutting & Beveling Coil | 2d | 2024-09-16 | 2024-09-17 | 112, 223 | 120d | 0d | 1403/6/26 | 1403/6/27 |
| 597 | 4.1.8.3.2 | Assembling of coil together | 3d | 2024-09-18 | 2024-09-21 | 596 | 120d | 0d | 1403/6/28 | 1403/6/31 |
| 598 | 4.1.8.3.3 | Welding of Coil together | 5d | 2024-09-22 | 2024-09-26 | 597 | 120d | 59d | 1403/7/1 | 1403/7/5 |
| 599 | 4.1.8.4 | **Final Assembly** | 48d | 2024-12-01 | 2025-01-25 |  | 38d |  | 1403/9/11 | 1403/11/6 |
| 600 | 4.1.8.4.1 | Assembling Shell course & Body flanges | 1d | 2024-12-01 | 2024-12-01 | 584, 993 | 50d | 0d | 1403/9/11 | 1403/9/11 |
| 601 | 4.1.8.4.2 | Welding Shell course & Body flanges | 3d | 2024-12-02 | 2024-12-04 | 600 | 50d | 0d | 1403/9/12 | 1403/9/14 |
| 602 | 4.1.8.4.3 | Marking & Opening Nozzle | 2d | 2024-12-05 | 2024-12-07 | 601 | 50d | 12d | 1403/9/15 | 1403/9/17 |
| 603 | 4.1.8.4.4 | Assembling nozzel & manhole | 4d | 2024-12-22 | 2024-12-25 | 589, 602 | 38d | 0d | 1403/10/2 | 1403/10/5 |
| 604 | 4.1.8.4.5 | Welding of nozzel & manhole | 2d | 2024-12-26 | 2024-12-28 | 603, 994 | 38d | 0d | 1403/10/6 | 1403/10/8 |
| 605 | 4.1.8.4.6 | Assembling of Lifting & Other External Part | 1d | 2024-12-29 | 2024-12-29 | 594, 604 | 38d | 0d | 1403/10/9 | 1403/10/9 |
| 606 | 4.1.8.4.7 | Welding of Lifting & Other External Part | 2d | 2024-12-30 | 2024-12-31 | 605 | 38d | 0d | 1403/10/10 | 1403/10/11 |
| 607 | 4.1.8.4.8 | Assembling of Coil to Shell | 8d | 2025-01-01 | 2025-01-09 | 598, 606 | 38d | 0d | 1403/10/12 | 1403/10/20 |
| 608 | 4.1.8.4.9 | Welding of Coil to Shell | 11d | 2025-01-11 | 2025-01-22 | 607 | 38d | 0d | 1403/10/22 | 1403/11/3 |
| 609 | 4.1.8.4.10 | Final dimensional Inspection | 2d | 2025-01-23 | 2025-01-25 | 608, 995 | 38d | 0d | 1403/11/4 | 1403/11/6 |
| 610 | 4.1.8.5 | **Final Activity** | 29d | 2025-01-26 | 2025-02-27 |  | 24d |  | 1403/11/7 | 1403/12/9 |
| 611 | 4.1.8.5.1 | prepare for PWHT | 2d | 2025-01-26 | 2025-01-27 | 609 | 38d | 0d | 1403/11/7 | 1403/11/8 |
| 612 | 4.1.8.5.2 | PWHT | 1d | 2025-01-28 | 2025-01-28 | 611, 26, 23 | 38d | 0d | 1403/11/9 | 1403/11/9 |
| 613 | 4.1.8.5.3 | NDT after PWHT | 1d | 2025-01-29 | 2025-01-29 | 612 | 38d | 0d | 1403/11/10 | 1403/11/10 |
| 614 | 4.1.8.5.4 | Prepare for Hydrotest | 2d | 2025-01-30 | 2025-02-01 | 613 | 38d | 0d | 1403/11/11 | 1403/11/13 |
| 615 | 4.1.8.5.5 | Hydrotest of shell side | 2d | 2025-02-02 | 2025-02-03 | 614, 32, 996, 997, 999, 1000, 1001 | 38d | 0d | 1403/11/14 | 1403/11/15 |
| 616 | 4.1.8.5.6 | Hydrotest of Coil side | 2d | 2025-02-04 | 2025-02-05 | 615, 32 | 38d | 0d | 1403/11/16 | 1403/11/17 |
| 617 | 4.1.8.5.7 | Sanblasting & Painting | 4d | 2025-02-24 | 2025-02-27 | 616, 272, 1003, 1004, 274 | 24d | 0d | 1403/12/6 | 1403/12/9 |
| 618 | 4.1.9 | **V-130 Surge Tank** | 143d | 2024-09-16 | 2025-03-01 |  | 23d |  | 1403/6/26 | 1403/12/11 |
| 619 | 4.1.9.1 | **Shell** | 16d | 2024-11-13 | 2024-12-01 |  | 49d |  | 1403/8/23 | 1403/9/11 |
| 620 | 4.1.9.1.1 | Marking & Cutting & Beveling | 2d | 2024-11-13 | 2024-11-14 | 136, 137, 226 | 49d | 0d | 1403/8/23 | 1403/8/24 |
| 621 | 4.1.9.1.2 | Pre- Assembling & Per-Welding of Plates | 2d | 2024-11-16 | 2024-11-17 | 620, 142, 1007 | 49d | 0d | 1403/8/26 | 1403/8/27 |
| 622 | 4.1.9.1.3 | Rolling | 4d | 2024-11-18 | 2024-11-21 | 621 | 49d | 0d | 1403/8/28 | 1403/9/1 |
| 623 | 4.1.9.1.4 | Assemble & Welding of Plates | 5d | 2024-11-23 | 2024-11-27 | 622 | 49d | 0d | 1403/9/3 | 1403/9/7 |
| 624 | 4.1.9.1.5 | Rerolling | 3d | 2024-11-28 | 2024-12-01 | 623 | 49d | 20d | 1403/9/8 | 1403/9/11 |

| ID | WBS | Task | Duration | Start | Finish | Predecessors | Total slack | Free slack | شروع | پایان |
| --- | --- | --- | --- | --- | --- | --- | --- | --- | --- | --- |
| 625 | 4.1.9.2 | **Head** | 36d | 2024-11-13 | 2024-12-24 |  | 29d |  | 1403/8/23 | 1403/10/4 |
| 626 | 4.1.9.2.1 | Marking & Cutting & Beveling head plate | 6d | 2024-11-13 | 2024-11-19 | 136, 137, 226 | 29d | 0d | 1403/8/23 | 1403/8/29 |
| 627 | 4.1.9.2.2 | Forming Head plate (sub contractor) | 30d | 2024-11-20 | 2024-12-24 | 626 | 29d | 0d | 1403/8/30 | 1403/10/4 |
| 628 | 4.1.9.3 | **External Part** | 90d | 2024-09-16 | 2024-12-29 |  | 38d |  | 1403/6/26 | 1403/10/9 |
| 629 | 4.1.9.3.1 | **Nozzles & Manholes** | 90d | 2024-09-16 | 2024-12-29 |  | 31d |  | 1403/6/26 | 1403/10/9 |
| 630 | 4.1.9.3.1.1 | Cutting & Beveling Pipe | 3d | 2024-09-16 | 2024-09-18 | 138, 223 | 108d | 77d | 1403/6/26 | 1403/6/28 |
| 631 | 4.1.9.3.1.2 | Assembling of Pipe To Flange | 4d | 2024-12-18 | 2024-12-22 | 630, 229, 235 | 31d | 0d | 1403/9/28 | 1403/10/2 |
| 632 | 4.1.9.3.1.3 | Welding of Pipe To Flange | 6d | 2024-12-23 | 2024-12-29 | 631 | 31d | 2d | 1403/10/3 | 1403/10/9 |
| 633 | 4.1.9.3.2 | **Lifting & Other External Part** | 18d | 2024-11-13 | 2024-12-03 |  | 60d |  | 1403/8/23 | 1403/9/13 |
| 634 | 4.1.9.3.2.1 | Marking & Cutting & Beveling Lifting & Other External Part | 2d | 2024-11-13 | 2024-11-14 | 139, 226 | 60d | 0d | 1403/8/23 | 1403/8/24 |
| 635 | 4.1.9.3.2.2 | Drilling Lifting & Other External Part | 4d | 2024-11-16 | 2024-11-19 | 634 | 60d | 0d | 1403/8/26 | 1403/8/29 |
| 636 | 4.1.9.3.2.3 | Assembling of external parts together | 4d | 2024-11-20 | 2024-11-24 | 635 | 60d | 0d | 1403/8/30 | 1403/9/4 |
| 637 | 4.1.9.3.2.4 | Welding of external parts together | 8d | 2024-11-25 | 2024-12-03 | 636 | 60d | 31d | 1403/9/5 | 1403/9/13 |
| 638 | 4.1.9.4 | **Internal Part** | 10d | 2024-11-13 | 2024-11-24 |  | 85d |  | 1403/8/23 | 1403/9/4 |
| 639 | 4.1.9.4.1 | Marking & Cutting & Beveling Internal Part | 2d | 2024-11-13 | 2024-11-14 | 139, 226 | 85d | 0d | 1403/8/23 | 1403/8/24 |
| 640 | 4.1.9.4.2 | Drilling Internal Part | 2d | 2024-11-16 | 2024-11-17 | 639 | 85d | 0d | 1403/8/26 | 1403/8/27 |
| 641 | 4.1.9.4.3 | Assembling of Internal parts together | 2d | 2024-11-18 | 2024-11-19 | 640 | 85d | 0d | 1403/8/28 | 1403/8/29 |
| 642 | 4.1.9.4.4 | Welding of Internal parts together | 4d | 2024-11-20 | 2024-11-24 | 641 | 85d | 56d | 1403/8/30 | 1403/9/4 |
| 643 | 4.1.9.5 | **Final Assembly** | 37d | 2024-12-25 | 2025-02-05 |  | 29d |  | 1403/10/5 | 1403/11/17 |
| 644 | 4.1.9.5.1 | Assembling Shell course & head | 2d | 2024-12-25 | 2024-12-26 | 624, 627, 1008 | 29d | 0d | 1403/10/5 | 1403/10/6 |
| 645 | 4.1.9.5.2 | Welding Shell course & head | 2d | 2024-12-28 | 2024-12-29 | 644 | 29d | 0d | 1403/10/8 | 1403/10/9 |
| 646 | 4.1.9.5.3 | Marking & Opening Nozzle | 2d | 2024-12-30 | 2024-12-31 | 645 | 29d | 0d | 1403/10/10 | 1403/10/11 |
| 647 | 4.1.9.5.4 | Assembling nozzel & manhole | 2d | 2025-01-01 | 2025-01-02 | 632, 646 | 29d | 0d | 1403/10/12 | 1403/10/13 |
| 648 | 4.1.9.5.5 | Welding of nozzel & manhole | 5d | 2025-01-04 | 2025-01-08 | 647, 1009 | 29d | 0d | 1403/10/15 | 1403/10/19 |
| 649 | 4.1.9.5.6 | Assembling of Lifting & Other External Part | 8d | 2025-01-09 | 2025-01-18 | 637, 648 | 29d | 0d | 1403/10/20 | 1403/10/29 |
| 650 | 4.1.9.5.7 | Welding of Lifting & Other External Part | 9d | 2025-01-19 | 2025-01-28 | 649 | 29d | 0d | 1403/10/30 | 1403/11/9 |
| 651 | 4.1.9.5.8 | Assembling of internal parts | 3d | 2025-01-29 | 2025-02-01 | 642, 650 | 29d | 0d | 1403/11/10 | 1403/11/13 |
| 652 | 4.1.9.5.9 | Welding of Internal parts | 2d | 2025-02-02 | 2025-02-03 | 651 | 29d | 0d | 1403/11/14 | 1403/11/15 |
| 653 | 4.1.9.5.10 | Final dimensional Inspection | 2d | 2025-02-04 | 2025-02-05 | 652, 1010 | 29d | 0d | 1403/11/16 | 1403/11/17 |

| ID | WBS | Task | Duration | Start | Finish | Predecessors | Total slack | Free slack | شروع | پایان |
| --- | --- | --- | --- | --- | --- | --- | --- | --- | --- | --- |
| 654 | 4.1.9.6 | **Final Activity** | 20d | 2025-02-06 | 2025-03-01 |  | 23d |  | 1403/11/18 | 1403/12/11 |
| 655 | 4.1.9.6.1 | prepare for PWHT | 2d | 2025-02-06 | 2025-02-08 | 653 | 29d | 0d | 1403/11/18 | 1403/11/20 |
| 656 | 4.1.9.6.2 | PWHT | 1d | 2025-02-09 | 2025-02-09 | 655, 26, 23 | 29d | 0d | 1403/11/21 | 1403/11/21 |
| 657 | 4.1.9.6.3 | NDT after PWHT | 2d | 2025-02-10 | 2025-02-11 | 656 | 29d | 0d | 1403/11/22 | 1403/11/23 |
| 658 | 4.1.9.6.4 | Prepare for Hydrotest | 1d | 2025-02-12 | 2025-02-12 | 657 | 29d | 0d | 1403/11/24 | 1403/11/24 |
| 659 | 4.1.9.6.5 | Hydrotest | 2d | 2025-02-13 | 2025-02-15 | 658, 31, 1011, 1012, 1014, 1015, 1016 | 29d | 0d | 1403/11/25 | 1403/11/27 |
| 660 | 4.1.9.6.6 | Sanblasting & Painting | 5d | 2025-02-24 | 2025-03-01 | 659, 272, 1018, 1019, 274 | 23d | 0d | 1403/12/6 | 1403/12/11 |
| 661 | 4.2 | **Heat exchanger** | 142d | 2024-09-16 | 2025-02-27 |  | 30d |  | 1403/6/26 | 1403/12/9 |
| 662 | 4.2.1 | **E -200 Rich-Lean HE** | 142d | 2024-09-16 | 2025-02-27 |  | 30d |  | 1403/6/26 | 1403/12/9 |
| 663 | 4.2.1.1 | **Shell** | 5d | 2024-11-23 | 2024-11-27 |  | 49d |  | 1403/9/3 | 1403/9/7 |
| 664 | 4.2.1.1.1 | Marking & Cutting & Beveling | 1d | 2024-11-23 | 2024-11-23 | 116, 117, 226FS+8d | 49d | 0d | 1403/9/3 | 1403/9/3 |
| 665 | 4.2.1.1.2 | Pre- Assembling & Per-Welding of Plates | 1d | 2024-11-24 | 2024-11-24 | 664, 1023 | 49d | 0d | 1403/9/4 | 1403/9/4 |
| 666 | 4.2.1.1.3 | Rolling | 1d | 2024-11-25 | 2024-11-25 | 665 | 49d | 0d | 1403/9/5 | 1403/9/5 |
| 667 | 4.2.1.1.4 | Assemble & Welding of Plates | 1d | 2024-11-26 | 2024-11-26 | 666 | 49d | 0d | 1403/9/6 | 1403/9/6 |
| 668 | 4.2.1.1.5 | Rerolling | 1d | 2024-11-27 | 2024-11-27 | 667 | 49d | 0d | 1403/9/7 | 1403/9/7 |
| 669 | 4.2.1.2 | **External Part** | 83d | 2024-09-16 | 2024-12-21 |  | 35d |  | 1403/6/26 | 1403/10/1 |
| 670 | 4.2.1.2.1 | **Nozzles & Manholes** | 83d | 2024-09-16 | 2024-12-21 |  | 32d |  | 1403/6/26 | 1403/10/1 |
| 671 | 4.2.1.2.1.1 | Cutting& Beveling Pipe | 1d | 2024-09-16 | 2024-09-16 | 117, 223 | 111d | 79d | 1403/6/26 | 1403/6/26 |
| 672 | 4.2.1.2.1.2 | Assembling of Pipe To Flange | 1d | 2024-12-18 | 2024-12-18 | 671, 229, 235 | 32d | 0d | 1403/9/28 | 1403/9/28 |
| 673 | 4.2.1.2.1.3 | Welding of Pipe To Flange | 2d | 2024-12-19 | 2024-12-21 | 672 | 32d | 0d | 1403/9/29 | 1403/10/1 |
| 674 | 4.2.1.2.2 | **Lifting & Other External Part** | 6d | 2024-11-25 | 2024-12-01 |  | 52d |  | 1403/9/5 | 1403/9/11 |
| 675 | 4.2.1.2.2.1 | Marking& Cutting & Beveling Lifting & Other External Part | 1d | 2024-11-25 | 2024-11-25 | 117, 226FS+10d | 52d | 0d | 1403/9/5 | 1403/9/5 |
| 676 | 4.2.1.2.2.2 | Drilling Lifting& Other External Part | 2d | 2024-11-26 | 2024-11-27 | 675 | 52d | 0d | 1403/9/6 | 1403/9/7 |
| 677 | 4.2.1.2.2.3 | Assembling of external parts together | 1d | 2024-11-28 | 2024-11-28 | 676 | 52d | 0d | 1403/9/8 | 1403/9/8 |
| 678 | 4.2.1.2.2.4 | Welding of external parts together | 2d | 2024-11-30 | 2024-12-01 | 677 | 52d | 20d | 1403/9/10 | 1403/9/11 |

| ID | WBS | Task | Duration | Start | Finish | Predecessors | Total slack | Free slack | شروع | پایان |
| --- | --- | --- | --- | --- | --- | --- | --- | --- | --- | --- |
| 679 | 4.2.1.3 | **Internal Plate** | 5d | 2024-11-13 | 2024-11-18 |  | 117d |  | 1403/8/23 | 1403/8/28 |
| 680 | 4.2.1.3.1 | Marking & Cutting & Beveling Internal plate | 2d | 2024-11-13 | 2024-11-14 | 117, 226 | 117d | 0d | 1403/8/23 | 1403/8/24 |
| 681 | 4.2.1.3.2 | Assembling of Internal plate together | 3d | 2024-11-16 | 2024-11-18 | 680 | 117d |  | 1403/8/26 | 1403/8/28 |
| 682 | 4.2.1.4 | **Final Assembly** | 56d | 2024-11-28 | 2025-02-01 |  | 32d |  | 1403/9/8 | 1403/11/13 |
| 683 | 4.2.1.4.1 | Assembling Shell course & Body flanges | 1d | 2024-11-28 | 2024-11-28 | 668, 1024 | 49d | 0d | 1403/9/8 | 1403/9/8 |
| 684 | 4.2.1.4.2 | Welding Shell course & Body flanges | 1d | 2024-11-30 | 2024-11-30 | 683 | 49d | 0d | 1403/9/10 | 1403/9/10 |
| 685 | 4.2.1.4.3 | Marking & Opening Nozzle | 1d | 2024-12-01 | 2024-12-01 | 684 | 49d | 17d | 1403/9/11 | 1403/9/11 |
| 686 | 4.2.1.4.4 | Assembling nozzel & manhole | 1d | 2024-12-22 | 2024-12-22 | 673, 685 | 32d | 0d | 1403/10/2 | 1403/10/2 |
| 687 | 4.2.1.4.5 | Welding of nozzel & manhole | 2d | 2024-12-23 | 2024-12-24 | 686, 1026 | 32d | 0d | 1403/10/3 | 1403/10/4 |
| 688 | 4.2.1.4.6 | Assembling of Lifting & Other External Part | 1d | 2024-12-25 | 2024-12-25 | 678, 687 | 32d | 0d | 1403/10/5 | 1403/10/5 |
| 689 | 4.2.1.4.7 | Welding of Lifting & Other External Part | 2d | 2024-12-26 | 2024-12-28 | 688 | 32d | 0d | 1403/10/6 | 1403/10/8 |
| 690 | 4.2.1.4.8 | Assembling of Internal plate to Shell | 14d | 2024-12-29 | 2025-01-13 | 689 | 32d | 0d | 1403/10/9 | 1403/10/24 |
| 691 | 4.2.1.4.9 | Welding of Internal plate to Shell | 14d | 2025-01-14 | 2025-01-29 | 690 | 32d | 0d | 1403/10/25 | 1403/11/10 |
| 692 | 4.2.1.4.10 | Final dimensional Inspection | 2d | 2025-01-30 | 2025-02-01 | 691, 1025, 1027 | 32d | 0d | 1403/11/11 | 1403/11/13 |
| 693 | 4.2.1.5 | **Final Activity** | 23d | 2025-02-02 | 2025-02-27 |  | 24d |  | 1403/11/14 | 1403/12/9 |
| 694 | 4.2.1.5.1 | prepare for PWHT | 2d | 2025-02-02 | 2025-02-03 | 692 | 32d | 0d | 1403/11/14 | 1403/11/15 |
| 695 | 4.2.1.5.2 | PWHT | 1d | 2025-02-04 | 2025-02-04 | 694, 26, 23 | 32d | 0d | 1403/11/16 | 1403/11/16 |
| 696 | 4.2.1.5.3 | NDT after PWHT | 1d | 2025-02-05 | 2025-02-05 | 695 | 32d | 0d | 1403/11/17 | 1403/11/17 |
| 697 | 4.2.1.5.4 | Prepare for Hydrotest | 2d | 2025-02-06 | 2025-02-08 | 696 | 32d | 0d | 1403/11/18 | 1403/11/20 |
| 698 | 4.2.1.5.5 | Hydrotest of shell side | 2d | 2025-02-09 | 2025-02-10 | 697, 32, 1028, 1029, 1031, 1032, 1033 | 32d | 0d | 1403/11/21 | 1403/11/22 |
| 699 | 4.2.1.5.6 | Hydrotest of internal side side | 2d | 2025-02-11 | 2025-02-12 | 698, 32 | 32d | 0d | 1403/11/23 | 1403/11/24 |
| 700 | 4.2.1.5.7 | Sanblasting & Painting | 4d | 2025-02-24 | 2025-02-27 | 699, 272, 1035, 1036, 274 | 24d | 0d | 1403/12/6 | 1403/12/9 |
| 701 | 4.2.2 | **E -300 LEAN TEG - DRY GAS EXCH** | 142d | 2024-09-16 | 2025-02-27 |  | 24d |  | 1403/6/26 | 1403/12/9 |
| 702 | 4.2.2.1 | **Shell** | 5d | 2024-11-13 | 2024-11-18 |  | 54d |  | 1403/8/23 | 1403/8/28 |
| 703 | 4.2.2.1.1 | Marking & Cutting & Beveling | 1d | 2024-11-13 | 2024-11-13 | 121, 122, 226 | 54d | 0d | 1403/8/23 | 1403/8/23 |
| 704 | 4.2.2.1.2 | Pre- Assembling & Per-Welding of Plates | 1d | 2024-11-14 | 2024-11-14 | 703, 1039 | 54d | 0d | 1403/8/24 | 1403/8/24 |
| 705 | 4.2.2.1.3 | Rolling | 1d | 2024-11-16 | 2024-11-16 | 704 | 54d | 0d | 1403/8/26 | 1403/8/26 |
| 706 | 4.2.2.1.4 | Assemble & Welding of Plates | 1d | 2024-11-17 | 2024-11-17 | 705 | 54d | 0d | 1403/8/27 | 1403/8/27 |
| 707 | 4.2.2.1.5 | Rerolling | 1d | 2024-11-18 | 2024-11-18 | 706 | 54d | 0d | 1403/8/28 | 1403/8/28 |

| ID | WBS | Task | Duration | Start | Finish | Predecessors | Total slack | Free slack | شروع | پایان |
| --- | --- | --- | --- | --- | --- | --- | --- | --- | --- | --- |
| 708 | 4.2.2.2 | **External Part** | 83d | 2024-09-16 | 2024-12-21 |  | 32d |  | 1403/6/26 | 1403/10/1 |
| 709 | 4.2.2.2.1 | **Nozzles & Manholes** | 83d | 2024-09-16 | 2024-12-21 |  | 29d |  | 1403/6/26 | 1403/10/1 |
| 710 | 4.2.2.2.1.1 | Cutting & Beveling Pipe | 1d | 2024-09-16 | 2024-09-16 | 122, 223 | 108d | 79d | 1403/6/26 | 1403/6/26 |
| 711 | 4.2.2.2.1.2 | Assembling of Pipe To Flange | 1d | 2024-12-18 | 2024-12-18 | 710, 229, 235 | 29d | 0d | 1403/9/28 | 1403/9/28 |
| 712 | 4.2.2.2.1.3 | Welding of Pipe To Flange | 2d | 2024-12-19 | 2024-12-21 | 711 | 29d | 0d | 1403/9/29 | 1403/10/1 |
| 713 | 4.2.2.2.2 | **Lifting & Other External Part** | 6d | 2024-11-13 | 2024-11-19 |  | 59d |  | 1403/8/23 | 1403/8/29 |
| 714 | 4.2.2.2.2.1 | Marking & Cutting & Beveling Lifting & Other External Part | 1d | 2024-11-13 | 2024-11-13 | 122, 226 | 59d | 0d | 1403/8/23 | 1403/8/23 |
| 715 | 4.2.2.2.2.2 | Drilling Lifting & Other External Part | 2d | 2024-11-14 | 2024-11-16 | 714 | 59d | 0d | 1403/8/24 | 1403/8/26 |
| 716 | 4.2.2.2.2.3 | Assembling of external parts together | 1d | 2024-11-17 | 2024-11-17 | 715 | 59d | 0d | 1403/8/27 | 1403/8/27 |
| 717 | 4.2.2.2.2.4 | Welding of external parts together | 2d | 2024-11-18 | 2024-11-19 | 716 | 59d | 30d | 1403/8/28 | 1403/8/29 |
| 718 | 4.2.2.3 | **Tube Bundle** | 33d | 2024-11-13 | 2024-12-21 |  | 35d |  | 1403/8/23 | 1403/10/1 |
| 719 | 4.2.2.3.1 | Cutting & Beveling of Baffles & Tie rod & Spacer &Stripper | 4d | 2024-11-13 | 2024-11-17 | 122, 223, 226 | 35d | 0d | 1403/8/23 | 1403/8/27 |
| 720 | 4.2.2.3.2 | Drilling of Baffles | 5d | 2024-11-18 | 2024-11-23 | 719 | 35d | 0d | 1403/8/28 | 1403/9/3 |
| 721 | 4.2.2.3.3 | Assembling of Tube & Tie rod & Spacer &Stripper in to Baffles | 11d | 2024-11-24 | 2024-12-05 | 720 | 35d | 0d | 1403/9/4 | 1403/9/15 |
| 722 | 4.2.2.3.4 | Welding of Tube & Tie rod & Spacer &Stripper in to Baffles | 13d | 2024-12-07 | 2024-12-21 | 721 | 35d | 6d | 1403/9/17 | 1403/10/1 |
| 723 | 4.2.2.4 | **Final Assembly** | 67d | 2024-11-19 | 2025-02-04 |  | 29d |  | 1403/8/29 | 1403/11/16 |
| 724 | 4.2.2.4.1 | Assembling Shell course & Body flanges | 1d | 2024-11-19 | 2024-11-19 | 707, 1040 | 54d | 0d | 1403/8/29 | 1403/8/29 |
| 725 | 4.2.2.4.2 | Welding Shell course & Body flanges | 1d | 2024-11-20 | 2024-11-20 | 724 | 54d | 0d | 1403/8/30 | 1403/8/30 |
| 726 | 4.2.2.4.3 | Marking & Opening Nozzle | 1d | 2024-11-21 | 2024-11-21 | 725 | 54d | 25d | 1403/9/1 | 1403/9/1 |
| 727 | 4.2.2.4.4 | Assembling nozzel & manhole | 1d | 2024-12-22 | 2024-12-22 | 712, 726 | 29d | 0d | 1403/10/2 | 1403/10/2 |
| 728 | 4.2.2.4.5 | Welding of nozzel & manhole | 2d | 2024-12-23 | 2024-12-24 | 727, 1042 | 29d | 0d | 1403/10/3 | 1403/10/4 |
| 729 | 4.2.2.4.6 | Assembling of Lifting & Other External Part | 1d | 2024-12-25 | 2024-12-25 | 717, 728 | 29d | 0d | 1403/10/5 | 1403/10/5 |
| 730 | 4.2.2.4.7 | Welding of Lifting & Other External Part | 2d | 2024-12-26 | 2024-12-28 | 729 | 29d | 0d | 1403/10/6 | 1403/10/8 |
| 731 | 4.2.2.4.8 | Assembling of Tube bandle& Tube Sheet to Shell | 8d | 2024-12-29 | 2025-01-06 | 722, 730 | 29d | 0d | 1403/10/9 | 1403/10/17 |
| 732 | 4.2.2.4.9 | Welding of Tube bandle& tube SheetT to Shell | 11d | 2025-01-07 | 2025-01-19 | 731 | 29d | 0d | 1403/10/18 | 1403/10/30 |
| 733 | 4.2.2.4.10 | Welding of tube to tubesheet | 7d | 2025-01-20 | 2025-01-27 | 732 | 29d | 0d | 1403/11/1 | 1403/11/8 |
| 734 | 4.2.2.4.11 | Expanding of Tube sheet | 5d | 2025-01-28 | 2025-02-02 | 733 | 29d | 0d | 1403/11/9 | 1403/11/14 |
| 735 | 4.2.2.4.12 | Final dimensional Inspection | 2d | 2025-02-03 | 2025-02-04 | 734, 1041, 1043 | 29d | 0d | 1403/11/15 | 1403/11/16 |

| ID | WBS | Task | Duration | Start | Finish | Predecessors | Total slack | Free slack | شروع | پایان |
| --- | --- | --- | --- | --- | --- | --- | --- | --- | --- | --- |
| 736 | 4.2.2.5 | **Final Activity** | 20d | 2025-02-05 | 2025-02-27 |  | 24d |  | 1403/11/17 | 1403/12/9 |
| 737 | 4.2.2.5.1 | prepare for PWHT | 2d | 2025-02-05 | 2025-02-06 | 735 | 29d | 0d | 1403/11/17 | 1403/11/18 |
| 738 | 4.2.2.5.2 | PWHT | 1d | 2025-02-08 | 2025-02-08 | 737, 26, 23 | 29d | 0d | 1403/11/20 | 1403/11/20 |
| 739 | 4.2.2.5.3 | NDT after PWHT | 1d | 2025-02-09 | 2025-02-09 | 738 | 29d | 0d | 1403/11/21 | 1403/11/21 |
| 740 | 4.2.2.5.4 | Prepare for Hydrotest | 2d | 2025-02-10 | 2025-02-11 | 739 | 29d | 0d | 1403/11/22 | 1403/11/23 |
| 741 | 4.2.2.5.5 | Hydrotest of shell side | 2d | 2025-02-12 | 2025-02-13 | 740, 32, 1044, 1045, 1047, 1048, 1049 | 29d | 0d | 1403/11/24 | 1403/11/25 |
| 742 | 4.2.2.5.6 | Hydrotest of tube side | 2d | 2025-02-15 | 2025-02-16 | 741, 32 | 29d | 0d | 1403/11/27 | 1403/11/28 |
| 743 | 4.2.2.5.7 | Sanblasting & Painting | 4d | 2025-02-24 | 2025-02-27 | 742, 272, 1051, 1052, 274 | 24d | 0d | 1403/12/6 | 1403/12/9 |
| 744 | 4.3 | **R-100 Reboiler** | 142d | 2024-09-16 | 2025-02-27 |  | 24d |  | 1403/6/26 | 1403/12/9 |
| 745 | 4.3.1 | **Shell** | 7d | 2024-11-13 | 2024-11-20 |  | 62d |  | 1403/8/23 | 1403/8/30 |
| 746 | 4.3.1.1 | Marking & Cutting & Beveling | 1d | 2024-11-13 | 2024-11-13 | 126, 127, 226 | 62d | 0d | 1403/8/23 | 1403/8/23 |
| 747 | 4.3.1.2 | Pre- Assembling & Per-Welding of Plates | 1d | 2024-11-14 | 2024-11-14 | 746, 133, 1055 | 62d | 0d | 1403/8/24 | 1403/8/24 |
| 748 | 4.3.1.3 | Rolling | 2d | 2024-11-16 | 2024-11-17 | 747 | 62d | 0d | 1403/8/26 | 1403/8/27 |
| 749 | 4.3.1.4 | Assemble & Welding of Plates | 2d | 2024-11-18 | 2024-11-19 | 748 | 62d | 0d | 1403/8/28 | 1403/8/29 |
| 750 | 4.3.1.5 | Rerolling | 1d | 2024-11-20 | 2024-11-20 | 749 | 62d | 25d | 1403/8/30 | 1403/8/30 |
| 751 | 4.3.2 | **Head** | 32d | 2024-11-13 | 2024-12-19 |  | 37d |  | 1403/8/23 | 1403/9/29 |
| 752 | 4.3.2.1 | Marking & Cutting & Beveling head plate | 2d | 2024-11-13 | 2024-11-14 | 126, 127, 226 | 37d | 0d | 1403/8/23 | 1403/8/24 |
| 753 | 4.3.2.2 | Forming Head plate (sub contractor) | 30d | 2024-11-16 | 2024-12-19 | 752 | 37d | 0d | 1403/8/26 | 1403/9/29 |
| 754 | 4.3.3 | **External Part** | 93d | 2024-09-16 | 2025-01-01 |  | 46d |  | 1403/6/26 | 1403/10/12 |
| 755 | 4.3.3.1 | **Nozzles & Manholes** | 93d | 2024-09-16 | 2025-01-01 |  | 39d |  | 1403/6/26 | 1403/10/12 |
| 756 | 4.3.3.1.1 | Cutting & Beveling Pipe | 5d | 2024-09-16 | 2024-09-21 | 128, 223 | 114d | 75d | 1403/6/26 | 1403/6/31 |
| 757 | 4.3.3.1.2 | Assembling of Pipe To Flange | 4d | 2024-12-18 | 2024-12-22 | 756, 229, 235 | 39d | 0d | 1403/9/28 | 1403/10/2 |
| 758 | 4.3.3.1.3 | Welding of Pipe To Flange | 9d | 2024-12-23 | 2025-01-01 | 757 | 39d | 2d | 1403/10/3 | 1403/10/12 |
| 759 | 4.3.3.2 | **Lifting & Other External Part** | 16d | 2024-11-13 | 2024-12-01 |  | 73d |  | 1403/8/23 | 1403/9/11 |
| 760 | 4.3.3.2.1 | Marking & Cutting & Beveling Lifting & Other External Part | 2d | 2024-11-13 | 2024-11-14 | 130, 226 | 73d | 0d | 1403/8/23 | 1403/8/24 |
| 761 | 4.3.3.2.2 | Drilling Lifting & Other External Part | 4d | 2024-11-16 | 2024-11-19 | 760 | 73d | 0d | 1403/8/26 | 1403/8/29 |
| 762 | 4.3.3.2.3 | Assembling of external parts together | 4d | 2024-11-20 | 2024-11-24 | 761 | 73d | 0d | 1403/8/30 | 1403/9/4 |
| 763 | 4.3.3.2.4 | Welding of external parts together | 6d | 2024-11-25 | 2024-12-01 | 762 | 73d | 36d | 1403/9/5 | 1403/9/11 |

| ID | WBS | Task | Duration | Start | Finish | Predecessors | Total slack | Free slack | شروع | پایان |
| --- | --- | --- | --- | --- | --- | --- | --- | --- | --- | --- |
| 764 | 4.3.4 | **Internal Part** | 9d | 2024-11-13 | 2024-11-23 |  | 87d |  | 1403/8/23 | 1403/9/3 |
| 765 | 4.3.4.1 | Marking & Cutting & Beveling Internal Part | 1d | 2024-11-13 | 2024-11-13 | 130, 226 | 87d | 0d | 1403/8/23 | 1403/8/23 |
| 766 | 4.3.4.2 | Drilling Internal Part | 2d | 2024-11-14 | 2024-11-16 | 765 | 87d | 0d | 1403/8/24 | 1403/8/26 |
| 767 | 4.3.4.3 | Assembling of Internal parts together | 2d | 2024-11-17 | 2024-11-18 | 766 | 87d | 0d | 1403/8/27 | 1403/8/28 |
| 768 | 4.3.4.4 | Welding of Internal parts together | 4d | 2024-11-19 | 2024-11-23 | 767 | 87d | 50d | 1403/8/29 | 1403/9/3 |
| 769 | 4.3.5 | **Final Assembly** | 35d | 2024-12-21 | 2025-01-29 |  | 37d |  | 1403/10/1 | 1403/11/10 |
| 770 | 4.3.5.1 | Assembling Shell course & head | 5d | 2024-12-21 | 2024-12-25 | 750, 753, 1056 | 37d | 0d | 1403/10/1 | 1403/10/5 |
| 771 | 4.3.5.2 | Welding Shell course & head | 6d | 2024-12-26 | 2025-01-01 | 770 | 37d | 0d | 1403/10/6 | 1403/10/12 |
| 772 | 4.3.5.3 | Marking & Opening Nozzle | 2d | 2025-01-02 | 2025-01-04 | 771 | 37d | 0d | 1403/10/13 | 1403/10/15 |
| 773 | 4.3.5.4 | Assembling nozzel & manhole | 2d | 2025-01-05 | 2025-01-06 | 758, 772 | 37d | 0d | 1403/10/16 | 1403/10/17 |
| 774 | 4.3.5.5 | Welding of nozzel & manhole | 5d | 2025-01-07 | 2025-01-12 | 773, 1057 | 37d | 0d | 1403/10/18 | 1403/10/23 |
| 775 | 4.3.5.6 | Assembling of Lifting & Other External Part | 3d | 2025-01-13 | 2025-01-15 | 763, 774 | 37d | 0d | 1403/10/24 | 1403/10/26 |
| 776 | 4.3.5.7 | Welding of Lifting & Other External Part | 4d | 2025-01-16 | 2025-01-20 | 775 | 37d | 0d | 1403/10/27 | 1403/11/1 |
| 777 | 4.3.5.8 | Assembling of internal parts | 2d | 2025-01-21 | 2025-01-22 | 768, 776 | 37d | 0d | 1403/11/2 | 1403/11/3 |
| 778 | 4.3.5.9 | Welding of Internal parts | 4d | 2025-01-23 | 2025-01-27 | 777 | 37d | 0d | 1403/11/4 | 1403/11/8 |
| 779 | 4.3.5.10 | Final dimensional Inspection | 2d | 2025-01-28 | 2025-01-29 | 778, 1058 | 37d | 0d | 1403/11/9 | 1403/11/10 |
| 780 | 4.3.6 | **Final Activity** | 25d | 2025-01-30 | 2025-02-27 |  | 24d |  | 1403/11/11 | 1403/12/9 |
| 781 | 4.3.6.1 | prepare for PWHT | 2d | 2025-01-30 | 2025-02-01 | 779 | 37d | 0d | 1403/11/11 | 1403/11/13 |
| 782 | 4.3.6.2 | PWHT | 1d | 2025-02-02 | 2025-02-02 | 781, 26, 23 | 37d | 0d | 1403/11/14 | 1403/11/14 |
| 783 | 4.3.6.3 | NDT after PWHT | 1d | 2025-02-03 | 2025-02-03 | 782 | 37d | 0d | 1403/11/15 | 1403/11/15 |
| 784 | 4.3.6.4 | Prepare for Hydrotest | 1d | 2025-02-04 | 2025-02-04 | 783 | 37d | 0d | 1403/11/16 | 1403/11/16 |
| 785 | 4.3.6.5 | Hydrotest | 2d | 2025-02-05 | 2025-02-06 | 784, 31, 1059, 1060, 1062, 1063, 1064 | 37d | 0d | 1403/11/17 | 1403/11/18 |
| 786 | 4.3.6.6 | Sanblasting & Painting | 4d | 2025-02-24 | 2025-02-27 | 785, 272, 1066, 1067, 274 | 24d | 0d | 1403/12/6 | 1403/12/9 |
| 787 | 4.4 | **Skid of Gas Dehydration** | 116d | 2024-11-13 | 2025-04-14 |  | 0d |  | 1403/8/23 | 1404/1/25 |
| 788 | 4.4.1 | **Profile and Plate** | 70d | 2024-11-13 | 2025-02-02 |  | 34d |  | 1403/8/23 | 1403/11/14 |
| 789 | 4.4.1.1 | Marking & Cutting & Beveling of Profile and Plate | 15d | 2024-11-13 | 2024-11-30 | 155, 226, 259 | 34d | 0d | 1403/8/23 | 1403/9/10 |
| 790 | 4.4.1.2 | Drilling Profile and Plate | 15d | 2024-12-01 | 2024-12-17 | 789 | 34d | 0d | 1403/9/11 | 1403/9/27 |
| 791 | 4.4.1.3 | Assembling of Profile and Plate together | 20d | 2024-12-18 | 2025-01-09 | 790 | 34d | 0d | 1403/9/28 | 1403/10/20 |
| 792 | 4.4.1.4 | Welding of Profile and Plate together | 20d | 2025-01-11 | 2025-02-02 | 791 | 34d |  | 1403/10/22 | 1403/11/14 |

| ID | WBS | Task | Duration | Start | Finish | Predecessors | Total slack | Free slack | شروع | پایان |
| --- | --- | --- | --- | --- | --- | --- | --- | --- | --- | --- |
| 793 | 4.4.2 | **Final Activity** | 12d | 2025-03-15 | 2025-04-14 |  | 0d |  | 1403/12/25 | 1404/1/25 |
| 794 | 4.4.2.1 | Final dimensional Inspection | 9d | 2025-03-15 | 2025-04-10 | 792, 220, 241, 244, 250, 253, 256, 262, 265, 268 | 0d |  | 1403/12/25 | 1404/1/21 |
| 795 | 4.4.2.2 | Sanblasting & Painting | 3d | 2025-04-12 | 2025-04-14 | 794, 272, 1070, 274 | 0d |  | 1404/1/23 | 1404/1/25 |
| 796 | 4.5 | **Piping of Gas Dehydration** | 152d | 2024-09-16 | 2025-03-11 |  | 14d |  | 1403/6/26 | 1403/12/21 |
| 797 | 4.5.1 | **Piping and External support** | 122d | 2024-09-16 | 2025-02-04 |  | 14d |  | 1403/6/26 | 1403/11/16 |
| 798 | 4.5.1.1 | Cutting & Beveling Pipe | 20d | 2024-09-16 | 2024-10-08 | 161, 223 | 74d | 60d | 1403/6/26 | 1403/7/17 |
| 799 | 4.5.1.2 | Assembling of Pipe To Flange | 10d | 2024-12-18 | 2024-12-29 | 798, 229, 235 | 14d | 0d | 1403/9/28 | 1403/10/9 |
| 800 | 4.5.1.3 | Welding of Pipe To Flange | 15d | 2024-12-30 | 2025-01-15 | 799 | 14d | 0d | 1403/10/10 | 1403/10/26 |
| 801 | 4.5.1.4 | Marking & Cutting & Beveling External Plate | 5d | 2025-01-16 | 2025-01-21 | 800, 226 | 14d | 0d | 1403/10/27 | 1403/11/2 |
| 802 | 4.5.1.5 | Assembling of External Plate To Pipe | 4d | 2025-01-22 | 2025-01-26 | 801 | 14d | 0d | 1403/11/3 | 1403/11/7 |
| 803 | 4.5.1.6 | Welding of External Plate To Pipe | 8d | 2025-01-27 | 2025-02-04 | 802 | 14d | 0d | 1403/11/8 | 1403/11/16 |
| 804 | 4.5.2 | **Final Activity** | 30d | 2025-02-05 | 2025-03-11 |  | 14d |  | 1403/11/17 | 1403/12/21 |
| 805 | 4.5.2.1 | prepare for PWHT | 3d | 2025-02-05 | 2025-02-08 | 803 | 14d | 0d | 1403/11/17 | 1403/11/20 |
| 806 | 4.5.2.2 | PWHT | 4d | 2025-02-09 | 2025-02-12 | 805, 26, 23 | 14d | 0d | 1403/11/21 | 1403/11/24 |
| 807 | 4.5.2.3 | NDT after PWHT | 3d | 2025-02-13 | 2025-02-16 | 806 | 14d | 0d | 1403/11/25 | 1403/11/28 |
| 808 | 4.5.2.4 | Prepare for Hydrotest | 5d | 2025-02-17 | 2025-02-22 | 807 | 14d | 0d | 1403/11/29 | 1403/12/4 |
| 809 | 4.5.2.5 | Hydrotest | 6d | 2025-02-23 | 2025-03-01 | 808, 31 | 14d | 0d | 1403/12/5 | 1403/12/11 |
| 810 | 4.5.2.6 | Sanblasting & Painting | 9d | 2025-03-02 | 2025-03-11 | 809, 272, 1072, 274 | 14d | 0d | 1403/12/12 | 1403/12/21 |
| 811 | 5 | **Test & Inspection** | 385d | 2023-12-16 | 2025-04-12 |  | 0d |  | 1402/9/25 | 1404/1/23 |
| 812 | 5.1 | **Material inspection** | 370d | 2023-12-16 | 2025-03-08 |  | 0d |  | 1402/9/25 | 1403/12/18 |
| 813 | 5.1.1 | **Field Instruments (Transmitter/ Switch/ Gauge/ Analyzer etc)** | 6d | 2024-10-30 | 2024-11-05 |  | 128d |  | 1403/8/9 | 1403/8/15 |
| 814 | 5.1.1.1 | Visual Dimensional Inspection(Appearance) | 1d | 2024-10-30 | 2024-10-30 | 220 | 128d | 0d | 1403/8/9 | 1403/8/9 |
| 815 | 5.1.1.2 | Calibration Check | 1d | 2024-10-31 | 2024-10-31 | 814 | 128d | 0d | 1403/8/10 | 1403/8/10 |
| 816 | 5.1.1.3 | Tag & Model No & Specification Check | 1d | 2024-11-02 | 2024-11-02 | 815 | 128d | 0d | 1403/8/12 | 1403/8/12 |
| 817 | 5.1.1.4 | Review Material, IP,ATEX Certificate | 1d | 2024-11-03 | 2024-11-03 | 816 | 128d | 0d | 1403/8/13 | 1403/8/13 |
| 818 | 5.1.1.5 | Pressure & Performance Test | 1d | 2024-11-04 | 2024-11-04 | 817 | 128d | 0d | 1403/8/14 | 1403/8/14 |
| 819 | 5.1.1.6 | Packing Inspection& Painting | 1d | 2024-11-05 | 2024-11-05 | 818 | 128d |  | 1403/8/15 | 1403/8/15 |

| ID | WBS | Task | Duration | Start | Finish | Predecessors | Total slack | Free slack | شروع | پایان |
| --- | --- | --- | --- | --- | --- | --- | --- | --- | --- | --- |
| 820 | 5.1.2 | **Cable, Wires & tray** | 88d | 2024-09-24 | 2025-01-04 |  | 77d |  | 1403/7/3 | 1403/10/15 |
| 821 | 5.1.2.1 | **Cable & Wires** | 2d | 2024-09-24 | 2024-09-25 |  | 163d |  | 1403/7/3 | 1403/7/4 |
| 822 | 5.1.2.1.1 | Visual Inspection | 1d | 2024-09-24 | 2024-09-24 | 268 | 163d | 0d | 1403/7/3 | 1403/7/3 |
| 823 | 5.1.2.1.2 | Type Test Sertificate or Manufacturer Catalogue | 1d | 2024-09-25 | 2024-09-25 | 822 | 163d |  | 1403/7/4 | 1403/7/4 |
| 824 | 5.1.2.2 | **Tray** | 2d | 2025-01-02 | 2025-01-04 |  | 77d |  | 1403/10/13 | 1403/10/15 |
| 825 | 5.1.2.2.1 | Material Inspection | 1d | 2025-01-02 | 2025-01-02 | 265 | 77d | 0d | 1403/10/13 | 1403/10/13 |
| 826 | 5.1.2.2.2 | Visual & Dimensional Inspection | 1d | 2025-01-04 | 2025-01-04 | 825 | 77d |  | 1403/10/15 | 1403/10/15 |
| 827 | 5.1.3 | **Filter** | 1d | 2023-12-16 | 2023-12-16 |  |  |  | 1403/7/28 | 1403/7/28 |
| 828 | 5.1.3.1 | Inspection for visual and dimensional check | 1d | 2024-10-19 | 2024-10-19 | 271 | 143d |  | 1403/7/28 | 1403/7/28 |
| 829 | 5.1.4 | **Junction Box** | 4d | 2024-12-10 | 2024-12-14 |  | 95d |  | 1403/9/20 | 1403/9/24 |
| 830 | 5.1.4.1 | Review IP, ATEX Certificate | 1d | 2024-12-10 | 2024-12-10 | 256 | 95d | 0d | 1403/9/20 | 1403/9/20 |
| 831 | 5.1.4.2 | Tag & Model No Check | 1d | 2024-12-11 | 2024-12-11 | 830 | 95d | 0d | 1403/9/21 | 1403/9/21 |
| 832 | 5.1.4.3 | Review IP, ATEX certificate | 1d | 2024-12-12 | 2024-12-12 | 831 | 95d | 0d | 1403/9/22 | 1403/9/22 |
| 833 | 5.1.4.4 | Packing inspection and painting | 1d | 2024-12-14 | 2024-12-14 | 832 | 95d |  | 1403/9/24 | 1403/9/24 |
| 834 | 5.1.5 | **Local Panel (Outdoor, Hazardous Area)** | 5d | 2024-12-10 | 2024-12-15 |  | 94d |  | 1403/9/20 | 1403/9/25 |
| 835 | 5.1.5.1 | Visual Inspection & Dimenslonal Check | 1d | 2024-12-10 | 2024-12-10 | 256 | 94d | 0d | 1403/9/20 | 1403/9/20 |
| 836 | 5.1.5.2 | Accessories Tag & Model No Check | 1d | 2024-12-11 | 2024-12-11 | 835 | 94d | 0d | 1403/9/21 | 1403/9/21 |
| 837 | 5.1.5.3 | Construction | 1d | 2024-12-12 | 2024-12-12 | 836 | 94d | 0d | 1403/9/22 | 1403/9/22 |
| 838 | 5.1.5.4 | Review IP, ATEX Certificate | 1d | 2024-12-14 | 2024-12-14 | 837 | 94d | 0d | 1403/9/24 | 1403/9/24 |
| 839 | 5.1.5.5 | Packing Inspection & Painting | 1d | 2024-12-15 | 2024-12-15 | 838 | 94d |  | 1403/9/25 | 1403/9/25 |
| 840 | 5.1.6 | **Control Panel (Indoor, Safe Area)** | 4d | 2025-01-14 | 2025-01-18 |  | 65d |  | 1403/10/25 | 1403/10/29 |
| 841 | 5.1.6.1 | Visual Inspection/ QTY & Dimensional Check | 1d | 2025-01-14 | 2025-01-14 | 217 | 65d | 0d | 1403/10/25 | 1403/10/25 |
| 842 | 5.1.6.2 | Tag & Model No Check | 1d | 2025-01-15 | 2025-01-15 | 841 | 65d | 0d | 1403/10/26 | 1403/10/26 |
| 843 | 5.1.6.3 | Function & Performance test (Power & Start-up Check, I/O Check) | 1d | 2025-01-16 | 2025-01-16 | 842 | 65d | 0d | 1403/10/27 | 1403/10/27 |
| 844 | 5.1.6.4 | Main equipment & Accessories Certificate IP , ATEX, SIL Certificate Check) | 1d | 2025-01-18 | 2025-01-18 | 843 | 65d |  | 1403/10/29 | 1403/10/29 |

| ID | WBS | Task | Duration | Start | Finish | Predecessors | Total slack | Free slack | شروع | پایان |
| --- | --- | --- | --- | --- | --- | --- | --- | --- | --- | --- |
| 845 | 5.1.7 | **Valves** | 7d | 2025-02-09 | 2025-02-16 |  | 40d |  | 1403/11/21 | 1403/11/28 |
| 846 | 5.1.7.1 | **Manual Valves** | 3d | 2025-02-09 | 2025-02-11 |  | 44d |  | 1403/11/21 | 1403/11/23 |
| 847 | 5.1.7.1.1 | Material Inspection | 1d | 2025-02-09 | 2025-02-09 | 241 | 44d | 0d | 1403/11/21 | 1403/11/21 |
| 848 | 5.1.7.1.2 | Visual and Dimensional Inspection | 1d | 2025-02-10 | 2025-02-10 | 847 | 44d | 0d | 1403/11/22 | 1403/11/22 |
| 849 | 5.1.7.1.3 | Other Required Tests | 1d | 2025-02-11 | 2025-02-11 | 848 | 44d |  | 1403/11/23 | 1403/11/23 |
| 850 | 5.1.7.2 | **Inst.Valves (Shut Down, On/Off, Control & Safety Valves)** | 7d | 2025-02-09 | 2025-02-16 |  | 40d |  | 1403/11/21 | 1403/11/28 |
| 851 | 5.1.7.2.1 | Material Inspection | 1d | 2025-02-09 | 2025-02-09 | 241 | 40d | 0d | 1403/11/21 | 1403/11/21 |
| 852 | 5.1.7.2.2 | Visual and Dimensional & QTY Inspection | 1d | 2025-02-10 | 2025-02-10 | 851 | 40d | 0d | 1403/11/22 | 1403/11/22 |
| 853 | 5.1.7.2.3 | Construction | 1d | 2025-02-11 | 2025-02-11 | 852 | 40d | 0d | 1403/11/23 | 1403/11/23 |
| 854 | 5.1.7.2.4 | Accessory | 1d | 2025-02-12 | 2025-02-12 | 853 | 40d | 0d | 1403/11/24 | 1403/11/24 |
| 855 | 5.1.7.2.5 | Pressure Test | 1d | 2025-02-13 | 2025-02-13 | 854 | 40d | 0d | 1403/11/25 | 1403/11/25 |
| 856 | 5.1.7.2.6 | Calibration | 1d | 2025-02-15 | 2025-02-15 | 855 | 40d | 0d | 1403/11/27 | 1403/11/27 |
| 857 | 5.1.7.2.7 | Performance test | 1d | 2025-02-16 | 2025-02-16 | 856 | 40d |  | 1403/11/28 | 1403/11/28 |
| 858 | 5.1.8 | **Strainers** | 3d | 2024-09-16 | 2024-09-18 |  | 169d |  | 1403/6/26 | 1403/6/28 |
| 859 | 5.1.8.1 | Material Inspection | 1d | 2024-09-16 | 2024-09-16 | 223 | 169d | 0d | 1403/6/26 | 1403/6/26 |
| 860 | 5.1.8.2 | Visual and Dimensional Inspection | 1d | 2024-09-17 | 2024-09-17 | 859 | 169d | 0d | 1403/6/27 | 1403/6/27 |
| 861 | 5.1.8.3 | Hydro Test | 1d | 2024-09-18 | 2024-09-18 | 860 | 169d |  | 1403/6/28 | 1403/6/28 |
| 862 | 5.1.9 | **Piping Items (Pipe, Flange, Fitting, Gasket, Bolt & Nut)** | 6d | 2025-03-02 | 2025-03-08 |  | 23d |  | 1403/12/12 | 1403/12/18 |
| 863 | 5.1.9.1 | Material Inspection | 1d | 2025-03-02 | 2025-03-02 | 223, 229, 232, 235, 238 | 23d | 0d | 1403/12/12 | 1403/12/12 |
| 864 | 5.1.9.2 | Visual and Dimensional Inspection | 1d | 2025-03-03 | 2025-03-03 | 863 | 23d | 0d | 1403/12/13 | 1403/12/13 |
| 865 | 5.1.9.3 | Weld Preparation and Fit-Up | 1d | 2025-03-04 | 2025-03-04 | 864 | 23d | 0d | 1403/12/14 | 1403/12/14 |
| 866 | 5.1.9.4 | Welding | 1d | 2025-03-05 | 2025-03-05 | 865 | 23d | 0d | 1403/12/15 | 1403/12/15 |
| 867 | 5.1.9.5 | NDT( VT, MT, PT, UT, RT) | 1d | 2025-03-06 | 2025-03-06 | 866 | 23d | 0d | 1403/12/16 | 1403/12/16 |
| 868 | 5.1.9.6 | Hydrostatic Test | 1d | 2025-03-08 | 2025-03-08 | 867 | 23d |  | 1403/12/18 | 1403/12/18 |

| ID | WBS | Task | Duration | Start | Finish | Predecessors | Total slack | Free slack | شروع | پایان |
| --- | --- | --- | --- | --- | --- | --- | --- | --- | --- | --- |
| 869 | 5.1.10 | **Pump** | 2d | 2025-02-09 | 2025-02-10 |  | 45d |  | 1403/11/21 | 1403/11/22 |
| 870 | 5.1.10.1 | Final Visual and Dimensional Inspection | 1d | 2025-02-09 | 2025-02-09 | 244 | 45d | 0d | 1403/11/21 | 1403/11/21 |
| 871 | 5.1.10.2 | Performance test | 1d | 2025-02-10 | 2025-02-10 | 870 | 45d |  | 1403/11/22 | 1403/11/22 |
| 872 | 5.1.11 | **Chemical Injection Package** | 7d | 2023-12-16 | 2023-12-23 |  | 386d |  | 1402/9/25 | 1402/10/2 |
| 873 | 5.1.11.1 | Raw Material for Tank | 1d | 2023-12-16 | 2023-12-16 |  | 386d | 0d | 1402/9/25 | 1402/9/25 |
| 874 | 5.1.11.2 | Final Inspection For Fabricated Tank | 1d | 2023-12-17 | 2023-12-17 | 873 | 386d | 0d | 1402/9/26 | 1402/9/26 |
| 875 | 5.1.11.3 | Piping & Structure Works | 1d | 2023-12-18 | 2023-12-18 | 874 | 386d | 0d | 1402/9/27 | 1402/9/27 |
| 876 | 5.1.11.4 | Performance test | 1d | 2023-12-19 | 2023-12-19 | 875 | 386d | 0d | 1402/9/28 | 1402/9/28 |
| 877 | 5.1.11.5 | Packing Inspection | 1d | 2023-12-20 | 2023-12-20 | 876 | 386d | 0d | 1402/9/29 | 1402/9/29 |
| 878 | 5.1.11.6 | IRN | 1d | 2023-12-21 | 2023-12-21 | 877 | 386d | 0d | 1402/9/30 | 1402/9/30 |
| 879 | 5.1.11.7 | Final Book | 1d | 2023-12-23 | 2023-12-23 | 878 | 386d |  | 1402/10/2 | 1402/10/2 |
| 880 | 5.1.12 | **Reboiler Burner** | 2d | 2025-01-26 | 2025-01-27 |  | 57d |  | 1403/11/7 | 1403/11/8 |
| 881 | 5.1.12.1 | Final Visual and Dimensional Inspection | 1d | 2025-01-26 | 2025-01-26 | 262 | 57d | 0d | 1403/11/7 | 1403/11/7 |
| 882 | 5.1.12.2 | Burner Test | 1d | 2025-01-27 | 2025-01-27 | 881 | 57d |  | 1403/11/8 | 1403/11/8 |
| 883 | 5.2 | **Constraction inspection** | 385d | 2023-12-16 | 2025-04-12 |  | 2d |  | 1402/9/25 | 1404/1/23 |
| 884 | 5.2.1 | **Vessel** | 385d | 2023-12-16 | 2025-04-12 |  | 2d |  | 1402/9/25 | 1404/1/23 |
| 885 | 5.2.1.1 | **C-100 Glycol Contactor** | 385d | 2023-12-16 | 2025-04-12 |  | 2d |  | 1402/9/25 | 1404/1/23 |
| 886 | 5.2.1.1.1 | Inspection for marking & cutting | 1d | 2024-11-16 | 2024-11-16 | 279FS-1d | 25d | 0d | 1403/8/26 | 1403/8/26 |
| 887 | 5.2.1.1.2 | Inspection for rolling & forming | 1d | 2024-12-22 | 2024-12-22 | 281FS-1d, 286FS-1d | 2d | 0d | 1403/10/2 | 1403/10/2 |
| 888 | 5.2.1.1.3 | Inspection for weld preparation and fit up (shell , nozzle , …) | 1d | 2025-01-13 | 2025-01-13 | 303FS-1d, 306FS-1d | 2d | 0d | 1403/10/24 | 1403/10/24 |
| 889 | 5.2.1.1.4 | Inspection for welding | 1d | 2025-01-07 | 2025-01-07 | 282FS-1d, 304FS-1d | 2d | 0d | 1403/10/18 | 1403/10/18 |
| 890 | 5.2.1.1.5 | Inspection for ferrite check for welding part | 1d | 2024-11-24 | 2024-11-24 | 282FS-1d | 26d | 24d | 1403/9/4 | 1403/9/4 |
| 891 | 5.2.1.1.6 | Inspection for NDT (VT, MT, PT, UT, RT) | 1d | 2025-03-09 | 2025-03-09 | 307FS-1d, 316FS-1d | 5d | 3d | 1403/12/19 | 1403/12/19 |
| 892 | 5.2.1.1.7 | Inspection for final visual and dimensional | 1d | 2025-02-25 | 2025-02-25 | 312FS-1d | 15d | 13d | 1403/12/7 | 1403/12/7 |
| 893 | 5.2.1.1.8 | Inspection for PWHT | 1d | 2025-03-04 | 2025-03-04 | 315FS-1d | 8d | 0d | 1403/12/14 | 1403/12/14 |
| 894 | 5.2.1.1.9 | Inspection for hardness check | 1d | 2025-03-05 | 2025-03-05 | 893 | 8d | 6d | 1403/12/15 | 1403/12/15 |
| 895 | 5.2.1.1.10 | Inspection for pneumatic test (pad test) | 1d | 2025-02-09 | 2025-02-09 | 309FS-1d | 29d | 27d | 1403/11/21 | 1403/11/21 |
| 896 | 5.2.1.1.11 | Inspection for hydrostatic test water quality | 1d | 2025-03-10 | 2025-03-10 | 317SS | 4d | 2d | 1403/12/20 | 1403/12/20 |
| 897 | 5.2.1.1.12 | Inspection for hydrostatic test | 1d | 2025-04-05 | 2025-04-05 | 318FS-1d | 2d | 0d | 1404/1/16 | 1404/1/16 |
| 898 | 5.2.1.1.13 | Inspection for draining & drying | 1d | 2025-04-06 | 2025-04-06 | 897 | 2d | 0d | 1404/1/17 | 1404/1/17 |
| 899 | 5.2.1.1.14 | Inspection for abrasive & paint material | 1d | 2023-12-16 | 2023-12-16 |  | 381d | 379d | 1402/9/25 | 1402/9/25 |
| 900 | 5.2.1.1.15 | Inspection for blasting & painting (each layer DFT) | 1d | 2025-04-12 | 2025-04-12 | 319FS-1d | 2d | 0d | 1404/1/23 | 1404/1/23 |

| ID | WBS | Task | Duration | Start | Finish | Predecessors | Total slack | Free slack | شروع | پایان |
| --- | --- | --- | --- | --- | --- | --- | --- | --- | --- | --- |
| 901 | 5.2.1.2 | **C-200 Still Column** | 363d | 2023-12-16 | 2025-02-27 |  | 24d |  | 1402/9/25 | 1403/12/9 |
| 902 | 5.2.1.2.1 | Inspection for marking & cutting | 1d | 2024-11-14 | 2024-11-14 | 322FS-1d | 64d | 0d | 1403/8/24 | 1403/8/24 |
| 903 | 5.2.1.2.2 | Inspection for rolling & forming | 1d | 2024-12-22 | 2024-12-22 | 324FS-1d, 329FS-1d | 37d | 0d | 1403/10/2 | 1403/10/2 |
| 904 | 5.2.1.2.3 | Inspection for weld preparation and fit up (shell , nozzle , …) | 1d | 2025-01-01 | 2025-01-01 | 346FS-1d, 349FS-1d | 37d | 0d | 1403/10/12 | 1403/10/12 |
| 905 | 5.2.1.2.4 | Inspection for welding | 1d | 2024-12-28 | 2024-12-28 | 325FS-1d, 347FS-1d | 62d | 25d | 1403/10/8 | 1403/10/8 |
| 906 | 5.2.1.2.5 | Inspection for NDT (VT, MT, PT, UT, RT) | 1d | 2025-02-02 | 2025-02-02 | 350FS-1d, 359FS-1d | 39d | 2d | 1403/11/14 | 1403/11/14 |
| 907 | 5.2.1.2.6 | Inspection for final visual and dimensional | 1d | 2025-01-28 | 2025-01-28 | 355FS-1d | 43d | 6d | 1403/11/9 | 1403/11/9 |
| 908 | 5.2.1.2.7 | Inspection for PWHT | 1d | 2025-01-30 | 2025-01-30 | 358FS-1d | 40d | 0d | 1403/11/11 | 1403/11/11 |
| 909 | 5.2.1.2.8 | Inspection for hardness check | 1d | 2025-02-01 | 2025-02-01 | 908 | 40d | 3d | 1403/11/13 | 1403/11/13 |
| 910 | 5.2.1.2.9 | Inspection for pneumatic test (pad test) | 1d | 2025-01-19 | 2025-01-19 | 352FS-1d | 51d | 14d | 1403/10/30 | 1403/10/30 |
| 911 | 5.2.1.2.10 | Inspection for hydrostatic test water quality | 1d | 2025-02-03 | 2025-02-03 | 360SS | 38d | 1d | 1403/11/15 | 1403/11/15 |
| 912 | 5.2.1.2.11 | Inspection for hydrostatic test | 1d | 2025-02-06 | 2025-02-06 | 361FS-1d | 37d | 0d | 1403/11/18 | 1403/11/18 |
| 913 | 5.2.1.2.12 | Inspection for draining & drying | 1d | 2025-02-08 | 2025-02-08 | 912 | 37d | 13d | 1403/11/20 | 1403/11/20 |
| 914 | 5.2.1.2.13 | Inspection for abrasive & paint material | 1d | 2023-12-16 | 2023-12-16 |  | 382d | 358d | 1402/9/25 | 1402/9/25 |
| 915 | 5.2.1.2.14 | Inspection for blasting & painting (each layer DFT) | 1d | 2025-02-27 | 2025-02-27 | 362FS-1d | 24d | 1d | 1403/12/9 | 1403/12/9 |
| 916 | 5.2.1.3 | **C-300 Stripping Column** | 363d | 2023-12-16 | 2025-02-27 |  | 24d |  | 1402/9/25 | 1403/12/9 |
| 917 | 5.2.1.3.1 | Inspection for marking & cutting | 1d | 2024-11-13 | 2024-11-13 | 365FS-1d | 67d | 0d | 1403/8/23 | 1403/8/23 |
| 918 | 5.2.1.3.2 | Inspection for rolling & forming | 1d | 2024-12-18 | 2024-12-18 | 367FS-1d, 372FS-1d | 50d | 0d | 1403/9/28 | 1403/9/28 |
| 919 | 5.2.1.3.3 | Inspection for weld preparation and fit up (shell , nozzle , …) | 1d | 2024-12-26 | 2024-12-26 | 389FS-1d, 392FS-1d | 64d | 14d | 1403/10/6 | 1403/10/6 |
| 920 | 5.2.1.3.4 | Inspection for welding | 1d | 2024-12-23 | 2024-12-23 | 368FS-1d, 390FS-1d | 67d | 17d | 1403/10/3 | 1403/10/3 |
| 921 | 5.2.1.3.5 | Inspection for NDT (VT, MT, PT, UT, RT) | 1d | 2025-01-19 | 2025-01-19 | 393FS-1d, 402FS-1d | 51d | 1d | 1403/10/30 | 1403/10/30 |
| 922 | 5.2.1.3.6 | Inspection for final visual and dimensional | 1d | 2025-01-14 | 2025-01-14 | 398FS-1d | 55d | 5d | 1403/10/25 | 1403/10/25 |
| 923 | 5.2.1.3.7 | Inspection for PWHT | 1d | 2025-01-16 | 2025-01-16 | 401FS-1d | 52d | 0d | 1403/10/27 | 1403/10/27 |
| 924 | 5.2.1.3.8 | Inspection for hardness check | 1d | 2025-01-18 | 2025-01-18 | 923 | 52d | 2d | 1403/10/29 | 1403/10/29 |
| 925 | 5.2.1.3.9 | Inspection for pneumatic test (pad test) | 1d | 2025-01-06 | 2025-01-06 | 395FS-1d | 62d | 12d | 1403/10/17 | 1403/10/17 |
| 926 | 5.2.1.3.10 | Inspection for hydrostatic test water quality | 1d | 2025-01-20 | 2025-01-20 | 403SS | 50d | 0d | 1403/11/1 | 1403/11/1 |
| 927 | 5.2.1.3.11 | Inspection for hydrostatic test | 1d | 2025-01-22 | 2025-01-22 | 404FS-1d | 50d | 0d | 1403/11/3 | 1403/11/3 |
| 928 | 5.2.1.3.12 | Inspection for draining & drying | 1d | 2025-01-23 | 2025-01-23 | 927 | 50d | 26d | 1403/11/4 | 1403/11/4 |
| 929 | 5.2.1.3.13 | Inspection for abrasive & paint material | 1d | 2023-12-16 | 2023-12-16 |  | 382d | 358d | 1402/9/25 | 1402/9/25 |
| 930 | 5.2.1.3.14 | Inspection for blasting & painting (each layer DFT) | 1d | 2025-02-27 | 2025-02-27 | 405FS-1d | 24d | 1d | 1403/12/9 | 1403/12/9 |

| ID | WBS | Task | Duration | Start | Finish | Predecessors | Total slack | Free slack | شروع | پایان |
| --- | --- | --- | --- | --- | --- | --- | --- | --- | --- | --- |
| 931 | 5.2.1.4 | **V-120 Glycol Flash Drum** | 363d | 2023-12-16 | 2025-02-27 |  | 24d |  | 1402/9/25 | 1403/12/9 |
| 932 | 5.2.1.4.1 | Inspection for marking & cutting | 1d | 2024-11-14 | 2024-11-14 | 408FS-1d | 52d | 0d | 1403/8/24 | 1403/8/24 |
| 933 | 5.2.1.4.2 | Inspection for rolling & forming | 1d | 2024-12-21 | 2024-12-21 | 410FS-1d, 415FS-1d | 32d | 0d | 1403/10/1 | 1403/10/1 |
| 934 | 5.2.1.4.3 | Inspection for weld preparation and fit up (shell , nozzle , …) | 1d | 2025-01-05 | 2025-01-05 | 432FS-1d, 435FS-1d | 55d | 23d | 1403/10/16 | 1403/10/16 |
| 935 | 5.2.1.4.4 | Inspection for welding | 1d | 2024-12-31 | 2024-12-31 | 411FS-1d, 433FS-1d | 59d | 27d | 1403/10/11 | 1403/10/11 |
| 936 | 5.2.1.4.5 | Inspection for NDT (VT, MT, PT, UT, RT) | 1d | 2025-02-09 | 2025-02-09 | 436FS-1d, 445FS-1d | 33d | 1d | 1403/11/21 | 1403/11/21 |
| 937 | 5.2.1.4.6 | Inspection for final visual and dimensional | 1d | 2025-02-03 | 2025-02-03 | 441FS-1d | 38d | 6d | 1403/11/15 | 1403/11/15 |
| 938 | 5.2.1.4.7 | Inspection for PWHT | 1d | 2025-02-06 | 2025-02-06 | 444FS-1d | 34d | 0d | 1403/11/18 | 1403/11/18 |
| 939 | 5.2.1.4.8 | Inspection for hardness check | 1d | 2025-02-08 | 2025-02-08 | 938 | 34d | 2d | 1403/11/20 | 1403/11/20 |
| 940 | 5.2.1.4.9 | Inspection for pneumatic test (pad test) | 1d | 2025-01-22 | 2025-01-22 | 438FS-1d | 48d | 16d | 1403/11/3 | 1403/11/3 |
| 941 | 5.2.1.4.10 | Inspection for hydrostatic test water quality | 1d | 2025-02-10 | 2025-02-10 | 446SS | 32d | 0d | 1403/11/22 | 1403/11/22 |
| 942 | 5.2.1.4.11 | Inspection for hydrostatic test | 1d | 2025-02-12 | 2025-02-12 | 447FS-1d | 32d | 0d | 1403/11/24 | 1403/11/24 |
| 943 | 5.2.1.4.12 | Inspection for draining & drying | 1d | 2025-02-13 | 2025-02-13 | 942 | 32d | 8d | 1403/11/25 | 1403/11/25 |
| 944 | 5.2.1.4.13 | Inspection for abrasive & paint material | 1d | 2023-12-16 | 2023-12-16 |  | 382d | 358d | 1402/9/25 | 1402/9/25 |
| 945 | 5.2.1.4.14 | Inspection for blasting & painting (each layer DFT) | 1d | 2025-02-27 | 2025-02-27 | 448FS-1d | 24d | 1d | 1403/12/9 | 1403/12/9 |
| 946 | 5.2.1.5 | **F-100A Particle Glycol Filter** | 364d | 2023-12-16 | 2025-03-01 |  | 23d |  | 1402/9/25 | 1403/12/11 |
| 947 | 5.2.1.5.1 | Inspection for marking & cutting | 1d | 2024-11-17 | 2024-11-17 | 451FS-1d | 61d | 0d | 1403/8/27 | 1403/8/27 |
| 948 | 5.2.1.5.2 | Inspection for rolling & forming | 1d | 2024-11-19 | 2024-11-19 | 453FS-1d | 64d | 28d | 1403/8/29 | 1403/8/29 |
| 949 | 5.2.1.5.3 | Inspection for weld preparation and fit up (shell , nozzle , …) | 1d | 2025-01-05 | 2025-01-05 | 475FS-1d, 478FS-1d | 49d | 13d | 1403/10/16 | 1403/10/16 |
| 950 | 5.2.1.5.4 | Inspection for welding | 1d | 2024-12-29 | 2024-12-29 | 454FS-1d, 476FS-1d | 55d | 19d | 1403/10/9 | 1403/10/9 |
| 951 | 5.2.1.5.5 | Inspection for NDT (VT, MT, PT, UT, RT) | 1d | 2025-02-01 | 2025-02-01 | 479FS-1d, 488FS-1d | 37d | 1d | 1403/11/13 | 1403/11/13 |
| 952 | 5.2.1.5.6 | Inspection for final visual and dimensional | 1d | 2025-01-25 | 2025-01-25 | 484FS-1d | 43d | 7d | 1403/11/6 | 1403/11/6 |
| 953 | 5.2.1.5.7 | Inspection for PWHT | 1d | 2025-01-29 | 2025-01-29 | 487FS-1d | 38d | 0d | 1403/11/10 | 1403/11/10 |
| 954 | 5.2.1.5.8 | Inspection for hardness check | 1d | 2025-01-30 | 2025-01-30 | 953 | 38d | 2d | 1403/11/11 | 1403/11/11 |
| 955 | 5.2.1.5.9 | Inspection for pneumatic test (pad test) | 1d | 2025-01-14 | 2025-01-14 | 481FS-1d | 52d | 16d | 1403/10/25 | 1403/10/25 |
| 956 | 5.2.1.5.10 | Inspection for hydrostatic test water quality | 1d | 2025-02-02 | 2025-02-02 | 489SS | 36d | 0d | 1403/11/14 | 1403/11/14 |
| 957 | 5.2.1.5.11 | Inspection for hydrostatic test | 1d | 2025-02-06 | 2025-02-06 | 490FS-1d | 36d | 0d | 1403/11/18 | 1403/11/18 |
| 958 | 5.2.1.5.12 | Inspection for draining & drying | 1d | 2025-02-08 | 2025-02-08 | 957 | 36d | 13d | 1403/11/20 | 1403/11/20 |
| 959 | 5.2.1.5.13 | Inspection for abrasive & paint material | 1d | 2023-12-16 | 2023-12-16 |  | 381d | 358d | 1402/9/25 | 1402/9/25 |
| 960 | 5.2.1.5.14 | Inspection for blasting & painting (each layer DFT) | 1d | 2025-03-01 | 2025-03-01 | 491FS-1d | 23d | 0d | 1403/12/11 | 1403/12/11 |

| ID | WBS | Task | Duration | Start | Finish | Predecessors | Total slack | Free slack | شروع | پایان |
| --- | --- | --- | --- | --- | --- | --- | --- | --- | --- | --- |
| 961 | 5.2.1.6 | **F-100B Particle Glycol Filter** | 361d | 2023-12-16 | 2025-02-25 |  | 26d |  | 1402/9/25 | 1403/12/7 |
| 962 | 5.2.1.6.1 | Inspection for marking & cutting | 1d | 2024-11-13 | 2024-11-13 | 494FS-1d | 88d | 0d | 1403/8/23 | 1403/8/23 |
| 963 | 5.2.1.6.2 | Inspection for rolling & forming | 1d | 2024-12-18 | 2024-12-18 | 496FS-1d, 501FS-1d | 63d | 0d | 1403/9/28 | 1403/9/28 |
| 964 | 5.2.1.6.3 | Inspection for weld preparation and fit up (shell , nozzle , …) | 1d | 2024-12-24 | 2024-12-24 | 518FS-1d, 521FS-1d | 69d | 7d | 1403/10/4 | 1403/10/4 |
| 965 | 5.2.1.6.4 | Inspection for welding | 1d | 2024-12-21 | 2024-12-21 | 497FS-1d, 519FS-1d | 72d | 10d | 1403/10/1 | 1403/10/1 |
| 966 | 5.2.1.6.5 | Inspection for NDT (VT, MT, PT, UT, RT) | 1d | 2025-01-07 | 2025-01-07 | 522FS-1d, 531FS-1d | 63d | 1d | 1403/10/18 | 1403/10/18 |
| 967 | 5.2.1.6.6 | Inspection for final visual and dimensional | 1d | 2025-01-04 | 2025-01-04 | 527FS-1d | 66d | 4d | 1403/10/15 | 1403/10/15 |
| 968 | 5.2.1.6.7 | Inspection for PWHT | 1d | 2025-01-06 | 2025-01-06 | 530FS-1d | 63d | 0d | 1403/10/17 | 1403/10/17 |
| 969 | 5.2.1.6.8 | Inspection for hardness check | 1d | 2025-01-07 | 2025-01-07 | 968 | 63d | 1d | 1403/10/18 | 1403/10/18 |
| 970 | 5.2.1.6.9 | Inspection for pneumatic test (pad test) | 1d | 2024-12-30 | 2024-12-30 | 524FS-1d | 70d | 8d | 1403/10/10 | 1403/10/10 |
| 971 | 5.2.1.6.10 | Inspection for hydrostatic test water quality | 1d | 2025-01-08 | 2025-01-08 | 532SS | 62d | 0d | 1403/10/19 | 1403/10/19 |
| 972 | 5.2.1.6.11 | Inspection for hydrostatic test | 1d | 2025-01-11 | 2025-01-11 | 533FS-1d | 62d | 0d | 1403/10/22 | 1403/10/22 |
| 973 | 5.2.1.6.12 | Inspection for draining & drying | 1d | 2025-01-12 | 2025-01-12 | 972 | 62d | 36d | 1403/10/23 | 1403/10/23 |
| 974 | 5.2.1.6.13 | Inspection for abrasive & paint material | 1d | 2023-12-16 | 2023-12-16 |  | 384d | 358d | 1402/9/25 | 1402/9/25 |
| 975 | 5.2.1.6.14 | Inspection for blasting & painting (each layer DFT) | 1d | 2025-02-25 | 2025-02-25 | 534FS-1d | 26d | 3d | 1403/12/7 | 1403/12/7 |
| 976 | 5.2.1.7 | **F-200 Carbon Glycol Filter** | 363d | 2023-12-16 | 2025-02-27 |  | 24d |  | 1402/9/25 | 1403/12/9 |
| 977 | 5.2.1.7.1 | Inspection for marking & cutting | 1d | 2024-11-17 | 2024-11-17 | 537FS-1d | 80d | 0d | 1403/8/27 | 1403/8/27 |
| 978 | 5.2.1.7.2 | Inspection for rolling & forming | 1d | 2024-12-22 | 2024-12-22 | 539FS-1d, 544FS-1d | 55d | 0d | 1403/10/2 | 1403/10/2 |
| 979 | 5.2.1.7.3 | Inspection for weld preparation and fit up (shell , nozzle , …) | 1d | 2024-12-28 | 2024-12-28 | 564FS-1d, 561FS-1d | 61d | 7d | 1403/10/8 | 1403/10/8 |
| 980 | 5.2.1.7.4 | Inspection for welding | 1d | 2024-12-24 | 2024-12-24 | 540FS-1d, 562FS-1d | 64d | 10d | 1403/10/4 | 1403/10/4 |
| 981 | 5.2.1.7.5 | Inspection for NDT (VT, MT, PT, UT, RT) | 1d | 2025-01-12 | 2025-01-12 | 565FS-1d, 574FS-1d | 56d | 2d | 1403/10/23 | 1403/10/23 |
| 982 | 5.2.1.7.6 | Inspection for final visual and dimensional | 1d | 2025-01-07 | 2025-01-07 | 570FS-1d | 60d | 6d | 1403/10/18 | 1403/10/18 |
| 983 | 5.2.1.7.7 | Inspection for PWHT | 1d | 2025-01-11 | 2025-01-11 | 573FS-1d | 56d | 0d | 1403/10/22 | 1403/10/22 |
| 984 | 5.2.1.7.8 | Inspection for hardness check | 1d | 2025-01-12 | 2025-01-12 | 983 | 56d | 2d | 1403/10/23 | 1403/10/23 |
| 985 | 5.2.1.7.9 | Inspection for pneumatic test (pad test) | 1d | 2025-01-02 | 2025-01-02 | 567FS-1d | 64d | 10d | 1403/10/13 | 1403/10/13 |
| 986 | 5.2.1.7.10 | Inspection for hydrostatic test water quality | 1d | 2025-01-13 | 2025-01-13 | 575SS | 55d | 1d | 1403/10/24 | 1403/10/24 |
| 987 | 5.2.1.7.11 | Inspection for hydrostatic test | 1d | 2025-01-18 | 2025-01-18 | 576FS-1d | 54d | 0d | 1403/10/29 | 1403/10/29 |
| 988 | 5.2.1.7.12 | Inspection for draining & drying | 1d | 2025-01-19 | 2025-01-19 | 987 | 54d | 30d | 1403/10/30 | 1403/10/30 |
| 989 | 5.2.1.7.13 | Inspection for abrasive & paint material | 1d | 2023-12-16 | 2023-12-16 |  | 382d | 358d | 1402/9/25 | 1402/9/25 |
| 990 | 5.2.1.7.14 | Inspection for blasting & painting (each layer DFT) | 1d | 2025-02-27 | 2025-02-27 | 577FS-1d | 24d | 1d | 1403/12/9 | 1403/12/9 |

| ID | WBS | Task | Duration | Start | Finish | Predecessors | Total slack | Free slack | شروع | پایان |
| --- | --- | --- | --- | --- | --- | --- | --- | --- | --- | --- |
| 991 | 5.2.1.8 | **E-100 Glycol reflux condenser COIL TYPE** | 363d | 2023-12-16 | 2025-02-27 |  | 24d |  | 1402/9/25 | 1403/12/9 |
| 992 | 5.2.1.8.1 | Inspection for marking & cutting | 1d | 2024-11-25 | 2024-11-25 | 580FS-1d | 50d | 0d | 1403/9/5 | 1403/9/5 |
| 993 | 5.2.1.8.2 | Inspection for rolling & forming | 1d | 2024-11-27 | 2024-11-27 | 582FS-1d | 52d | 2d | 1403/9/7 | 1403/9/7 |
| 994 | 5.2.1.8.3 | Inspection for weld preparation and fit up (shell , nozzle , …) | 1d | 2024-12-25 | 2024-12-25 | 600FS-1d, 603FS-1d | 38d | 0d | 1403/10/5 | 1403/10/5 |
| 995 | 5.2.1.8.4 | Inspection for welding | 1d | 2024-12-04 | 2024-12-04 | 581FS-1d, 601FS-1d, 598FS-1d | 80d | 42d | 1403/9/14 | 1403/9/14 |
| 996 | 5.2.1.8.5 | Inspection for NDT (VT, MT, PT, UT, RT) | 1d | 2025-01-29 | 2025-01-29 | 604FS-1d, 613FS-1d | 40d | 2d | 1403/11/10 | 1403/11/10 |
| 997 | 5.2.1.8.6 | Inspection for final visual and dimensional | 1d | 2025-01-25 | 2025-01-25 | 609FS-1d | 44d | 6d | 1403/11/6 | 1403/11/6 |
| 998 | 5.2.1.8.7 | Inspection for PWHT | 1d | 2025-01-28 | 2025-01-28 | 612FS-1d | 40d | 0d | 1403/11/9 | 1403/11/9 |
| 999 | 5.2.1.8.8 | Inspection for hardness check | 1d | 2025-01-29 | 2025-01-29 | 998 | 40d | 2d | 1403/11/10 | 1403/11/10 |
| 1000 | 5.2.1.8.9 | Inspection for pneumatic test (pad test) | 1d | 2024-12-31 | 2024-12-31 | 606FS-1d | 65d | 27d | 1403/10/11 | 1403/10/11 |
| 1001 | 5.2.1.8.10 | Inspection for hydrostatic test water quality | 1d | 2025-01-30 | 2025-01-30 | 614SS | 39d | 1d | 1403/11/11 | 1403/11/11 |
| 1002 | 5.2.1.8.11 | Inspection for hydrostatic test | 1d | 2025-02-05 | 2025-02-05 | 615FS-1d, 616FS-1d | 38d | 0d | 1403/11/17 | 1403/11/17 |
| 1003 | 5.2.1.8.12 | Inspection for draining & drying | 1d | 2025-02-06 | 2025-02-06 | 1002 | 38d | 14d | 1403/11/18 | 1403/11/18 |
| 1004 | 5.2.1.8.13 | Inspection for abrasive & paint material | 1d | 2023-12-16 | 2023-12-16 |  | 382d | 358d | 1402/9/25 | 1402/9/25 |
| 1005 | 5.2.1.8.14 | Inspection for blasting & painting (each layer DFT) | 1d | 2025-02-27 | 2025-02-27 | 617FS-1d | 24d | 1d | 1403/12/9 | 1403/12/9 |
| 1006 | 5.2.1.9 | **V-130 Surge Tank** | 364d | 2023-12-16 | 2025-03-01 |  | 23d |  | 1402/9/25 | 1403/12/11 |
| 1007 | 5.2.1.9.1 | Inspection for marking & cutting | 1d | 2024-11-14 | 2024-11-14 | 620FS-1d | 49d | 0d | 1403/8/24 | 1403/8/24 |
| 1008 | 5.2.1.9.2 | Inspection for rolling & forming | 1d | 2024-12-24 | 2024-12-24 | 622FS-1d, 627FS-1d | 29d | 0d | 1403/10/4 | 1403/10/4 |
| 1009 | 5.2.1.9.3 | Inspection for weld preparation and fit up (shell , nozzle , …) | 1d | 2025-01-02 | 2025-01-02 | 644FS-1d, 647FS-1d | 29d | 0d | 1403/10/13 | 1403/10/13 |
| 1010 | 5.2.1.9.4 | Inspection for welding | 1d | 2024-12-29 | 2024-12-29 | 623FS-1d, 645FS-1d | 60d | 31d | 1403/10/9 | 1403/10/9 |
| 1011 | 5.2.1.9.5 | Inspection for NDT (VT, MT, PT, UT, RT) | 1d | 2025-02-11 | 2025-02-11 | 648FS-1d, 657FS-1d | 30d | 1d | 1403/11/23 | 1403/11/23 |
| 1012 | 5.2.1.9.6 | Inspection for final visual and dimensional | 1d | 2025-02-05 | 2025-02-05 | 653FS-1d | 35d | 6d | 1403/11/17 | 1403/11/17 |
| 1013 | 5.2.1.9.7 | Inspection for PWHT | 1d | 2025-02-09 | 2025-02-09 | 656FS-1d | 31d | 0d | 1403/11/21 | 1403/11/21 |
| 1014 | 5.2.1.9.8 | Inspection for hardness check | 1d | 2025-02-10 | 2025-02-10 | 1013 | 31d | 2d | 1403/11/22 | 1403/11/22 |
| 1015 | 5.2.1.9.9 | Inspection for pneumatic test (pad test) | 1d | 2025-01-28 | 2025-01-28 | 650FS-1d | 42d | 13d | 1403/11/9 | 1403/11/9 |
| 1016 | 5.2.1.9.10 | Inspection for hydrostatic test water quality | 1d | 2025-02-12 | 2025-02-12 | 658SS | 29d | 0d | 1403/11/24 | 1403/11/24 |
| 1017 | 5.2.1.9.11 | Inspection for hydrostatic test | 1d | 2025-02-15 | 2025-02-15 | 659FS-1d | 29d | 0d | 1403/11/27 | 1403/11/27 |
| 1018 | 5.2.1.9.12 | Inspection for draining & drying | 1d | 2025-02-16 | 2025-02-16 | 1017 | 29d | 6d | 1403/11/28 | 1403/11/28 |
| 1019 | 5.2.1.9.13 | Inspection for abrasive & paint material | 1d | 2023-12-16 | 2023-12-16 |  | 381d | 358d | 1402/9/25 | 1402/9/25 |
| 1020 | 5.2.1.9.14 | Inspection for blasting & painting (each layer DFT) | 1d | 2025-03-01 | 2025-03-01 | 660FS-1d | 23d | 0d | 1403/12/11 | 1403/12/11 |

| ID | WBS | Task | Duration | Start | Finish | Predecessors | Total slack | Free slack | شروع | پایان |
| --- | --- | --- | --- | --- | --- | --- | --- | --- | --- | --- |
| 1021 | 5.2.2 | **Heat Exchanger** | 363d | 2023-12-16 | 2025-02-27 |  | 24d |  | 1402/9/25 | 1403/12/9 |
| 1022 | 5.2.2.1 | **E -200 Rich-Lean HE** | 363d | 2023-12-16 | 2025-02-27 |  | 24d |  | 1402/9/25 | 1403/12/9 |
| 1023 | 5.2.2.1.1 | Inspection for marking & cutting | 1d | 2024-11-23 | 2024-11-23 | 664FS-1d | 49d | 0d | 1403/9/3 | 1403/9/3 |
| 1024 | 5.2.2.1.2 | Inspection for rolling & forming | 1d | 2024-11-25 | 2024-11-25 | 666FS-1d | 51d | 2d | 1403/9/5 | 1403/9/5 |
| 1025 | 5.2.2.1.3 | Inspection for tube to tube sheet joint (expansion) | 1d | 2024-12-25 | 2024-12-25 | 688FS-1d | 62d | 30d | 1403/10/5 | 1403/10/5 |
| 1026 | 5.2.2.1.4 | Inspection for weld preparation and fit up (shell , nozzle , …) | 1d | 2024-12-22 | 2024-12-22 | 683FS-1d, 686FS-1d | 32d | 0d | 1403/10/2 | 1403/10/2 |
| 1027 | 5.2.2.1.5 | Inspection for welding | 1d | 2024-11-30 | 2024-11-30 | 684FS-1d, 667FS-1d | 84d | 52d | 1403/9/10 | 1403/9/10 |
| 1028 | 5.2.2.1.6 | Inspection for NDT (VT, MT, PT, UT, RT) | 1d | 2025-02-05 | 2025-02-05 | 687FS-1d, 696FS-1d | 34d | 2d | 1403/11/17 | 1403/11/17 |
| 1029 | 5.2.2.1.7 | Inspection for final visual and dimensional | 1d | 2025-02-01 | 2025-02-01 | 692FS-1d | 38d | 6d | 1403/11/13 | 1403/11/13 |
| 1030 | 5.2.2.1.8 | Inspection for PWHT | 1d | 2025-02-04 | 2025-02-04 | 695FS-1d | 34d | 0d | 1403/11/16 | 1403/11/16 |
| 1031 | 5.2.2.1.9 | Inspection for hardness check | 1d | 2025-02-05 | 2025-02-05 | 1030 | 34d | 2d | 1403/11/17 | 1403/11/17 |
| 1032 | 5.2.2.1.10 | Inspection for pneumatic test (pad test) | 1d | 2024-12-28 | 2024-12-28 | 689FS-1d | 68d | 36d | 1403/10/8 | 1403/10/8 |
| 1033 | 5.2.2.1.11 | Inspection for hydrostatic test water quality | 1d | 2025-02-06 | 2025-02-06 | 697SS | 33d | 1d | 1403/11/18 | 1403/11/18 |
| 1034 | 5.2.2.1.12 | Inspection for hydrostatic test | 1d | 2025-02-12 | 2025-02-12 | 699FS-1d | 32d | 0d | 1403/11/24 | 1403/11/24 |
| 1035 | 5.2.2.1.13 | Inspection for draining & drying | 1d | 2025-02-13 | 2025-02-13 | 1034 | 32d | 8d | 1403/11/25 | 1403/11/25 |
| 1036 | 5.2.2.1.14 | Inspection for abrasive & paint material | 1d | 2023-12-16 | 2023-12-16 |  | 382d | 358d | 1402/9/25 | 1402/9/25 |
| 1037 | 5.2.2.1.15 | Inspection for blasting & painting (each layer DFT) | 1d | 2025-02-27 | 2025-02-27 | 700FS-1d | 24d | 1d | 1403/12/9 | 1403/12/9 |
| 1038 | 5.2.2.2 | **E -300 LEAN TEG - DRY GAS EXCH** | 363d | 2023-12-16 | 2025-02-27 |  | 24d |  | 1402/9/25 | 1403/12/9 |
| 1039 | 5.2.2.2.1 | Inspection for marking & cutting | 1d | 2024-11-13 | 2024-11-13 | 703FS-1d | 54d | 0d | 1403/8/23 | 1403/8/23 |
| 1040 | 5.2.2.2.2 | Inspection for rolling & forming | 1d | 2024-11-16 | 2024-11-16 | 705FS-1d | 56d | 2d | 1403/8/26 | 1403/8/26 |
| 1041 | 5.2.2.2.3 | Inspection for tube to tube sheet joint (expansion) | 1d | 2025-02-02 | 2025-02-02 | 734FS-1d | 29d | 0d | 1403/11/14 | 1403/11/14 |
| 1042 | 5.2.2.2.4 | Inspection for weld preparation and fit up (shell , nozzle , …) | 1d | 2024-12-22 | 2024-12-22 | 724FS-1d, 727FS-1d | 29d | 0d | 1403/10/2 | 1403/10/2 |
| 1043 | 5.2.2.2.5 | Inspection for welding | 1d | 2024-11-20 | 2024-11-20 | 725FS-1d, 706FS-1d | 92d | 63d | 1403/8/30 | 1403/8/30 |
| 1044 | 5.2.2.2.6 | Inspection for NDT (VT, MT, PT, UT, RT) | 1d | 2025-02-09 | 2025-02-09 | 728FS-1d, 739FS-1d | 31d | 2d | 1403/11/21 | 1403/11/21 |
| 1045 | 5.2.2.2.7 | Inspection for final visual and dimensional | 1d | 2025-02-04 | 2025-02-04 | 735FS-1d | 35d | 6d | 1403/11/16 | 1403/11/16 |
| 1046 | 5.2.2.2.8 | Inspection for PWHT | 1d | 2025-02-08 | 2025-02-08 | 738FS-1d | 31d | 0d | 1403/11/20 | 1403/11/20 |
| 1047 | 5.2.2.2.9 | Inspection for hardness check | 1d | 2025-02-09 | 2025-02-09 | 1046 | 31d | 2d | 1403/11/21 | 1403/11/21 |
| 1048 | 5.2.2.2.10 | Inspection for pneumatic test (pad test) | 1d | 2024-12-28 | 2024-12-28 | 730FS-1d | 68d | 39d | 1403/10/8 | 1403/10/8 |
| 1049 | 5.2.2.2.11 | Inspection for hydrostatic test water quality | 1d | 2025-02-10 | 2025-02-10 | 740SS | 30d | 1d | 1403/11/22 | 1403/11/22 |
| 1050 | 5.2.2.2.12 | Inspection for hydrostatic test | 1d | 2025-02-16 | 2025-02-16 | 741FS-1d, 742FS-1d | 29d | 0d | 1403/11/28 | 1403/11/28 |
| 1051 | 5.2.2.2.13 | Inspection for draining & drying | 1d | 2025-02-17 | 2025-02-17 | 1050 | 29d | 5d | 1403/11/29 | 1403/11/29 |
| 1052 | 5.2.2.2.14 | Inspection for abrasive & paint material | 1d | 2023-12-16 | 2023-12-16 |  | 382d | 358d | 1402/9/25 | 1402/9/25 |
| 1053 | 5.2.2.2.15 | Inspection for blasting & painting (each layer DFT) | 1d | 2025-02-27 | 2025-02-27 | 743FS-1d | 24d | 1d | 1403/12/9 | 1403/12/9 |

| ID | WBS | Task | Duration | Start | Finish | Predecessors | Total slack | Free slack | شروع | پایان |
| --- | --- | --- | --- | --- | --- | --- | --- | --- | --- | --- |
| 1054 | 5.2.3 | **Reboiler** | 363d | 2023-12-16 | 2025-02-27 |  | 24d |  | 1402/9/25 | 1403/12/9 |
| 1055 | 5.2.3.1 | Inspection for marking & cutting | 1d | 2024-11-13 | 2024-11-13 | 746FS-1d | 62d | 0d | 1403/8/23 | 1403/8/23 |
| 1056 | 5.2.3.2 | Inspection for rolling & forming | 1d | 2024-12-19 | 2024-12-19 | 748FS-1d, 753FS-1d | 37d | 0d | 1403/9/29 | 1403/9/29 |
| 1057 | 5.2.3.3 | Inspection for weld preparation and fit up (shell , nozzle , …) | 1d | 2025-01-06 | 2025-01-06 | 770FS-1d, 773FS-1d | 37d | 0d | 1403/10/17 | 1403/10/17 |
| 1058 | 5.2.3.4 | Inspection for welding | 1d | 2025-01-01 | 2025-01-01 | 749FS-1d, 771FS-1d | 59d | 22d | 1403/10/12 | 1403/10/12 |
| 1059 | 5.2.3.5 | Inspection for NDT (VT, MT, PT, UT, RT) | 1d | 2025-02-03 | 2025-02-03 | 774FS-1d, 783FS-1d | 38d | 1d | 1403/11/15 | 1403/11/15 |
| 1060 | 5.2.3.6 | Inspection for final visual and dimensional | 1d | 2025-01-29 | 2025-01-29 | 779FS-1d | 42d | 5d | 1403/11/10 | 1403/11/10 |
| 1061 | 5.2.3.7 | Inspection for PWHT | 1d | 2025-02-02 | 2025-02-02 | 782FS-1d | 38d | 0d | 1403/11/14 | 1403/11/14 |
| 1062 | 5.2.3.8 | Inspection for hardness check | 1d | 2025-02-03 | 2025-02-03 | 1061 | 38d | 1d | 1403/11/15 | 1403/11/15 |
| 1063 | 5.2.3.9 | Inspection for pneumatic test (pad test) | 1d | 2025-01-20 | 2025-01-20 | 776FS-1d | 50d | 13d | 1403/11/1 | 1403/11/1 |
| 1064 | 5.2.3.10 | Inspection for hydrostatic test water quality | 1d | 2025-02-04 | 2025-02-04 | 784SS | 37d | 0d | 1403/11/16 | 1403/11/16 |
| 1065 | 5.2.3.11 | Inspection for hydrostatic test | 1d | 2025-02-06 | 2025-02-06 | 785FS-1d | 37d | 0d | 1403/11/18 | 1403/11/18 |
| 1066 | 5.2.3.12 | Inspection for draining & drying | 1d | 2025-02-08 | 2025-02-08 | 1065 | 37d | 13d | 1403/11/20 | 1403/11/20 |
| 1067 | 5.2.3.13 | Inspection for abrasive & paint material | 1d | 2023-12-16 | 2023-12-16 |  | 382d | 358d | 1402/9/25 | 1402/9/25 |
| 1068 | 5.2.3.14 | Inspection for blasting & painting (each layer DFT) | 1d | 2025-02-27 | 2025-02-27 | 786FS-1d | 24d | 1d | 1403/12/9 | 1403/12/9 |
| 1069 | 5.2.4 | **L&P** | 1d | 2025-04-10 | 2025-04-10 |  | 0d |  | 1404/1/21 | 1404/1/21 |
| 1070 | 5.2.4.1 | Inspection for visual and dimensional check after welding | 1d | 2025-04-10 | 2025-04-10 | 794FS-1d | 0d |  | 1404/1/21 | 1404/1/21 |
| 1071 | 5.2.5 | **Painting Of Package Assembly (Piping, Structure)** | 373d | 2023-12-16 | 2025-03-11 |  | 14d |  | 1402/9/25 | 1403/12/21 |
| 1072 | 5.2.5.1 | Inspection for abrasive & paint material | 1d | 2023-12-16 | 2023-12-16 |  | 377d | 363d | 1402/9/25 | 1402/9/25 |
| 1073 | 5.2.5.2 | Inspection for blasting & painting (each layer DFT) | 1d | 2025-03-11 | 2025-03-11 | 810FS-1d | 14d |  | 1403/12/21 | 1403/12/21 |
| 1074 | 5.2.6 | **Pickling (For Stailess Steel Part)** | 1d | 2025-01-28 | 2025-01-28 |  | 43d |  | 1403/11/9 | 1403/11/9 |
| 1075 | 5.2.6.1 | Inspection for pickling and passivation | 1d | 2025-01-28 | 2025-01-28 | 355FS-1d | 43d | 6d | 1403/11/9 | 1403/11/9 |
| 1076 | 6 | **Final Inspection & Releas note** | 25d | 2025-03-02 | 2025-04-16 |  | 0d |  | 1403/12/12 | 1404/1/27 |
| 1077 | 6.1 | **C-100 Glycol Contactor** | 2d | 2025-04-13 | 2025-04-14 |  | 2d |  | 1404/1/24 | 1404/1/25 |
| 1078 | 6.1.1 | Final Inspection & Releas note | 2d | 2025-04-13 | 2025-04-14 | 319, 900, 217, 232, 238 | 2d | 0d | 1404/1/24 | 1404/1/25 |

| ID | WBS | Task | Duration | Start | Finish | Predecessors | Total slack | Free slack | شروع | پایان |
| --- | --- | --- | --- | --- | --- | --- | --- | --- | --- | --- |
| 1079 | 6.2 | **C-200 Still Column** | 2d | 2025-03-02 | 2025-03-03 |  | 23d |  | 1403/12/12 | 1403/12/13 |
| 1080 | 6.2.1 | Final Inspection & Releas note | 2d | 2025-03-02 | 2025-03-03 | 362, 915, 217, 232, 238 | 23d | 0d | 1403/12/12 | 1403/12/13 |
| 1081 | 6.3 | **C-300 Stripping Column** | 2d | 2025-03-02 | 2025-03-03 |  | 23d |  | 1403/12/12 | 1403/12/13 |
| 1082 | 6.3.1 | Final Inspection & Releas note | 2d | 2025-03-02 | 2025-03-03 | 405, 930, 217, 232, 238 | 23d | 0d | 1403/12/12 | 1403/12/13 |
| 1083 | 6.4 | **V-120 Glycol Flash Drum** | 2d | 2025-03-02 | 2025-03-03 |  | 23d |  | 1403/12/12 | 1403/12/13 |
| 1084 | 6.4.1 | Final Inspection & Releas note | 2d | 2025-03-02 | 2025-03-03 | 448, 945, 217, 232, 238 | 23d | 0d | 1403/12/12 | 1403/12/13 |
| 1085 | 6.5 | **F-100A Particle Glycol Filter** | 2d | 2025-03-02 | 2025-03-03 |  | 23d |  | 1403/12/12 | 1403/12/13 |
| 1086 | 6.5.1 | Final Inspection & Releas note | 2d | 2025-03-02 | 2025-03-03 | 491, 960, 217, 232, 238 | 23d | 0d | 1403/12/12 | 1403/12/13 |
| 1087 | 6.6 | **F-100B Particle Glycol Filter** | 2d | 2025-03-02 | 2025-03-03 |  | 23d |  | 1403/12/12 | 1403/12/13 |
| 1088 | 6.6.1 | Final Inspection & Releas note | 2d | 2025-03-02 | 2025-03-03 | 534, 975, 217, 232, 238 | 23d | 0d | 1403/12/12 | 1403/12/13 |
| 1089 | 6.7 | **F-200 Carbon Glycol Filter** | 2d | 2025-03-02 | 2025-03-03 |  | 23d |  | 1403/12/12 | 1403/12/13 |
| 1090 | 6.7.1 | Final Inspection & Releas note | 2d | 2025-03-02 | 2025-03-03 | 577, 990, 217, 232, 238 | 23d | 0d | 1403/12/12 | 1403/12/13 |
| 1091 | 6.8 | **E-100 Glycol reflux condenser COIL TYPE** | 2d | 2025-03-02 | 2025-03-03 |  | 23d |  | 1403/12/12 | 1403/12/13 |
| 1092 | 6.8.1 | Final Inspection & Releas note | 2d | 2025-03-02 | 2025-03-03 | 617, 1005, 217, 232, 238 | 23d | 0d | 1403/12/12 | 1403/12/13 |
| 1093 | 6.9 | **E -200 Rich-Lean HE** | 2d | 2025-03-02 | 2025-03-03 |  | 23d |  | 1403/12/12 | 1403/12/13 |
| 1094 | 6.9.1 | Final Inspection & Releas note | 2d | 2025-03-02 | 2025-03-03 | 700, 1037, 217, 232, 238 | 23d | 0d | 1403/12/12 | 1403/12/13 |
| 1095 | 6.10 | **E -300 LEAN TEG - DRY GAS EXCH** | 2d | 2025-03-02 | 2025-03-03 |  | 23d |  | 1403/12/12 | 1403/12/13 |
| 1096 | 6.10.1 | Final Inspection & Releas note | 2d | 2025-03-02 | 2025-03-03 | 743, 1053, 217, 232, 238 | 23d | 0d | 1403/12/12 | 1403/12/13 |
| 1097 | 6.11 | **V-130 Surge Tank** | 2d | 2025-03-02 | 2025-03-03 |  | 23d |  | 1403/12/12 | 1403/12/13 |
| 1098 | 6.11.1 | Final Inspection & Releas note | 2d | 2025-03-02 | 2025-03-03 | 660, 1020, 217, 232, 238 | 23d | 0d | 1403/12/12 | 1403/12/13 |
| 1099 | 6.12 | **R-100 Reboiler** | 2d | 2025-03-02 | 2025-03-03 |  | 23d |  | 1403/12/12 | 1403/12/13 |
| 1100 | 6.12.1 | Final Inspection & Releas note | 2d | 2025-03-02 | 2025-03-03 | 786, 1068, 217, 232, 238 | 23d | 0d | 1403/12/12 | 1403/12/13 |
| 1101 | 6.13 | **Skid of Gas Dehydration** | 2d | 2025-04-15 | 2025-04-16 |  | 0d |  | 1404/1/26 | 1404/1/27 |
| 1102 | 6.13.1 | Final Inspection & Releas note | 2d | 2025-04-15 | 2025-04-16 | 795, 1073, 217, 232, 238 | 0d |  | 1404/1/26 | 1404/1/27 |

| ID | WBS | Task | Duration | Start | Finish | Predecessors | Total slack | Free slack | شروع | پایان |
| --- | --- | --- | --- | --- | --- | --- | --- | --- | --- | --- |
| 1103 | 6.14 | **Piping of Gas Dehydration** | 2d | 2025-03-12 | 2025-03-13 |  | 14d |  | 1403/12/22 | 1403/12/23 |
| 1104 | 6.14.1 | Final Inspection & Releas note | 2d | 2025-03-12 | 2025-03-13 | 810, 217, 232, 238 | 14d | 0d | 1403/12/22 | 1403/12/23 |
| 1105 | 7 | **Ready for Shipment** | 25d | 2025-03-04 | 2025-04-19 |  | 2d |  | 1403/12/14 | 1404/1/30 |
| 1106 | 7.1 | **C-100 Glycol Contactor** | 2d | 2025-04-15 | 2025-04-16 |  | 4d |  | 1404/1/26 | 1404/1/27 |
| 1107 | 7.1.1 | Preparing and shipment | 2d | 2025-04-15 | 2025-04-16 | 1078 | 4d |  | 1404/1/26 | 1404/1/27 |
| 1108 | 7.2 | **C-200 Still Column** | 2d | 2025-03-04 | 2025-03-05 |  | 25d |  | 1403/12/14 | 1403/12/15 |
| 1109 | 7.2.1 | Preparing and shipment | 2d | 2025-03-04 | 2025-03-05 | 1080 | 25d |  | 1403/12/14 | 1403/12/15 |
| 1110 | 7.3 | **C-300 Stripping Column** | 2d | 2025-03-04 | 2025-03-05 |  | 25d |  | 1403/12/14 | 1403/12/15 |
| 1111 | 7.3.1 | Preparing and shipment | 2d | 2025-03-04 | 2025-03-05 | 1082 | 25d |  | 1403/12/14 | 1403/12/15 |
| 1112 | 7.4 | **V-120 Glycol Flash Drum** | 2d | 2025-03-04 | 2025-03-05 |  | 25d |  | 1403/12/14 | 1403/12/15 |
| 1113 | 7.4.1 | Preparing and shipment | 2d | 2025-03-04 | 2025-03-05 | 1084 | 25d |  | 1403/12/14 | 1403/12/15 |
| 1114 | 7.5 | **F-100A Particle Glycol Filter** | 2d | 2025-03-04 | 2025-03-05 |  | 25d |  | 1403/12/14 | 1403/12/15 |
| 1115 | 7.5.1 | Preparing and shipment | 2d | 2025-03-04 | 2025-03-05 | 1086 | 25d |  | 1403/12/14 | 1403/12/15 |
| 1116 | 7.6 | **F-100B Particle Glycol Filter** | 2d | 2025-03-04 | 2025-03-05 |  | 25d |  | 1403/12/14 | 1403/12/15 |
| 1117 | 7.6.1 | Preparing and shipment | 2d | 2025-03-04 | 2025-03-05 | 1088 | 25d |  | 1403/12/14 | 1403/12/15 |
| 1118 | 7.7 | **F-200 Carbon Glycol Filter** | 2d | 2025-03-04 | 2025-03-05 |  | 25d |  | 1403/12/14 | 1403/12/15 |
| 1119 | 7.7.1 | Preparing and shipment | 2d | 2025-03-04 | 2025-03-05 | 1090 | 25d |  | 1403/12/14 | 1403/12/15 |
| 1120 | 7.8 | **E-100 Glycol reflux condenser COIL TYPE** | 2d | 2025-03-04 | 2025-03-05 |  | 25d |  | 1403/12/14 | 1403/12/15 |
| 1121 | 7.8.1 | Preparing and shipment | 2d | 2025-03-04 | 2025-03-05 | 1092 | 25d |  | 1403/12/14 | 1403/12/15 |
| 1122 | 7.9 | **E -200 Rich-Lean HE** | 2d | 2025-03-04 | 2025-03-05 |  | 25d |  | 1403/12/14 | 1403/12/15 |
| 1123 | 7.9.1 | Preparing and shipment | 2d | 2025-03-04 | 2025-03-05 | 1094 | 25d |  | 1403/12/14 | 1403/12/15 |
| 1124 | 7.10 | **E -300 LEAN TEG - DRY GAS EXCH** | 2d | 2025-03-04 | 2025-03-05 |  | 25d |  | 1403/12/14 | 1403/12/15 |
| 1125 | 7.10.1 | Preparing and shipment | 2d | 2025-03-04 | 2025-03-05 | 1096 | 25d |  | 1403/12/14 | 1403/12/15 |
| 1126 | 7.11 | **V-130 Surge Tank** | 2d | 2025-03-04 | 2025-03-05 |  | 25d |  | 1403/12/14 | 1403/12/15 |
| 1127 | 7.11.1 | Preparing and shipment | 2d | 2025-03-04 | 2025-03-05 | 1098 | 25d |  | 1403/12/14 | 1403/12/15 |

| ID | WBS | Task | Duration | Start | Finish | Predecessors | Total slack | شروع | پایان |
| --- | --- | --- | --- | --- | --- | --- | --- | --- | --- |
| 1128 | 7.12 | **R-100 Reboiler** | 2d | 2025-03-04 | 2025-03-05 |  | 25d | 1403/12/14 | 1403/12/15 |
| 1129 | 7.12.1 | Preparing and shipment | 2d | 2025-03-04 | 2025-03-05 | 1100 | 25d | 1403/12/14 | 1403/12/15 |
| 1130 | 7.13 | **Skid of Gas Dehydration** | 2d | 2025-04-17 | 2025-04-19 |  | 2d | 1404/1/28 | 1404/1/30 |
| 1131 | 7.13.1 | Preparing and shipment | 2d | 2025-04-17 | 2025-04-19 | 1102 | 2d | 1404/1/28 | 1404/1/30 |
| 1132 | 7.14 | **Piping of Gas Dehydration** | 2d | 2025-03-15 | 2025-04-02 |  | 16d | 1403/12/25 | 1404/1/13 |
| 1133 | 7.14.1 | Preparing and shipment | 2d | 2025-03-15 | 2025-04-02 | 1104 | 16d | 1403/12/25 | 1404/1/13 |
| 1134 | 8 | **Final data book** | 6d | 2025-04-15 | 2025-04-21 |  | 0d | 1404/1/26 | 1404/2/1 |
| 1135 | 8.1 | Final data book | 6d | 2025-04-15 | 2025-04-21 | 1080SS, 1082SS, 1084SS, 1086SS, 1088SS, 1090SS, 1092SS, 1094SS, 1096SS, 1098SS, 1100SS, 1102SS, 1104SS, 15SS, 1078SS | 0d | 1404/1/26 | 1404/2/1 |
